# Learning Management System Implementation

How a schedule from MS Project changed from version to version. A marks actual dates.

## Version 1 (data date 2016-02-29, saved 2025-04-02, file 12.0 Project Exercise 10 - Learning Management System Implementation_ver8.0.mpp)

| ID | WBS | Task | Duration | Start | Finish | Predecessors | Complete | Total float | Constraint |
| --- | --- | --- | --- | --- | --- | --- | --- | --- | --- |
| 1 | 1 | **Planning Phase** | 34d | 2015-04-06 A | 2015-05-25 A |  | 100% |  |  |
| 2 |  | Strategic Objectives | 7d | 2015-04-06 A | 2015-04-14 A |  | 100% |  |  |
| 3 |  | Budgetary Objectives | 5d | 2015-04-15 A | 2015-04-21 A | 2 | 100% |  |  |
| 4 |  | Compliance and Regulatory requirements | 6d | 2015-04-22 A | 2015-04-29 A | 3 | 100% |  |  |
| 5 |  | Partners/Suppliers/Corporate Objectives | 2d | 2015-04-30 A | 2015-05-01 A | 4 | 100% |  |  |
| 6 |  | Doc: Strategic Objectives document | 7d | 2015-05-04 A | 2015-05-12 A | 5 | 100% |  |  |
| 7 |  | Review Objectives Document | 5d | 2015-05-13 A | 2015-05-19 A | 6 | 100% |  |  |
| 8 |  | Signoff Objectives | 4d | 2015-05-20 A | 2015-05-25 A | 7 | 100% |  |  |
| 9 |  | Milestone: Planning Complete | 0d | 2015-05-25 A | 2015-05-25 A | 8 | 100% |  |  |
| 10 | 2 | **Weekly Review Meeting** | 185.25d | 2015-06-01 A | 2016-02-29 A |  | 100% |  |  |
| 11 |  | Weekly Review Meeting 1 | 2h | 2015-06-01 A | 2015-06-01 A |  | 100% |  | start no earlier than 2015-06-01 |
| 12 |  | Weekly Review Meeting 2 | 2h | 2015-06-08 A | 2015-06-08 A |  | 100% |  | start no earlier than 2015-06-08 |
| 13 |  | Weekly Review Meeting 3 | 2h | 2015-06-15 A | 2015-06-15 A |  | 100% |  | start no earlier than 2015-06-15 |
| 14 |  | Weekly Review Meeting 4 | 2h | 2015-06-22 A | 2015-06-22 A |  | 100% |  | start no earlier than 2015-06-22 |
| 15 |  | Weekly Review Meeting 5 | 2h | 2015-06-29 A | 2015-06-29 A |  | 100% |  | start no earlier than 2015-06-29 |
| 16 |  | Weekly Review Meeting 6 | 2h | 2015-07-06 A | 2015-07-06 A |  | 100% |  | start no earlier than 2015-07-06 |
| 17 |  | Weekly Review Meeting 7 | 2h | 2015-07-13 A | 2015-07-13 A |  | 100% |  | start no earlier than 2015-07-13 |
| 18 |  | Weekly Review Meeting 8 | 2h | 2015-07-20 A | 2015-07-20 A |  | 100% |  | start no earlier than 2015-07-20 |
| 19 |  | Weekly Review Meeting 9 | 2h | 2015-07-27 A | 2015-07-27 A |  | 100% |  | start no earlier than 2015-07-27 |
| 20 |  | Weekly Review Meeting 10 | 2h | 2015-08-03 A | 2015-08-03 A |  | 100% |  | start no earlier than 2015-08-03 |
| 21 |  | Weekly Review Meeting 11 | 2h | 2015-08-10 A | 2015-08-10 A |  | 100% |  | start no earlier than 2015-08-10 |
| 22 |  | Weekly Review Meeting 12 | 2h | 2015-08-17 A | 2015-08-17 A |  | 100% |  | start no earlier than 2015-08-17 |
| 23 |  | Weekly Review Meeting 13 | 2h | 2015-08-24 A | 2015-08-24 A |  | 100% |  | start no earlier than 2015-08-24 |
| 24 |  | Weekly Review Meeting 14 | 2h | 2015-08-31 A | 2015-08-31 A |  | 100% |  | start no earlier than 2015-08-31 |
| 25 |  | Weekly Review Meeting 15 | 2h | 2015-09-08 A | 2015-09-08 A |  | 100% |  | start no earlier than 2015-09-07 |
| 26 |  | Weekly Review Meeting 16 | 2h | 2015-09-14 A | 2015-09-14 A |  | 100% |  | start no earlier than 2015-09-14 |
| 27 |  | Weekly Review Meeting 17 | 2h | 2015-09-21 A | 2015-09-21 A |  | 100% |  | start no earlier than 2015-09-21 |
| 28 |  | Weekly Review Meeting 18 | 2h | 2015-09-28 A | 2015-09-28 A |  | 100% |  | start no earlier than 2015-09-28 |
| 29 |  | Weekly Review Meeting 19 | 2h | 2015-10-05 A | 2015-10-05 A |  | 100% |  | start no earlier than 2015-10-05 |
| 30 |  | Weekly Review Meeting 20 | 2h | 2015-10-13 A | 2015-10-13 A |  | 100% |  | start no earlier than 2015-10-12 |
| 31 |  | Weekly Review Meeting 21 | 2h | 2015-10-19 A | 2015-10-19 A |  | 100% |  | start no earlier than 2015-10-19 |
| 32 |  | Weekly Review Meeting 22 | 2h | 2015-10-26 A | 2015-10-26 A |  | 100% |  | start no earlier than 2015-10-26 |
| 33 |  | Weekly Review Meeting 23 | 2h | 2015-11-02 A | 2015-11-02 A |  | 100% |  | start no earlier than 2015-11-02 |
| 34 |  | Weekly Review Meeting 24 | 2h | 2015-11-09 A | 2015-11-09 A |  | 100% |  | start no earlier than 2015-11-09 |
| 35 |  | Weekly Review Meeting 25 | 2h | 2015-11-16 A | 2015-11-16 A |  | 100% |  | start no earlier than 2015-11-16 |
| 36 |  | Weekly Review Meeting 26 | 2h | 2015-11-23 A | 2015-11-23 A |  | 100% |  | start no earlier than 2015-11-23 |
| 37 |  | Weekly Review Meeting 27 | 2h | 2015-11-30 A | 2015-11-30 A |  | 100% |  | start no earlier than 2015-11-30 |
| 38 |  | Weekly Review Meeting 28 | 2h | 2015-12-07 A | 2015-12-07 A |  | 100% |  | start no earlier than 2015-12-07 |
| 39 |  | Weekly Review Meeting 29 | 2h | 2015-12-14 A | 2015-12-14 A |  | 100% |  | start no earlier than 2015-12-14 |
| 40 |  | Weekly Review Meeting 30 | 2h | 2015-12-21 A | 2015-12-21 A |  | 100% |  | start no earlier than 2015-12-21 |
| 41 |  | Weekly Review Meeting 31 | 2h | 2015-12-28 A | 2015-12-28 A |  | 100% |  | start no earlier than 2015-12-28 |
| 42 |  | Weekly Review Meeting 32 | 2h | 2016-01-04 A | 2016-01-04 A |  | 100% |  | start no earlier than 2016-01-04 |
| 43 |  | Weekly Review Meeting 33 | 2h | 2016-01-11 A | 2016-01-11 A |  | 100% |  | start no earlier than 2016-01-11 |
| 44 |  | Weekly Review Meeting 34 | 2h | 2016-01-19 A | 2016-01-19 A |  | 100% |  | start no earlier than 2016-01-18 |
| 45 |  | Weekly Review Meeting 35 | 2h | 2016-01-25 A | 2016-01-25 A |  | 100% |  | start no earlier than 2016-01-25 |
| 46 |  | Weekly Review Meeting 36 | 2h | 2016-02-01 A | 2016-02-01 A |  | 100% |  | start no earlier than 2016-02-01 |
| 47 |  | Weekly Review Meeting 37 | 2h | 2016-02-08 A | 2016-02-08 A |  | 100% |  | start no earlier than 2016-02-08 |
| 48 |  | Weekly Review Meeting 38 | 2h | 2016-02-16 A | 2016-02-16 A |  | 100% |  | start no earlier than 2016-02-15 |
| 49 |  | Weekly Review Meeting 39 | 2h | 2016-02-22 A | 2016-02-22 A |  | 100% |  | start no earlier than 2016-02-22 |
| 50 |  | Weekly Review Meeting 40 | 2h | 2016-02-29 A | 2016-02-29 A |  | 100% |  | start no earlier than 2016-02-29 |
| 51 | 3 | **Detailed Design Phase** | 74d | 2015-05-26 A | 2015-09-08 |  | 99% | 163d |  |
| 52 |  | Technology Considerations | 3d | 2015-05-26 A | 2015-05-28 A | 9 | 100% |  |  |
| 53 |  | Integration Considerations | 6d | 2015-05-29 A | 2015-06-05 A | 52 | 100% |  |  |
| 54 |  | Non Functional Requirements | 6d | 2015-06-08 A | 2015-06-15 A | 53 | 100% |  |  |
| 55 |  | Administrative Needs and Roles | 7d | 2015-06-16 A | 2015-06-24 | 54 | 86% | 215d |  |
| 56 |  | RACI Matrix for LMS - Org wide | 4d | 2015-06-25 A | 2015-06-30 A | 55 | 100% |  |  |
| 57 |  | Content Strategy | 2.4w | 2015-07-01 A | 2015-07-16 A | 56 | 100% |  |  |
| 58 |  | Marketing Requirements | 1w | 2015-07-17 A | 2015-07-23 A | 57 | 100% |  |  |
| 59 |  | Deployment Plan (rollout to all colleges) | 1w | 2015-07-24 A | 2015-07-30 A | 58 | 100% |  |  |
| 60 |  | Doc: Functional Specification Document (FSD) | 1w | 2015-07-31 A | 2015-08-06 A | 59 | 100% |  |  |
| 61 |  | Review: FSD | 2d | 2015-08-07 A | 2015-08-10 A | 60 | 100% |  |  |
| 62 |  | Signoff: FSD | 2d | 2015-08-11 A | 2015-08-12 A | 61 | 100% |  |  |
| 63 |  | Doc: Technical Specifications Document (TSD) | 5d | 2015-08-13 A | 2015-08-19 A | 62 | 100% |  |  |
| 64 |  | Review: TSD | 2d | 2015-08-20 A | 2015-08-21 A | 63 | 100% |  |  |
| 65 |  | Signoff: TSD | 2d | 2015-08-24 A | 2015-08-25 A | 64 | 100% |  |  |
| 66 |  | Content Strategy Document (CSD) | 2w | 2015-08-26 A | 2015-09-08 A | 65 | 100% |  |  |
| 67 |  | Milestone: Detailed Design Complete | 0d | 2015-09-08 A | 2015-09-08 A | 66 | 100% |  |  |
| 68 | 4 | **Implementation Phase** | 88d | 2015-09-09 A | 2016-01-19 |  | 99% | 75d |  |
| 69 |  | Testing Server Setup | 2d | 2015-09-09 A | 2015-09-10 A | 67 | 100% |  |  |
| 70 |  | Development Server Setup | 2d | 2015-09-11 A | 2015-09-14 A | 69 | 100% |  |  |

| ID | WBS | Task | Duration | Start | Finish | Predecessors | Complete | Total float |
| --- | --- | --- | --- | --- | --- | --- | --- | --- |
| 71 |  | Install: Moodle Test installation | 1d | 2015-09-15 A | 2015-09-15 A | 70 | 100% |  |
| 72 |  | Database design | 5d | 2015-09-16 A | 2015-09-22 A | 71 | 100% |  |
| 73 |  | Doc: Upgrade Strategy Document (USD) | 5d | 2015-09-23 A | 2015-09-29 A | 72 | 100% |  |
| 74 | 4.6 | **Moodle: LMS Structure** | 21d | 2015-09-30 A | 2015-10-29 A |  | 100% |  |
| 75 |  | Home Page | 3d | 2015-09-30 A | 2015-10-02 A | 73 | 100% |  |
| 76 |  | Main Landing Page | 10d | 2015-10-05 A | 2015-10-16 A | 75 | 100% |  |
| 77 |  | Institution Landing Pages | 5d | 2015-10-19 A | 2015-10-23 A | 76 | 100% |  |
| 78 |  | Course Landing Pages | 4d | 2015-10-26 A | 2015-10-29 A | 77 | 100% |  |
| 79 | 4.7 | **Moodle: Course Design and Planning** | 11d | 2015-10-30 A | 2015-11-16 A |  | 100% |  |
| 80 |  | Courses Upload | 5d | 2015-10-30 A | 2015-11-05 A | 78 | 100% |  |
| 81 |  | Courses Structuring | 4d | 2015-11-06 A | 2015-11-11 A | 80 | 100% |  |
| 82 |  | Courses Support Material Upload | 3d | 2015-11-12 A | 2015-11-16 A | 81 | 100% |  |
| 83 | 4.8 | **Moodle: Course Creation** | 10d | 2015-11-17 A | 2015-12-02 A |  | 100% |  |
| 84 |  | Course Space Creation | 5d | 2015-11-17 A | 2015-11-23 A | 82 | 100% |  |
| 85 |  | Course Pages | 4d | 2015-11-24 A | 2015-11-27 A | 84 | 100% |  |
| 86 |  | Assessment Requirements | 3d | 2015-11-30 A | 2015-12-02 A | 85 | 100% |  |
| 87 | 4.9 | **Moodle: Performance and Control Considerations** | 13.25d | 2015-12-03 A | 2015-12-22 |  | 91% | 92.75d |
| 88 |  | Automated and Manual Communications setup | 6.25d | 2015-12-03 A | 2015-12-11 | 86 | 80% | 99.75d |
| 89 |  | Support Pages Configuration | 4d | 2015-12-11 A | 2015-12-17 A | 88 | 100% |  |
| 90 |  | Course Release Strategy | 3d | 2015-12-17 A | 2015-12-22 A | 89 | 100% |  |
| 91 | 4.10 | **LMS User Experience** | 33d | 2015-09-09 A | 2015-10-26 A |  | 100% |  |
| 92 |  | Doc: UX Design document (UXD) | 5d | 2015-09-09 A | 2015-09-15 A | 67 | 100% |  |
| 93 |  | Review: UXD | 2d | 2015-09-16 A | 2015-09-17 A | 92 | 100% |  |
| 94 |  | Signoff: UXD | 2d | 2015-09-18 A | 2015-09-21 A | 93 | 100% |  |
| 95 |  | Custom Theme Development | 2w | 2015-09-22 A | 2015-10-05 A | 94 | 100% |  |
| 96 |  | Department-wide custom themes | 1w | 2015-10-06 A | 2015-10-12 A | 95 | 100% |  |
| 97 |  | Logo and Branding requirements | 5d | 2015-10-13 A | 2015-10-19 A | 96 | 100% |  |
| 98 |  | Marketing UX reqts | 5d | 2015-10-20 A | 2015-10-26 A | 97 | 100% |  |
| 99 |  | Milestone: UX complete | 0d | 2015-10-26 A | 2015-10-26 A | 98 | 100% |  |
| 100 | 4.11 | **LMS Content Migration** | 88d | 2015-09-09 A | 2016-01-19 |  | 99% | 75d |
| 101 |  | Content Vendor Selection | 5d | 2015-09-09 A | 2015-09-15 A | 67 | 100% |  |
| 102 |  | Content Vendor Engage | 5d | 2015-09-16 A | 2015-09-22 A | 101 | 100% |  |
| 103 |  | Migrate SCORM Content | 10d | 2015-09-23 A | 2015-10-06 A | 102 | 100% |  |
| 104 |  | Vendor: New Content Creation | 60d | 2015-10-07 A | 2015-12-29 A | 103 | 100% |  |
| 105 |  | Vendor: New content Upload | 15d | 2015-12-30 A | 2016-01-19 A | 104 | 100% |  |
| 106 |  | Milestone: Migration done | 0d | 2016-01-19 | 2016-01-19 | 105 |  | 75d |
| 107 | 4.12 | **Mobile App Development** | 56d | 2015-09-30 A | 2015-12-22 A |  | 100% |  |
| 108 |  | Mobile Dev Vendor Selection | 1w | 2015-09-30 A | 2015-10-06 A | 67FS+15d | 100% |  |
| 109 |  | Requirements and signoff | 2w | 2015-10-07 A | 2015-10-20 A | 108 | 100% |  |
| 110 |  | Notifications | 4d | 2015-10-21 A | 2015-10-26 A | 109 | 100% |  |
| 111 |  | Calendar | 2d | 2015-10-27 A | 2015-10-28 A | 110 | 100% |  |
| 112 |  | Quiz Engine | 15d | 2015-10-29 A | 2015-11-18 A | 111 | 100% |  |
| 113 |  | Annual Time Table | 2d | 2015-11-19 A | 2015-11-20 A | 112 | 100% |  |
| 114 |  | Messaging | 1w | 2015-11-23 A | 2015-11-27 A | 113 | 100% |  |
| 115 |  | Social Integration | 2d | 2015-11-30 A | 2015-12-01 A | 114 | 100% |  |
| 116 |  | Usability Testing | 5d | 2015-12-02 A | 2015-12-08 A | 115 | 100% |  |
| 117 |  | Functional Testing | 5d | 2015-12-09 A | 2015-12-15 A | 116 | 100% |  |
| 118 |  | Integration testing | 5d | 2015-12-16 A | 2015-12-22 A | 117 | 100% |  |
| 119 |  | Milestone: Mobile dev complete | 0d | 2015-12-22 A | 2015-12-22 A | 118 | 100% |  |
| 120 | 4.13 | **Testing Plan and Setup** | 37d | 2015-10-22 A | 2015-12-16 A |  | 100% |  |
| 121 |  | Doc: Test Specification Document (TSD) | 3w | 2015-10-22 A | 2015-11-11 A | 67FS+30d | 100% |  |
| 122 |  | Test team setup | 5d | 2015-11-12 A | 2015-11-18 A | 121 | 100% |  |
| 123 |  | Review: TSD | 3d | 2015-11-19 A | 2015-11-23 A | 122 | 100% |  |
| 124 |  | Signoff: TSD | 2d | 2015-11-24 A | 2015-11-25 A | 123 | 100% |  |
| 125 |  | Content Test Strategy | 2w | 2015-11-26 A | 2015-12-09 A | 124 | 100% |  |
| 126 |  | Usability Test Strategy | 1w | 2015-12-10 A | 2015-12-16 A | 125 | 100% |  |
| 127 |  | Milestone: Implementation Complete | 0d | 2016-01-19 A | 2016-01-19 A | 126, 106, 119, 99 | 100% |  |
| 128 | 5 | **Integration Phase** | 53d | 2016-01-20 A | 2016-04-04 |  | 54% | 2d |
| 129 |  | Single Sign On (SSO) Setup | 3d | 2016-01-20 A | 2016-01-22 A | 127 | 100% |  |
| 130 |  | Student Information System (SIS) Setup | 5d | 2016-01-25 A | 2016-01-29 A | 129 | 100% |  |
| 131 |  | Datewarehousing Integration (Learning Analytics) | 10d | 2016-02-01 A | 2016-02-12 A | 130 | 100% |  |
| 132 |  | SAP Integration | 15d | 2016-02-15 A | 2016-03-04 | 131 | 73% | 2d |
| 133 |  | Accounting Software Setup | 5d | 2016-03-07 | 2016-03-11 | 132 |  | 2d |
| 134 | 5.6 | **STAGING SERVER SETUP** | 16d | 2016-03-14 | 2016-04-04 |  |  | 2d |
| 135 |  | Server setup, Redundancy setup | 3d | 2016-03-14 | 2016-03-16 | 133 |  | 2d |
| 136 |  | Database Configuration | 3d | 2016-03-17 | 2016-03-21 | 135 |  | 2d |
| 137 |  | LMS Installation | 2d | 2016-03-22 | 2016-03-23 | 136 |  | 2d |
| 138 |  | Course Data Migration | 3d | 2016-03-24 | 2016-03-28 | 137 |  | 2d |
| 139 |  | Student Data Import | 3d | 2016-03-29 | 2016-03-31 | 138 |  | 2d |
| 140 |  | RBAC Setup and testing | 2d | 2016-04-01 | 2016-04-04 | 139 |  | 2d |

| ID | WBS | Task | Duration | Start | Finish | Predecessors | Complete | Total float |
| --- | --- | --- | --- | --- | --- | --- | --- | --- |
| 141 |  | Milestone: Integration Phase Complete | 0d | 2016-04-04 | 2016-04-04 | 140 |  | 2d |
| 142 | 6 | **VERIFICATION and STAGING** | 117d | 2015-11-02 A | 2016-04-22 |  | 69% | 9d |
| 143 |  | Unit Testing of all modules | 2mo | 2015-11-02 A | 2015-12-25 A | 68SS+2.5% | 100% |  |
| 144 |  | Functional Testing | 3w | 2015-12-28 A | 2016-01-15 A | 143 | 100% |  |
| 145 |  | Installation and Deploy Testing | 2w | 2016-01-18 A | 2016-01-29 A | 144 | 100% |  |
| 146 |  | Performance Testing | 2w | 2016-02-01 A | 2016-02-12 A | 145 | 100% |  |
| 147 |  | Usability Testing | 2w | 2016-02-15 A | 2016-02-26 A | 146 | 100% |  |
| 148 |  | Alpha Testing | 2w | 2016-02-29 A | 2016-03-11 | 147 | 10% | 9d |
| 149 |  | UAT Scripting | 2w | 2016-03-14 | 2016-03-25 | 148 |  | 9d |
| 150 |  | UAT cases review and approval | 2w | 2016-03-28 | 2016-04-08 | 149 |  | 8d |
| 151 |  | User Acceptance Testing | 2w | 2016-04-11 | 2016-04-22 | 150 |  | 8d |
| 152 |  | Milestone: Testing Complete | 0d | 2016-04-22 | 2016-04-22 | 151 |  | 9d |
| 153 | 7 | **PRODUCTION DEPLOYMENT** | 20d | 2016-04-05 | 2016-05-03 |  |  | 2d |
| 154 |  | Hardware, Software, Database Setup, Configuration | 5d | 2016-04-05 | 2016-04-11 | 141 |  | 2d |
| 155 |  | Course Data Migration | 6d | 2016-04-12 | 2016-04-19 | 154 |  | 2d |
| 156 |  | Student Data Migration | 4d | 2016-04-20 | 2016-04-25 | 155 |  | 2d |
| 157 |  | Course Creation - all Colleges | 5d | 2016-04-26 | 2016-05-02 | 156 |  | 2d |
| 158 |  | Roles and Accounts | 1d | 2016-05-03 | 2016-05-03 | 157 |  | 2d |
| 159 |  | Milestone: Prod Deploy Complete | 0d | 2016-05-03 | 2016-05-03 | 158 |  | 2d |
| 160 | 8 | **Maintenance Handover** | 55d | 2016-02-18 A | 2016-05-05 |  | 13% | 0d |
| 161 |  | Training Calendar | 3d | 2016-02-18 A | 2016-02-22 A | 129SS+20d | 100% |  |
| 162 |  | Maintenance Vendor Selection | 20d | 2016-02-23 A | 2016-03-21 | 161 | 25% | 0d |
| 163 |  | Maintenance Vendor Engagement | 5d | 2016-03-22 | 2016-03-28 | 162 |  | 0d |
| 164 |  | User Manual | 10d | 2016-03-29 | 2016-04-11 | 163 |  | 0d |
| 165 |  | Administration Manual | 10d | 2016-04-12 | 2016-04-25 | 164 |  | 0d |
| 166 |  | Techno Functional Handover | 3d | 2016-04-26 | 2016-04-28 | 165 |  | 0d |
| 167 |  | Training Org Wide | 5d | 2016-04-29 | 2016-05-05 | 166 |  | 0d |
| 168 | 8.8 | **BUGZILLA** | 5d | 2016-04-29 | 2016-05-05 |  |  | 0d |
| 169 |  | Issue Tracking BUGZILLA installation | 2d | 2016-04-29 | 2016-05-02 | 166 |  | 0d |
| 170 |  | Bugzilla accounts, training and access handover | 3d | 2016-05-03 | 2016-05-05 | 169 |  | 0d |
| 171 |  | Milestone: Project Complete | 0d | 2016-05-05 | 2016-05-05 | 170 |  | 0d |

## Version 2 (saved 2025-04-02, file 12.0 Project Exercise 10 - Learning Management System Implementation_ver1.0.mpp)

Last finish 2016-05-05 → 2017-04-28 (+358d). Complete tasks 121 → 0.

Changed:

| ID | Task | Start | Finish | Duration | Complete | Total float | Other |
| --- | --- | --- | --- | --- | --- | --- | --- |
| 1 | **Planning Phase** | 2015-04-06 A → 2016-04-12 (+372d) | 2015-05-25 A → 2016-05-30 (+371d) | 34d → 35d | 100% → 0% | none → 0d | baseline start 2015-04-06 → none; baseline finish 2015-05-22 → none |
| 2 | Strategic Objectives | 2015-04-06 A → 2016-04-12 (+372d) | 2015-04-14 A → 2016-04-20 (+372d) |  | 100% → 0% | none → 0d | baseline start 2015-04-06 → none; baseline finish 2015-04-14 → none |
| 3 | Budgetary Objectives | 2015-04-15 A → 2016-04-21 (+372d) | 2015-04-21 A → 2016-04-27 (+372d) |  | 100% → 0% | none → 0d | baseline start 2015-04-15 → none; baseline finish 2015-04-21 → none |
| 4 | Compliance and Regulatory requirements | 2015-04-22 A → 2016-04-28 (+372d) | 2015-04-29 A → 2016-05-05 (+372d) |  | 100% → 0% | none → 0d | baseline start 2015-04-22 → none; baseline finish 2015-04-29 → none |
| 5 | Partners/Suppliers/Corporate Objectives | 2015-04-30 A → 2016-05-06 (+372d) | 2015-05-01 A → 2016-05-09 (+374d) |  | 100% → 0% | none → 0d | baseline start 2015-04-30 → none; baseline finish 2015-05-01 → none |
| 6 | Doc: Strategic Objectives document | 2015-05-04 A → 2016-05-10 (+372d) | 2015-05-12 A → 2016-05-18 (+372d) |  | 100% → 0% | none → 0d | baseline start 2015-05-04 → none; baseline finish 2015-05-12 → none |
| 7 | Review Objectives Document | 2015-05-13 A → 2016-05-19 (+372d) | 2015-05-19 A → 2016-05-25 (+372d) |  | 100% → 0% | none → 0d | baseline start 2015-05-13 → none; baseline finish 2015-05-19 → none |
| 8 | Signoff Objectives | 2015-05-20 A → 2016-05-26 (+372d) | 2015-05-25 A → 2016-05-30 (+371d) | 4d → 3d | 100% → 0% | none → 0d | baseline start 2015-05-20 → none; baseline finish 2015-05-22 → none |
| 9 | Milestone: Planning Complete | 2015-05-25 A → 2016-05-30 (+371d) | 2015-05-25 A → 2016-05-30 (+371d) |  | 100% → 0% | none → 0d | baseline start 2015-05-22 → none; baseline finish 2015-05-22 → none |
| 10 | **Weekly Review Meeting** | 2015-06-01 A → 2016-06-06 (+371d) | 2016-02-29 A → 2017-03-06 (+371d) | 185.25d → 195.25d | 100% → 0% | none → 39.75d | baseline start 2015-06-01 → none; baseline finish 2016-02-29 → none |
| 11 | Weekly Review Meeting 1 | 2015-06-01 A → 2016-06-06 (+371d) | 2015-06-01 A → 2016-06-06 (+371d) |  | 100% → 0% | none → 234.75d | constraint start no earlier than 2015-06-01 → start no earlier than 2016-06-06; baseline start 2015-06-01 → none; baseline finish 2015-06-01 → none |
| 12 | Weekly Review Meeting 2 | 2015-06-08 A → 2016-06-13 (+371d) | 2015-06-08 A → 2016-06-13 (+371d) |  | 100% → 0% | none → 229.75d | constraint start no earlier than 2015-06-08 → start no earlier than 2016-06-13; baseline start 2015-06-08 → none; baseline finish 2015-06-08 → none |
| 13 | Weekly Review Meeting 3 | 2015-06-15 A → 2016-06-20 (+371d) | 2015-06-15 A → 2016-06-20 (+371d) |  | 100% → 0% | none → 224.75d | constraint start no earlier than 2015-06-15 → start no earlier than 2016-06-20; baseline start 2015-06-15 → none; baseline finish 2015-06-15 → none |
| 14 | Weekly Review Meeting 4 | 2015-06-22 A → 2016-06-27 (+371d) | 2015-06-22 A → 2016-06-27 (+371d) |  | 100% → 0% | none → 219.75d | constraint start no earlier than 2015-06-22 → start no earlier than 2016-06-27; baseline start 2015-06-22 → none; baseline finish 2015-06-22 → none |
| 15 | Weekly Review Meeting 5 | 2015-06-29 A → 2016-07-04 (+371d) | 2015-06-29 A → 2016-07-04 (+371d) |  | 100% → 0% | none → 214.75d | constraint start no earlier than 2015-06-29 → start no earlier than 2016-07-04; baseline start 2015-06-29 → none; baseline finish 2015-06-29 → none |
| 16 | Weekly Review Meeting 6 | 2015-07-06 A → 2016-07-11 (+371d) | 2015-07-06 A → 2016-07-11 (+371d) |  | 100% → 0% | none → 209.75d | constraint start no earlier than 2015-07-06 → start no earlier than 2016-07-11; baseline start 2015-07-06 → none; baseline finish 2015-07-06 → none |
| 17 | Weekly Review Meeting 7 | 2015-07-13 A → 2016-07-18 (+371d) | 2015-07-13 A → 2016-07-18 (+371d) |  | 100% → 0% | none → 204.75d | constraint start no earlier than 2015-07-13 → start no earlier than 2016-07-18; baseline start 2015-07-13 → none; baseline finish 2015-07-13 → none |
| 18 | Weekly Review Meeting 8 | 2015-07-20 A → 2016-07-25 (+371d) | 2015-07-20 A → 2016-07-25 (+371d) |  | 100% → 0% | none → 199.75d | constraint start no earlier than 2015-07-20 → start no earlier than 2016-07-25; baseline start 2015-07-20 → none; baseline finish 2015-07-20 → none |
| 19 | Weekly Review Meeting 9 | 2015-07-27 A → 2016-08-01 (+371d) | 2015-07-27 A → 2016-08-01 (+371d) |  | 100% → 0% | none → 194.75d | constraint start no earlier than 2015-07-27 → start no earlier than 2016-08-01; baseline start 2015-07-27 → none; baseline finish 2015-07-27 → none |
| 20 | Weekly Review Meeting 10 | 2015-08-03 A → 2016-08-08 (+371d) | 2015-08-03 A → 2016-08-08 (+371d) |  | 100% → 0% | none → 189.75d | constraint start no earlier than 2015-08-03 → start no earlier than 2016-08-08; baseline start 2015-08-03 → none; baseline finish 2015-08-03 → none |
| 21 | Weekly Review Meeting 11 | 2015-08-10 A → 2016-08-15 (+371d) | 2015-08-10 A → 2016-08-15 (+371d) |  | 100% → 0% | none → 184.75d | constraint start no earlier than 2015-08-10 → start no earlier than 2016-08-15; baseline start 2015-08-10 → none; baseline finish 2015-08-10 → none |
| 22 | Weekly Review Meeting 12 | 2015-08-17 A → 2016-08-22 (+371d) | 2015-08-17 A → 2016-08-22 (+371d) |  | 100% → 0% | none → 179.75d | constraint start no earlier than 2015-08-17 → start no earlier than 2016-08-22; baseline start 2015-08-17 → none; baseline finish 2015-08-17 → none |
| 23 | Weekly Review Meeting 13 | 2015-08-24 A → 2016-08-29 (+371d) | 2015-08-24 A → 2016-08-29 (+371d) |  | 100% → 0% | none → 174.75d | constraint start no earlier than 2015-08-24 → start no earlier than 2016-08-29; baseline start 2015-08-24 → none; baseline finish 2015-08-24 → none |
| 24 | Weekly Review Meeting 14 | 2015-08-31 A → 2016-09-05 (+371d) | 2015-08-31 A → 2016-09-05 (+371d) |  | 100% → 0% | none → 169.75d | constraint start no earlier than 2015-08-31 → start no earlier than 2016-09-05; baseline start 2015-08-31 → none; baseline finish 2015-08-31 → none |
| 25 | Weekly Review Meeting 15 | 2015-09-08 A → 2016-09-12 (+370d) | 2015-09-08 A → 2016-09-12 (+370d) |  | 100% → 0% | none → 164.75d | constraint start no earlier than 2015-09-07 → start no earlier than 2016-09-12; baseline start 2015-09-08 → none; baseline finish 2015-09-08 → none |
| 26 | Weekly Review Meeting 16 | 2015-09-14 A → 2016-09-19 (+371d) | 2015-09-14 A → 2016-09-19 (+371d) |  | 100% → 0% | none → 159.75d | constraint start no earlier than 2015-09-14 → start no earlier than 2016-09-19; baseline start 2015-09-14 → none; baseline finish 2015-09-14 → none |
| 27 | Weekly Review Meeting 17 | 2015-09-21 A → 2016-09-26 (+371d) | 2015-09-21 A → 2016-09-26 (+371d) |  | 100% → 0% | none → 154.75d | constraint start no earlier than 2015-09-21 → start no earlier than 2016-09-26; baseline start 2015-09-21 → none; baseline finish 2015-09-21 → none |
| 28 | Weekly Review Meeting 18 | 2015-09-28 A → 2016-10-03 (+371d) | 2015-09-28 A → 2016-10-03 (+371d) |  | 100% → 0% | none → 149.75d | constraint start no earlier than 2015-09-28 → start no earlier than 2016-10-03; baseline start 2015-09-28 → none; baseline finish 2015-09-28 → none |
| 29 | Weekly Review Meeting 19 | 2015-10-05 A → 2016-10-10 (+371d) | 2015-10-05 A → 2016-10-10 (+371d) |  | 100% → 0% | none → 144.75d | constraint start no earlier than 2015-10-05 → start no earlier than 2016-10-10; baseline start 2015-10-05 → none; baseline finish 2015-10-05 → none |
| 30 | Weekly Review Meeting 20 | 2015-10-13 A → 2016-10-17 (+370d) | 2015-10-13 A → 2016-10-17 (+370d) |  | 100% → 0% | none → 139.75d | constraint start no earlier than 2015-10-12 → start no earlier than 2016-10-17; baseline start 2015-10-13 → none; baseline finish 2015-10-13 → none |
| 31 | Weekly Review Meeting 21 | 2015-10-19 A → 2016-10-24 (+371d) | 2015-10-19 A → 2016-10-24 (+371d) |  | 100% → 0% | none → 134.75d | constraint start no earlier than 2015-10-19 → start no earlier than 2016-10-24; baseline start 2015-10-19 → none; baseline finish 2015-10-19 → none |
| 32 | Weekly Review Meeting 22 | 2015-10-26 A → 2016-10-31 (+371d) | 2015-10-26 A → 2016-10-31 (+371d) |  | 100% → 0% | none → 129.75d | constraint start no earlier than 2015-10-26 → start no earlier than 2016-10-31; baseline start 2015-10-26 → none; baseline finish 2015-10-26 → none |
| 33 | Weekly Review Meeting 23 | 2015-11-02 A → 2016-11-07 (+371d) | 2015-11-02 A → 2016-11-07 (+371d) |  | 100% → 0% | none → 124.75d | constraint start no earlier than 2015-11-02 → start no earlier than 2016-11-07; baseline start 2015-11-02 → none; baseline finish 2015-11-02 → none |
| 34 | Weekly Review Meeting 24 | 2015-11-09 A → 2016-11-14 (+371d) | 2015-11-09 A → 2016-11-14 (+371d) |  | 100% → 0% | none → 119.75d | constraint start no earlier than 2015-11-09 → start no earlier than 2016-11-14; baseline start 2015-11-09 → none; baseline finish 2015-11-09 → none |
| 35 | Weekly Review Meeting 25 | 2015-11-16 A → 2016-11-21 (+371d) | 2015-11-16 A → 2016-11-21 (+371d) |  | 100% → 0% | none → 114.75d | constraint start no earlier than 2015-11-16 → start no earlier than 2016-11-21; baseline start 2015-11-16 → none; baseline finish 2015-11-16 → none |
| 36 | Weekly Review Meeting 26 | 2015-11-23 A → 2016-11-28 (+371d) | 2015-11-23 A → 2016-11-28 (+371d) |  | 100% → 0% | none → 109.75d | constraint start no earlier than 2015-11-23 → start no earlier than 2016-11-28; baseline start 2015-11-23 → none; baseline finish 2015-11-23 → none |
| 37 | Weekly Review Meeting 27 | 2015-11-30 A → 2016-12-05 (+371d) | 2015-11-30 A → 2016-12-05 (+371d) |  | 100% → 0% | none → 104.75d | constraint start no earlier than 2015-11-30 → start no earlier than 2016-12-05; baseline start 2015-11-30 → none; baseline finish 2015-11-30 → none |
| 38 | Weekly Review Meeting 28 | 2015-12-07 A → 2016-12-12 (+371d) | 2015-12-07 A → 2016-12-12 (+371d) |  | 100% → 0% | none → 99.75d | constraint start no earlier than 2015-12-07 → start no earlier than 2016-12-12; baseline start 2015-12-07 → none; baseline finish 2015-12-07 → none |
| 39 | Weekly Review Meeting 29 | 2015-12-14 A → 2016-12-19 (+371d) | 2015-12-14 A → 2016-12-19 (+371d) |  | 100% → 0% | none → 94.75d | constraint start no earlier than 2015-12-14 → start no earlier than 2016-12-19; baseline start 2015-12-14 → none; baseline finish 2015-12-14 → none |
| 40 | Weekly Review Meeting 30 | 2015-12-21 A → 2016-12-26 (+371d) | 2015-12-21 A → 2016-12-26 (+371d) |  | 100% → 0% | none → 89.75d | constraint start no earlier than 2015-12-21 → start no earlier than 2016-12-26; baseline start 2015-12-21 → none; baseline finish 2015-12-21 → none |
| 41 | Weekly Review Meeting 31 | 2015-12-28 A → 2017-01-02 (+371d) | 2015-12-28 A → 2017-01-02 (+371d) |  | 100% → 0% | none → 84.75d | constraint start no earlier than 2015-12-28 → start no earlier than 2017-01-02; baseline start 2015-12-28 → none; baseline finish 2015-12-28 → none |
| 42 | Weekly Review Meeting 32 | 2016-01-04 A → 2017-01-09 (+371d) | 2016-01-04 A → 2017-01-09 (+371d) |  | 100% → 0% | none → 79.75d | constraint start no earlier than 2016-01-04 → start no earlier than 2017-01-09; baseline start 2016-01-04 → none; baseline finish 2016-01-04 → none |
| 43 | Weekly Review Meeting 33 | 2016-01-11 A → 2017-01-16 (+371d) | 2016-01-11 A → 2017-01-16 (+371d) |  | 100% → 0% | none → 74.75d | constraint start no earlier than 2016-01-11 → start no earlier than 2017-01-16; baseline start 2016-01-11 → none; baseline finish 2016-01-11 → none |
| 44 | Weekly Review Meeting 34 | 2016-01-19 A → 2017-01-23 (+370d) | 2016-01-19 A → 2017-01-23 (+370d) |  | 100% → 0% | none → 69.75d | constraint start no earlier than 2016-01-18 → start no earlier than 2017-01-23; baseline start 2016-01-19 → none; baseline finish 2016-01-19 → none |
| 45 | Weekly Review Meeting 35 | 2016-01-25 A → 2017-01-30 (+371d) | 2016-01-25 A → 2017-01-30 (+371d) |  | 100% → 0% | none → 64.75d | constraint start no earlier than 2016-01-25 → start no earlier than 2017-01-30; baseline start 2016-01-25 → none; baseline finish 2016-01-25 → none |
| 46 | Weekly Review Meeting 36 | 2016-02-01 A → 2017-02-06 (+371d) | 2016-02-01 A → 2017-02-06 (+371d) |  | 100% → 0% | none → 59.75d | constraint start no earlier than 2016-02-01 → start no earlier than 2017-02-06; baseline start 2016-02-01 → none; baseline finish 2016-02-01 → none |
| 47 | Weekly Review Meeting 37 | 2016-02-08 A → 2017-02-13 (+371d) | 2016-02-08 A → 2017-02-13 (+371d) |  | 100% → 0% | none → 54.75d | constraint start no earlier than 2016-02-08 → start no earlier than 2017-02-13; baseline start 2016-02-08 → none; baseline finish 2016-02-08 → none |
| 48 | Weekly Review Meeting 38 | 2016-02-16 A → 2017-02-20 (+370d) | 2016-02-16 A → 2017-02-20 (+370d) |  | 100% → 0% | none → 49.75d | constraint start no earlier than 2016-02-15 → start no earlier than 2017-02-20; baseline start 2016-02-16 → none; baseline finish 2016-02-16 → none |
| 49 | Weekly Review Meeting 39 | 2016-02-22 A → 2017-02-27 (+371d) | 2016-02-22 A → 2017-02-27 (+371d) |  | 100% → 0% | none → 44.75d | constraint start no earlier than 2016-02-22 → start no earlier than 2017-02-27; baseline start 2016-02-22 → none; baseline finish 2016-02-22 → none |
| 50 | Weekly Review Meeting 40 | 2016-02-29 A → 2017-03-06 (+371d) | 2016-02-29 A → 2017-03-06 (+371d) |  | 100% → 0% | none → 39.75d | constraint start no earlier than 2016-02-29 → start no earlier than 2017-03-06; baseline start 2016-02-29 → none; baseline finish 2016-02-29 → none |
| 51 | **Detailed Design Phase** | 2015-05-26 A → 2016-05-31 (+371d) | 2015-09-08 → 2016-09-08 (+366d) | 74d → 73d | 99% → 0% | 163d → 0d | baseline start 2015-05-25 → none; baseline finish 2015-09-02 → none |
| 52 | Technology Considerations | 2015-05-26 A → 2016-05-31 (+371d) | 2015-05-28 A → 2016-06-02 (+371d) |  | 100% → 0% | none → 0d | baseline start 2015-05-25 → none; baseline finish 2015-05-27 → none |
| 53 | Integration Considerations | 2015-05-29 A → 2016-06-03 (+371d) | 2015-06-05 A → 2016-06-10 (+371d) |  | 100% → 0% | none → 0d | baseline start 2015-05-28 → none; baseline finish 2015-06-04 → none |
| 54 | Non Functional Requirements | 2015-06-08 A → 2016-06-13 (+371d) | 2015-06-15 A → 2016-06-20 (+371d) |  | 100% → 0% | none → 0d | baseline start 2015-06-05 → none; baseline finish 2015-06-12 → none |
| 55 | Administrative Needs and Roles | 2015-06-16 A → 2016-06-21 (+371d) | 2015-06-24 → 2016-06-24 (+366d) | 7d → 4d | 86% → 0% | 215d → 0d | baseline start 2015-06-15 → none; baseline finish 2015-06-18 → none |
| 56 | RACI Matrix for LMS - Org wide | 2015-06-25 A → 2016-06-27 (+368d) | 2015-06-30 A → 2016-07-04 (+370d) | 4d → 6d | 100% → 0% | none → 0d | baseline start 2015-06-19 → none; baseline finish 2015-06-26 → none |
| 57 | Content Strategy | 2015-07-01 A → 2016-07-05 (+370d) | 2015-07-16 A → 2016-07-18 (+368d) | 2.4w → 2w | 100% → 0% | none → 0d | baseline start 2015-06-29 → none; baseline finish 2015-07-10 → none |
| 58 | Marketing Requirements | 2015-07-17 A → 2016-07-19 (+368d) | 2015-07-23 A → 2016-07-25 (+368d) |  | 100% → 0% | none → 0d | baseline start 2015-07-13 → none; baseline finish 2015-07-17 → none |
| 59 | Deployment Plan (rollout to all colleges) | 2015-07-24 A → 2016-07-26 (+368d) | 2015-07-30 A → 2016-08-01 (+368d) |  | 100% → 0% | none → 0d | baseline start 2015-07-20 → none; baseline finish 2015-07-24 → none |
| 60 | Doc: Functional Specification Document (FSD) | 2015-07-31 A → 2016-08-02 (+368d) | 2015-08-06 A → 2016-08-08 (+368d) |  | 100% → 0% | none → 0d | baseline start 2015-07-27 → none; baseline finish 2015-07-31 → none |
| 61 | Review: FSD | 2015-08-07 A → 2016-08-09 (+368d) | 2015-08-10 A → 2016-08-10 (+366d) |  | 100% → 0% | none → 0d | baseline start 2015-08-03 → none; baseline finish 2015-08-04 → none |
| 62 | Signoff: FSD | 2015-08-11 A → 2016-08-11 (+366d) | 2015-08-12 A → 2016-08-12 (+366d) |  | 100% → 0% | none → 0d | baseline start 2015-08-05 → none; baseline finish 2015-08-06 → none |
| 63 | Doc: Technical Specifications Document (TSD) | 2015-08-13 A → 2016-08-15 (+368d) | 2015-08-19 A → 2016-08-19 (+366d) |  | 100% → 0% | none → 0d | baseline start 2015-08-07 → none; baseline finish 2015-08-13 → none |
| 64 | Review: TSD | 2015-08-20 A → 2016-08-22 (+368d) | 2015-08-21 A → 2016-08-23 (+368d) |  | 100% → 0% | none → 0d | baseline start 2015-08-14 → none; baseline finish 2015-08-17 → none |
| 65 | Signoff: TSD | 2015-08-24 A → 2016-08-24 (+366d) | 2015-08-25 A → 2016-08-25 (+366d) |  | 100% → 0% | none → 0d | baseline start 2015-08-18 → none; baseline finish 2015-08-19 → none |
| 66 | Content Strategy Document (CSD) | 2015-08-26 A → 2016-08-26 (+366d) | 2015-09-08 A → 2016-09-08 (+366d) |  | 100% → 0% | none → 0d | baseline start 2015-08-20 → none; baseline finish 2015-09-02 → none |
| 67 | Milestone: Detailed Design Complete | 2015-09-08 A → 2016-09-08 (+366d) | 2015-09-08 A → 2016-09-08 (+366d) |  | 100% → 0% | none → 0d | baseline start 2015-09-02 → none; baseline finish 2015-09-02 → none |
| 68 | **Implementation Phase** | 2015-09-09 A → 2016-09-09 (+366d) | 2016-01-19 → 2017-01-12 (+359d) | 88d → 90d | 99% → 0% | 75d → 0d | baseline start 2015-09-03 → none; baseline finish 2016-01-06 → none |
| 69 | Testing Server Setup | 2015-09-09 A → 2016-09-09 (+366d) | 2015-09-10 A → 2016-09-12 (+368d) |  | 100% → 0% | none → 95d | baseline start 2015-09-03 → none; baseline finish 2015-09-04 → none |
| 70 | Development Server Setup | 2015-09-11 A → 2016-09-13 (+368d) | 2015-09-14 A → 2016-09-14 (+366d) |  | 100% → 0% | none → 95d | baseline start 2015-09-07 → none; baseline finish 2015-09-08 → none |

| ID | Task | Start | Finish | Duration | Complete | Total float | Other |
| --- | --- | --- | --- | --- | --- | --- | --- |
| 71 | Install: Moodle Test installation | 2015-09-15 A → 2016-09-15 (+366d) | 2015-09-15 A → 2016-09-15 (+366d) |  | 100% → 0% | none → 95d | baseline start 2015-09-09 → none; baseline finish 2015-09-09 → none |
| 72 | Database design | 2015-09-16 A → 2016-09-16 (+366d) | 2015-09-22 A → 2016-09-22 (+366d) |  | 100% → 0% | none → 95d | baseline start 2015-09-10 → none; baseline finish 2015-09-16 → none |
| 73 | Doc: Upgrade Strategy Document (USD) | 2015-09-23 A → 2016-09-23 (+366d) | 2015-09-29 A → 2016-09-29 (+366d) |  | 100% → 0% | none → 95d | baseline start 2015-09-17 → none; baseline finish 2015-09-23 → none |
| 74 | **Moodle: LMS Structure** | 2015-09-30 A → 2016-09-30 (+366d) | 2015-10-29 A → 2016-10-27 (+364d) | 21d → 20d | 100% → 0% | none → 95d | baseline start 2015-09-24 → none; baseline finish 2015-10-21 → none |
| 75 | Home Page | 2015-09-30 A → 2016-09-30 (+366d) | 2015-10-02 A → 2016-10-04 (+368d) |  | 100% → 0% | none → 95d | baseline start 2015-09-24 → none; baseline finish 2015-09-28 → none |
| 76 | Main Landing Page | 2015-10-05 A → 2016-10-05 (+366d) | 2015-10-16 A → 2016-10-14 (+364d) | 10d → 8d | 100% → 0% | none → 95d | baseline start 2015-09-29 → none; baseline finish 2015-10-08 → none |
| 77 | Institution Landing Pages | 2015-10-19 A → 2016-10-17 (+364d) | 2015-10-23 A → 2016-10-21 (+364d) |  | 100% → 0% | none → 95d | baseline start 2015-10-09 → none; baseline finish 2015-10-15 → none |
| 78 | Course Landing Pages | 2015-10-26 A → 2016-10-24 (+364d) | 2015-10-29 A → 2016-10-27 (+364d) |  | 100% → 0% | none → 95d | baseline start 2015-10-16 → none; baseline finish 2015-10-21 → none |
| 79 | **Moodle: Course Design and Planning** | 2015-10-30 A → 2016-10-28 (+364d) | 2015-11-16 A → 2016-11-14 (+364d) | 11d → 12d | 100% → 0% | none → 95d | baseline start 2015-10-22 → none; baseline finish 2015-11-06 → none |
| 80 | Courses Upload | 2015-10-30 A → 2016-10-28 (+364d) | 2015-11-05 A → 2016-11-03 (+364d) |  | 100% → 0% | none → 95d | baseline start 2015-10-22 → none; baseline finish 2015-10-28 → none |
| 81 | Courses Structuring | 2015-11-06 A → 2016-11-04 (+364d) | 2015-11-11 A → 2016-11-09 (+364d) |  | 100% → 0% | none → 95d | baseline start 2015-10-29 → none; baseline finish 2015-11-03 → none |
| 82 | Courses Support Material Upload | 2015-11-12 A → 2016-11-10 (+364d) | 2015-11-16 A → 2016-11-14 (+364d) |  | 100% → 0% | none → 95d | baseline start 2015-11-04 → none; baseline finish 2015-11-06 → none |
| 83 | **Moodle: Course Creation** | 2015-11-17 A → 2016-11-15 (+364d) | 2015-12-02 A → 2016-11-30 (+364d) | 10d → 12d | 100% → 0% | none → 95d | baseline start 2015-11-09 → none; baseline finish 2015-11-24 → none |
| 84 | Course Space Creation | 2015-11-17 A → 2016-11-15 (+364d) | 2015-11-23 A → 2016-11-21 (+364d) |  | 100% → 0% | none → 95d | baseline start 2015-11-09 → none; baseline finish 2015-11-13 → none |
| 85 | Course Pages | 2015-11-24 A → 2016-11-22 (+364d) | 2015-11-27 A → 2016-11-25 (+364d) |  | 100% → 0% | none → 95d | baseline start 2015-11-16 → none; baseline finish 2015-11-19 → none |
| 86 | Assessment Requirements | 2015-11-30 A → 2016-11-28 (+364d) | 2015-12-02 A → 2016-11-30 (+364d) |  | 100% → 0% | none → 95d | baseline start 2015-11-20 → none; baseline finish 2015-11-24 → none |
| 87 | **Moodle: Performance and Control Considerations** | 2015-12-03 A → 2016-12-01 (+364d) | 2015-12-22 → 2016-12-16 (+360d) | 13.25d → 12d | 91% → 0% | 92.75d → 95d | baseline start 2015-11-25 → none; baseline finish 2015-12-10 → none |
| 88 | Automated and Manual Communications setup | 2015-12-03 A → 2016-12-01 (+364d) | 2015-12-11 → 2016-12-07 (+362d) | 6.25d → 5d | 80% → 0% | 99.75d → 95d | baseline start 2015-11-25 → none; baseline finish 2015-12-01 → none |
| 89 | Support Pages Configuration | 2015-12-11 A → 2016-12-08 (+363d) | 2015-12-17 A → 2016-12-13 (+362d) |  | 100% → 0% | none → 95d | baseline start 2015-12-02 → none; baseline finish 2015-12-07 → none |
| 90 | Course Release Strategy | 2015-12-17 A → 2016-12-14 (+363d) | 2015-12-22 A → 2016-12-16 (+360d) |  | 100% → 0% | none → 95d | baseline start 2015-12-08 → none; baseline finish 2015-12-10 → none |
| 91 | **LMS User Experience** | 2015-09-09 A → 2016-09-09 (+366d) | 2015-10-26 A → 2016-10-26 (+366d) | 33d → 34d | 100% → 0% | none → 56d | baseline start 2015-09-03 → none; baseline finish 2015-10-20 → none |
| 92 | Doc: UX Design document (UXD) | 2015-09-09 A → 2016-09-09 (+366d) | 2015-09-15 A → 2016-09-15 (+366d) |  | 100% → 0% | none → 56d | baseline start 2015-09-03 → none; baseline finish 2015-09-09 → none |
| 93 | Review: UXD | 2015-09-16 A → 2016-09-16 (+366d) | 2015-09-17 A → 2016-09-19 (+368d) |  | 100% → 0% | none → 56d | baseline start 2015-09-10 → none; baseline finish 2015-09-11 → none |
| 94 | Signoff: UXD | 2015-09-18 A → 2016-09-20 (+368d) | 2015-09-21 A → 2016-09-21 (+366d) |  | 100% → 0% | none → 56d | baseline start 2015-09-14 → none; baseline finish 2015-09-15 → none |
| 95 | Custom Theme Development | 2015-09-22 A → 2016-09-22 (+366d) | 2015-10-05 A → 2016-10-05 (+366d) |  | 100% → 0% | none → 56d | baseline start 2015-09-16 → none; baseline finish 2015-09-29 → none |
| 96 | Department-wide custom themes | 2015-10-06 A → 2016-10-06 (+366d) | 2015-10-12 A → 2016-10-12 (+366d) |  | 100% → 0% | none → 56d | baseline start 2015-09-30 → none; baseline finish 2015-10-06 → none |
| 97 | Logo and Branding requirements | 2015-10-13 A → 2016-10-13 (+366d) | 2015-10-19 A → 2016-10-19 (+366d) |  | 100% → 0% | none → 56d | baseline start 2015-10-07 → none; baseline finish 2015-10-13 → none |
| 98 | Marketing UX reqts | 2015-10-20 A → 2016-10-20 (+366d) | 2015-10-26 A → 2016-10-26 (+366d) |  | 100% → 0% | none → 56d | baseline start 2015-10-14 → none; baseline finish 2015-10-20 → none |
| 99 | Milestone: UX complete | 2015-10-26 A → 2016-10-26 (+366d) | 2015-10-26 A → 2016-10-26 (+366d) |  | 100% → 0% | none → 56d | baseline start 2015-10-20 → none; baseline finish 2015-10-20 → none |
| 100 | **LMS Content Migration** | 2015-09-09 A → 2016-09-09 (+366d) | 2016-01-19 → 2017-01-12 (+359d) | 88d → 90d | 99% → 0% | 75d → 0d | baseline start 2015-09-03 → none; baseline finish 2016-01-06 → none |
| 101 | Content Vendor Selection | 2015-09-09 A → 2016-09-09 (+366d) | 2015-09-15 A → 2016-09-15 (+366d) |  | 100% → 0% | none → 0d | baseline start 2015-09-03 → none; baseline finish 2015-09-09 → none |
| 102 | Content Vendor Engage | 2015-09-16 A → 2016-09-16 (+366d) | 2015-09-22 A → 2016-09-22 (+366d) |  | 100% → 0% | none → 0d | baseline start 2015-09-10 → none; baseline finish 2015-09-16 → none |
| 103 | Migrate SCORM Content | 2015-09-23 A → 2016-09-23 (+366d) | 2015-10-06 A → 2016-10-06 (+366d) |  | 100% → 0% | none → 0d | baseline start 2015-09-17 → none; baseline finish 2015-09-30 → none |
| 104 | Vendonr: New Content Creation | 2015-10-07 A → 2016-10-07 (+366d) | 2015-12-29 A → 2016-12-29 (+366d) |  | 100% → 0% | none → 0d | was named Vendor: New Content Creation; baseline start 2015-10-01 → none; baseline finish 2015-12-23 → none |
| 105 | Vendor: New content Upload | 2015-12-30 A → 2016-12-30 (+366d) | 2016-01-19 A → 2017-01-12 (+359d) | 15d → 10d | 100% → 0% | none → 0d | baseline start 2015-12-24 → none; baseline finish 2016-01-06 → none |
| 106 | Milestone: Migration done | 2016-01-19 → 2017-01-12 (+359d) | 2016-01-19 → 2017-01-12 (+359d) |  |  | 75d → 0d | baseline start 2016-01-06 → none; baseline finish 2016-01-06 → none |
| 107 | **Mobile App Development** | 2015-09-30 A → 2016-09-30 (+366d) | 2015-12-22 A → 2016-12-22 (+366d) | 56d → 60d | 100% → 0% | none → 15d | baseline start 2015-09-25 → none; baseline finish 2015-12-17 → none |
| 108 | Mobile Dev Vendor Selection | 2015-09-30 A → 2016-09-30 (+366d) | 2015-10-06 A → 2016-10-06 (+366d) |  | 100% → 0% | none → 15d | baseline start 2015-09-25 → none; baseline finish 2015-10-01 → none |
| 109 | Requirements and signoff | 2015-10-07 A → 2016-10-07 (+366d) | 2015-10-20 A → 2016-10-20 (+366d) |  | 100% → 0% | none → 15d | baseline start 2015-10-02 → none; baseline finish 2015-10-15 → none |
| 110 | Notifications | 2015-10-21 A → 2016-10-21 (+366d) | 2015-10-26 A → 2016-10-26 (+366d) |  | 100% → 0% | none → 15d | baseline start 2015-10-16 → none; baseline finish 2015-10-21 → none |
| 111 | Calendar | 2015-10-27 A → 2016-10-27 (+366d) | 2015-10-28 A → 2016-10-28 (+366d) |  | 100% → 0% | none → 15d | baseline start 2015-10-22 → none; baseline finish 2015-10-23 → none |
| 112 | Quiz Engine | 2015-10-29 A → 2016-10-31 (+368d) | 2015-11-18 A → 2016-11-18 (+366d) |  | 100% → 0% | none → 15d | baseline start 2015-10-26 → none; baseline finish 2015-11-13 → none |
| 113 | Annual Time Table | 2015-11-19 A → 2016-11-21 (+368d) | 2015-11-20 A → 2016-11-22 (+368d) |  | 100% → 0% | none → 15d | baseline start 2015-11-16 → none; baseline finish 2015-11-17 → none |
| 114 | Messaging | 2015-11-23 A → 2016-11-23 (+366d) | 2015-11-27 A → 2016-11-29 (+368d) |  | 100% → 0% | none → 15d | baseline start 2015-11-18 → none; baseline finish 2015-11-24 → none |
| 115 | Social Integration | 2015-11-30 A → 2016-11-30 (+366d) | 2015-12-01 A → 2016-12-01 (+366d) |  | 100% → 0% | none → 15d | baseline start 2015-11-25 → none; baseline finish 2015-11-26 → none |
| 116 | Usability Testing | 2015-12-02 A → 2016-12-02 (+366d) | 2015-12-08 A → 2016-12-08 (+366d) |  | 100% → 0% | none → 15d | baseline start 2015-11-27 → none; baseline finish 2015-12-03 → none |
| 117 | Functional Testing | 2015-12-09 A → 2016-12-09 (+366d) | 2015-12-15 A → 2016-12-15 (+366d) |  | 100% → 0% | none → 15d | baseline start 2015-12-04 → none; baseline finish 2015-12-10 → none |
| 118 | Integration testing | 2015-12-16 A → 2016-12-16 (+366d) | 2015-12-22 A → 2016-12-22 (+366d) |  | 100% → 0% | none → 15d | baseline start 2015-12-11 → none; baseline finish 2015-12-17 → none |
| 119 | Milestone: Mobile dev complete | 2015-12-22 A → 2016-12-22 (+366d) | 2015-12-22 A → 2016-12-22 (+366d) |  | 100% → 0% | none → 15d | baseline start 2015-12-17 → none; baseline finish 2015-12-17 → none |
| 120 | **Testing Plan and Setup** | 2015-10-22 A → 2016-10-21 (+365d) | 2015-12-16 A → 2016-12-08 (+358d) | 37d → 35d | 100% → 0% | none → 25d | baseline start 2015-10-19 → none; baseline finish 2015-12-04 → none |
| 121 | Doc: Test Specification Document (TSD) | 2015-10-22 A → 2016-10-21 (+365d) | 2015-11-11 A → 2016-11-03 (+358d) | 3w → 2w | 100% → 0% | none → 25d | baseline start 2015-10-19 → none; baseline finish 2015-10-30 → none |
| 122 | Test team setup | 2015-11-12 A → 2016-11-04 (+358d) | 2015-11-18 A → 2016-11-10 (+358d) |  | 100% → 0% | none → 25d | baseline start 2015-11-02 → none; baseline finish 2015-11-06 → none |
| 123 | Review: TSD | 2015-11-19 A → 2016-11-11 (+358d) | 2015-11-23 A → 2016-11-15 (+358d) |  | 100% → 0% | none → 25d | baseline start 2015-11-09 → none; baseline finish 2015-11-11 → none |
| 124 | Signoff: TSD | 2015-11-24 A → 2016-11-16 (+358d) | 2015-11-25 A → 2016-11-17 (+358d) |  | 100% → 0% | none → 25d | baseline start 2015-11-12 → none; baseline finish 2015-11-13 → none |
| 125 | Content Test Strategy | 2015-11-26 A → 2016-11-18 (+358d) | 2015-12-09 A → 2016-12-01 (+358d) |  | 100% → 0% | none → 25d | baseline start 2015-11-16 → none; baseline finish 2015-11-27 → none |
| 126 | Usability Test Strategy | 2015-12-10 A → 2016-12-02 (+358d) | 2015-12-16 A → 2016-12-08 (+358d) |  | 100% → 0% | none → 25d | baseline start 2015-11-30 → none; baseline finish 2015-12-04 → none |
| 127 | Milestone: Implementation Complete | 2016-01-19 A → 2017-01-12 (+359d) | 2016-01-19 A → 2017-01-12 (+359d) |  | 100% → 0% | none → 0d | baseline start 2016-01-06 → none; baseline finish 2016-01-06 → none |
| 128 | **Integration Phase** | 2016-01-20 A → 2017-01-13 (+359d) | 2016-04-04 → 2017-03-29 (+359d) | 53d → 54d | 54% → 0% | 2d → 0d | baseline start 2016-01-07 → none; baseline finish 2016-03-22 → none |
| 129 | Single Sign On (SSO) Setup | 2016-01-20 A → 2017-01-13 (+359d) | 2016-01-22 A → 2017-01-17 (+361d) |  | 100% → 0% | none → 0d | baseline start 2016-01-07 → none; baseline finish 2016-01-11 → none |
| 130 | Student Information System (SIS) Setup | 2016-01-25 A → 2017-01-18 (+359d) | 2016-01-29 A → 2017-01-24 (+361d) |  | 100% → 0% | none → 1d | baseline start 2016-01-12 → none; baseline finish 2016-01-18 → none |
| 131 | Datewarehousing Integration (Learning Analytics) | 2016-02-01 A → 2017-01-25 (+359d) | 2016-02-12 A → 2017-02-07 (+361d) |  | 100% → 0% | none → 1d | baseline start 2016-01-19 → none; baseline finish 2016-02-01 → none |
| 132 | SAP Integration | 2016-02-15 A → 2017-02-08 (+359d) | 2016-03-04 → 2017-02-28 (+361d) |  | 73% → 0% | 2d → 1d | baseline start 2016-02-02 → none; baseline finish 2016-02-22 → none |
| 133 | Accounting Software Setup | 2016-03-07 → 2017-03-01 (+359d) | 2016-03-11 → 2017-03-07 (+361d) |  |  | 2d → 1d | baseline start 2016-02-23 → none; baseline finish 2016-02-29 → none |
| 134 | **STAGING SERVER SETUP** | 2016-03-14 → 2017-03-08 (+359d) | 2016-04-04 → 2017-03-29 (+359d) |  |  | 2d → 1d | baseline start 2016-03-01 → none; baseline finish 2016-03-22 → none |
| 135 | Server setup, Redundancy setup | 2016-03-14 → 2017-03-08 (+359d) | 2016-03-16 → 2017-03-10 (+359d) |  |  | 2d → 1d | baseline start 2016-03-01 → none; baseline finish 2016-03-03 → none |
| 136 | Database Configuration | 2016-03-17 → 2017-03-13 (+361d) | 2016-03-21 → 2017-03-15 (+359d) |  |  | 2d → 1d | baseline start 2016-03-04 → none; baseline finish 2016-03-08 → none |
| 137 | LMS Installation | 2016-03-22 → 2017-03-16 (+359d) | 2016-03-23 → 2017-03-17 (+359d) |  |  | 2d → 1d | baseline start 2016-03-09 → none; baseline finish 2016-03-10 → none |
| 138 | Course Data Migration | 2016-03-24 → 2017-03-20 (+361d) | 2016-03-28 → 2017-03-22 (+359d) |  |  | 2d → 1d | baseline start 2016-03-11 → none; baseline finish 2016-03-15 → none |
| 139 | Student Data Import | 2016-03-29 → 2017-03-23 (+359d) | 2016-03-31 → 2017-03-27 (+361d) |  |  | 2d → 1d | baseline start 2016-03-16 → none; baseline finish 2016-03-18 → none |
| 140 | RBAC Setup and testing | 2016-04-01 → 2017-03-28 (+361d) | 2016-04-04 → 2017-03-29 (+359d) |  |  | 2d → 1d | baseline start 2016-03-21 → none; baseline finish 2016-03-22 → none |

| ID | Task | Start | Finish | Duration | Complete | Total float | Other |
| --- | --- | --- | --- | --- | --- | --- | --- |
| 141 | Milestone: Integration Phase Complete | 2016-04-04 → 2017-03-29 (+359d) | 2016-04-04 → 2017-03-29 (+359d) |  |  | 2d → 1d | baseline start 2016-03-22 → none; baseline finish 2016-03-22 → none |
| 142 | **VERIFICATION and STAGING** | 2015-11-02 A → 2016-10-28 (+361d) | 2016-04-22 → 2017-04-20 (+363d) | 117d → 125d | 69% → 0% | 9d → 6d | baseline start 2015-10-22 → none; baseline finish 2016-04-13 → none |
| 143 | Unit Testing of all modules | 2015-11-02 A → 2016-10-28 (+361d) | 2015-12-25 A → 2016-12-22 (+363d) |  | 100% → 0% | none → 6d | baseline start 2015-10-22 → none; baseline finish 2015-12-16 → none |
| 144 | Functional Testing | 2015-12-28 A → 2016-12-23 (+361d) | 2016-01-15 A → 2017-01-12 (+363d) |  | 100% → 0% | none → 6d | baseline start 2015-12-17 → none; baseline finish 2016-01-06 → none |
| 145 | Installation and Deploy Testing | 2016-01-18 A → 2017-01-13 (+361d) | 2016-01-29 A → 2017-01-26 (+363d) |  | 100% → 0% | none → 6d | baseline start 2016-01-07 → none; baseline finish 2016-01-20 → none |
| 146 | Performance Testing | 2016-02-01 A → 2017-01-27 (+361d) | 2016-02-12 A → 2017-02-09 (+363d) |  | 100% → 0% | none → 6d | baseline start 2016-01-21 → none; baseline finish 2016-02-03 → none |
| 147 | Usability Testing | 2016-02-15 A → 2017-02-10 (+361d) | 2016-02-26 A → 2017-02-23 (+363d) |  | 100% → 0% | none → 6d | baseline start 2016-02-04 → none; baseline finish 2016-02-17 → none |
| 148 | Alpha Testing | 2016-02-29 A → 2017-02-24 (+361d) | 2016-03-11 → 2017-03-09 (+363d) |  | 10% → 0% | 9d → 6d | baseline start 2016-02-18 → none; baseline finish 2016-03-02 → none |
| 149 | UAT Scripting | 2016-03-14 → 2017-03-10 (+361d) | 2016-03-25 → 2017-03-23 (+363d) |  |  | 9d → 6d | baseline start 2016-03-03 → none; baseline finish 2016-03-16 → none |
| 150 | UAT cases review and approval | 2016-03-28 → 2017-03-24 (+361d) | 2016-04-08 → 2017-04-06 (+363d) |  |  | 8d → 6d | baseline start 2016-03-17 → none; baseline finish 2016-03-30 → none |
| 151 | User Acceptance Testing | 2016-04-11 → 2017-04-07 (+361d) | 2016-04-22 → 2017-04-20 (+363d) |  |  | 8d → 6d | baseline start 2016-03-31 → none; baseline finish 2016-04-13 → none |
| 152 | Milestone: Testing Complete | 2016-04-22 → 2017-04-20 (+363d) | 2016-04-22 → 2017-04-20 (+363d) |  |  | 9d → 6d | baseline start 2016-04-13 → none; baseline finish 2016-04-13 → none |
| 153 | **PRODUCTION DEPLOYMENT** | 2016-04-05 → 2017-03-30 (+359d) | 2016-05-03 → 2017-04-27 (+359d) | 20d → 21d |  | 2d → 1d | baseline start 2016-03-23 → none; baseline finish 2016-04-20 → none |
| 154 | Hardware, Software, Database Setup, Configuration | 2016-04-05 → 2017-03-30 (+359d) | 2016-04-11 → 2017-04-05 (+359d) |  |  | 2d → 1d | baseline start 2016-03-23 → none; baseline finish 2016-03-29 → none |
| 155 | Course Data Migration | 2016-04-12 → 2017-04-06 (+359d) | 2016-04-19 → 2017-04-13 (+359d) |  |  | 2d → 1d | baseline start 2016-03-30 → none; baseline finish 2016-04-06 → none |
| 156 | Student Data Migration | 2016-04-20 → 2017-04-14 (+359d) | 2016-04-25 → 2017-04-19 (+359d) |  |  | 2d → 1d | baseline start 2016-04-07 → none; baseline finish 2016-04-12 → none |
| 157 | Course Creation - all Colleges | 2016-04-26 → 2017-04-20 (+359d) | 2016-05-02 → 2017-04-26 (+359d) |  |  | 2d → 1d | baseline start 2016-04-13 → none; baseline finish 2016-04-19 → none |
| 158 | Roles and Accounts | 2016-05-03 → 2017-04-27 (+359d) | 2016-05-03 → 2017-04-27 (+359d) |  |  | 2d → 1d | baseline start 2016-04-20 → none; baseline finish 2016-04-20 → none |
| 159 | Milestone: Prod Deploy Complete | 2016-05-03 → 2017-04-27 (+359d) | 2016-05-03 → 2017-04-27 (+359d) |  |  | 2d → 1d | baseline start 2016-04-20 → none; baseline finish 2016-04-20 → none |
| 160 | **Maintenance Handover** | 2016-02-18 A → 2017-02-10 (+358d) | 2016-05-05 → 2017-04-28 (+358d) | 55d → 56d | 13% → 0% |  | baseline start 2016-02-05 → none; baseline finish 2016-04-22 → none |
| 161 | Training Calendar | 2016-02-18 A → 2017-02-10 (+358d) | 2016-02-22 A → 2017-02-14 (+358d) |  | 100% → 0% | none → 0d | baseline start 2016-02-05 → none; baseline finish 2016-02-09 → none |
| 162 | Maintenance Vendor Selection | 2016-02-23 A → 2017-02-15 (+358d) | 2016-03-21 → 2017-03-14 (+358d) |  | 25% → 0% |  | baseline start 2016-02-10 → none; baseline finish 2016-03-08 → none |
| 163 | Maintenance Vendor Engagement | 2016-03-22 → 2017-03-15 (+358d) | 2016-03-28 → 2017-03-21 (+358d) |  |  |  | baseline start 2016-03-09 → none; baseline finish 2016-03-15 → none |
| 164 | User Manual | 2016-03-29 → 2017-03-22 (+358d) | 2016-04-11 → 2017-04-04 (+358d) |  |  |  | baseline start 2016-03-16 → none; baseline finish 2016-03-29 → none |
| 165 | Administration Manual | 2016-04-12 → 2017-04-05 (+358d) | 2016-04-25 → 2017-04-18 (+358d) |  |  |  | baseline start 2016-03-30 → none; baseline finish 2016-04-12 → none |
| 166 | Techno Functional Handover | 2016-04-26 → 2017-04-19 (+358d) | 2016-04-28 → 2017-04-21 (+358d) |  |  |  | baseline start 2016-04-13 → none; baseline finish 2016-04-15 → none |
| 167 | Training Org Wide | 2016-04-29 → 2017-04-24 (+360d) | 2016-05-05 → 2017-04-28 (+358d) |  |  |  | baseline start 2016-04-18 → none; baseline finish 2016-04-22 → none |
| 168 | **BUGZILLA** | 2016-04-29 → 2017-04-24 (+360d) | 2016-05-05 → 2017-04-28 (+358d) |  |  |  | baseline start 2016-04-18 → none; baseline finish 2016-04-22 → none |
| 169 | Issue Tracking BUGZILLA installation | 2016-04-29 → 2017-04-24 (+360d) | 2016-05-02 → 2017-04-25 (+358d) |  |  |  | baseline start 2016-04-18 → none; baseline finish 2016-04-19 → none |
| 170 | Bugzilla accounts, training and access handover | 2016-05-03 → 2017-04-26 (+358d) | 2016-05-05 → 2017-04-28 (+358d) |  |  |  | baseline start 2016-04-20 → none; baseline finish 2016-04-22 → none |
| 171 | Milestone: Project Complete | 2016-05-05 → 2017-04-28 (+358d) | 2016-05-05 → 2017-04-28 (+358d) |  |  |  | baseline start 2016-04-22 → none; baseline finish 2016-04-22 → none |

## Version 3 (data date 2015-06-30, saved 2025-04-02, file 12.0 Project Exercise 10 - Learning Management System Implementation_ver5.0.mpp)

Last finish 2017-04-28 → 2016-04-26 (-367d). Complete tasks 0 → 16.

Changed:

| ID | Task | Start | Finish | Duration | Complete | Total float | Other |
| --- | --- | --- | --- | --- | --- | --- | --- |
| 1 | **Planning Phase** | 2016-04-12 → 2015-04-06 A (-372d) | 2016-05-30 → 2015-05-25 (-371d) | 35d → 34d | 0% → 99% | 0d → 230d | baseline start none → 2015-04-06; baseline finish none → 2015-05-22 |
| 2 | Strategic Objectives | 2016-04-12 → 2015-04-06 A (-372d) | 2016-04-20 → 2015-04-14 A (-372d) |  | 0% → 100% | 0d → none | baseline start none → 2015-04-06; baseline finish none → 2015-04-14 |
| 3 | Budgetary Objectives | 2016-04-21 → 2015-04-15 A (-372d) | 2016-04-27 → 2015-04-21 A (-372d) |  | 0% → 100% | 0d → none | baseline start none → 2015-04-15; baseline finish none → 2015-04-21 |
| 4 | Compliance and Regulatory requirements | 2016-04-28 → 2015-04-22 A (-372d) | 2016-05-05 → 2015-04-29 A (-372d) |  | 0% → 100% | 0d → none | baseline start none → 2015-04-22; baseline finish none → 2015-04-29 |
| 5 | Partners/Suppliers/Corporate Objectives | 2016-05-06 → 2015-04-30 A (-372d) | 2016-05-09 → 2015-05-01 A (-374d) |  | 0% → 100% | 0d → none | baseline start none → 2015-04-30; baseline finish none → 2015-05-01 |
| 6 | Doc: Strategic Objectives document | 2016-05-10 → 2015-05-04 A (-372d) | 2016-05-18 → 2015-05-12 A (-372d) |  | 0% → 100% | 0d → none | baseline start none → 2015-05-04; baseline finish none → 2015-05-12 |
| 7 | Review Objectives Document | 2016-05-19 → 2015-05-13 A (-372d) | 2016-05-25 → 2015-05-19 A (-372d) |  | 0% → 100% | 0d → none | baseline start none → 2015-05-13; baseline finish none → 2015-05-19 |
| 8 | Signoff Objectives | 2016-05-26 → 2015-05-20 A (-372d) | 2016-05-30 → 2015-05-25 A (-371d) | 3d → 4d | 0% → 100% | 0d → none | baseline start none → 2015-05-20; baseline finish none → 2015-05-22 |
| 9 | Milestone: Planning Complete | 2016-05-30 → 2015-05-25 (-371d) | 2016-05-30 → 2015-05-25 (-371d) |  |  | 0d → 230d | baseline start none → 2015-05-22; baseline finish none → 2015-05-22 |
| 10 | **Weekly Review Meeting** | 2016-06-06 → 2015-06-01 A (-371d) | 2017-03-06 → 2016-02-29 (-371d) | 195.25d → 185.25d | 0% → 13% | 39.75d → 40.75d | baseline start none → 2015-06-01; baseline finish none → 2016-02-29 |
| 11 | Weekly Review Meeting 1 | 2016-06-06 → 2015-06-01 A (-371d) | 2016-06-06 → 2015-06-01 A (-371d) |  | 0% → 100% | 234.75d → none | constraint start no earlier than 2016-06-06 → start no earlier than 2015-06-01; baseline start none → 2015-06-01; baseline finish none → 2015-06-01 |
| 12 | Weekly Review Meeting 2 | 2016-06-13 → 2015-06-08 A (-371d) | 2016-06-13 → 2015-06-08 A (-371d) |  | 0% → 100% | 229.75d → none | constraint start no earlier than 2016-06-13 → start no earlier than 2015-06-08; baseline start none → 2015-06-08; baseline finish none → 2015-06-08 |
| 13 | Weekly Review Meeting 3 | 2016-06-20 → 2015-06-15 A (-371d) | 2016-06-20 → 2015-06-15 A (-371d) |  | 0% → 100% | 224.75d → none | constraint start no earlier than 2016-06-20 → start no earlier than 2015-06-15; baseline start none → 2015-06-15; baseline finish none → 2015-06-15 |
| 14 | Weekly Review Meeting 4 | 2016-06-27 → 2015-06-22 A (-371d) | 2016-06-27 → 2015-06-22 A (-371d) |  | 0% → 100% | 219.75d → none | constraint start no earlier than 2016-06-27 → start no earlier than 2015-06-22; baseline start none → 2015-06-22; baseline finish none → 2015-06-22 |
| 15 | Weekly Review Meeting 5 | 2016-07-04 → 2015-06-29 A (-371d) | 2016-07-04 → 2015-06-29 A (-371d) |  | 0% → 100% | 214.75d → none | constraint start no earlier than 2016-07-04 → start no earlier than 2015-06-29; baseline start none → 2015-06-29; baseline finish none → 2015-06-29 |
| 16 | Weekly Review Meeting 6 | 2016-07-11 → 2015-07-06 (-371d) | 2016-07-11 → 2015-07-06 (-371d) |  |  | 209.75d → 201.75d | constraint start no earlier than 2016-07-11 → start no earlier than 2015-07-06; baseline start none → 2015-07-06; baseline finish none → 2015-07-06 |
| 17 | Weekly Review Meeting 7 | 2016-07-18 → 2015-07-13 (-371d) | 2016-07-18 → 2015-07-13 (-371d) |  |  | 204.75d → 196.75d | constraint start no earlier than 2016-07-18 → start no earlier than 2015-07-13; baseline start none → 2015-07-13; baseline finish none → 2015-07-13 |
| 18 | Weekly Review Meeting 8 | 2016-07-25 → 2015-07-20 (-371d) | 2016-07-25 → 2015-07-20 (-371d) |  |  | 199.75d → 191.75d | constraint start no earlier than 2016-07-25 → start no earlier than 2015-07-20; baseline start none → 2015-07-20; baseline finish none → 2015-07-20 |
| 19 | Weekly Review Meeting 9 | 2016-08-01 → 2015-07-27 (-371d) | 2016-08-01 → 2015-07-27 (-371d) |  |  | 194.75d → 186.75d | constraint start no earlier than 2016-08-01 → start no earlier than 2015-07-27; baseline start none → 2015-07-27; baseline finish none → 2015-07-27 |
| 20 | Weekly Review Meeting 10 | 2016-08-08 → 2015-08-03 (-371d) | 2016-08-08 → 2015-08-03 (-371d) |  |  | 189.75d → 181.75d | constraint start no earlier than 2016-08-08 → start no earlier than 2015-08-03; baseline start none → 2015-08-03; baseline finish none → 2015-08-03 |
| 21 | Weekly Review Meeting 11 | 2016-08-15 → 2015-08-10 (-371d) | 2016-08-15 → 2015-08-10 (-371d) |  |  | 184.75d → 176.75d | constraint start no earlier than 2016-08-15 → start no earlier than 2015-08-10; baseline start none → 2015-08-10; baseline finish none → 2015-08-10 |
| 22 | Weekly Review Meeting 12 | 2016-08-22 → 2015-08-17 (-371d) | 2016-08-22 → 2015-08-17 (-371d) |  |  | 179.75d → 171.75d | constraint start no earlier than 2016-08-22 → start no earlier than 2015-08-17; baseline start none → 2015-08-17; baseline finish none → 2015-08-17 |
| 23 | Weekly Review Meeting 13 | 2016-08-29 → 2015-08-24 (-371d) | 2016-08-29 → 2015-08-24 (-371d) |  |  | 174.75d → 166.75d | constraint start no earlier than 2016-08-29 → start no earlier than 2015-08-24; baseline start none → 2015-08-24; baseline finish none → 2015-08-24 |
| 24 | Weekly Review Meeting 14 | 2016-09-05 → 2015-08-31 (-371d) | 2016-09-05 → 2015-08-31 (-371d) |  |  | 169.75d → 161.75d | constraint start no earlier than 2016-09-05 → start no earlier than 2015-08-31; baseline start none → 2015-08-31; baseline finish none → 2015-08-31 |
| 25 | Weekly Review Meeting 15 | 2016-09-12 → 2015-09-08 (-370d) | 2016-09-12 → 2015-09-08 (-370d) |  |  | 164.75d → 156.75d | constraint start no earlier than 2016-09-12 → start no earlier than 2015-09-07; baseline start none → 2015-09-08; baseline finish none → 2015-09-08 |
| 26 | Weekly Review Meeting 16 | 2016-09-19 → 2015-09-14 (-371d) | 2016-09-19 → 2015-09-14 (-371d) |  |  | 159.75d → 152.75d | constraint start no earlier than 2016-09-19 → start no earlier than 2015-09-14; baseline start none → 2015-09-14; baseline finish none → 2015-09-14 |
| 27 | Weekly Review Meeting 17 | 2016-09-26 → 2015-09-21 (-371d) | 2016-09-26 → 2015-09-21 (-371d) |  |  | 154.75d → 147.75d | constraint start no earlier than 2016-09-26 → start no earlier than 2015-09-21; baseline start none → 2015-09-21; baseline finish none → 2015-09-21 |
| 28 | Weekly Review Meeting 18 | 2016-10-03 → 2015-09-28 (-371d) | 2016-10-03 → 2015-09-28 (-371d) |  |  | 149.75d → 142.75d | constraint start no earlier than 2016-10-03 → start no earlier than 2015-09-28; baseline start none → 2015-09-28; baseline finish none → 2015-09-28 |
| 29 | Weekly Review Meeting 19 | 2016-10-10 → 2015-10-05 (-371d) | 2016-10-10 → 2015-10-05 (-371d) |  |  | 144.75d → 137.75d | constraint start no earlier than 2016-10-10 → start no earlier than 2015-10-05; baseline start none → 2015-10-05; baseline finish none → 2015-10-05 |
| 30 | Weekly Review Meeting 20 | 2016-10-17 → 2015-10-13 (-370d) | 2016-10-17 → 2015-10-13 (-370d) |  |  | 139.75d → 132.75d | constraint start no earlier than 2016-10-17 → start no earlier than 2015-10-12; baseline start none → 2015-10-13; baseline finish none → 2015-10-13 |
| 31 | Weekly Review Meeting 21 | 2016-10-24 → 2015-10-19 (-371d) | 2016-10-24 → 2015-10-19 (-371d) |  |  | 134.75d → 128.75d | constraint start no earlier than 2016-10-24 → start no earlier than 2015-10-19; baseline start none → 2015-10-19; baseline finish none → 2015-10-19 |
| 32 | Weekly Review Meeting 22 | 2016-10-31 → 2015-10-26 (-371d) | 2016-10-31 → 2015-10-26 (-371d) |  |  | 129.75d → 123.75d | constraint start no earlier than 2016-10-31 → start no earlier than 2015-10-26; baseline start none → 2015-10-26; baseline finish none → 2015-10-26 |
| 33 | Weekly Review Meeting 23 | 2016-11-07 → 2015-11-02 (-371d) | 2016-11-07 → 2015-11-02 (-371d) |  |  | 124.75d → 118.75d | constraint start no earlier than 2016-11-07 → start no earlier than 2015-11-02; baseline start none → 2015-11-02; baseline finish none → 2015-11-02 |
| 34 | Weekly Review Meeting 24 | 2016-11-14 → 2015-11-09 (-371d) | 2016-11-14 → 2015-11-09 (-371d) |  |  | 119.75d → 113.75d | constraint start no earlier than 2016-11-14 → start no earlier than 2015-11-09; baseline start none → 2015-11-09; baseline finish none → 2015-11-09 |
| 35 | Weekly Review Meeting 25 | 2016-11-21 → 2015-11-16 (-371d) | 2016-11-21 → 2015-11-16 (-371d) |  |  | 114.75d → 109.75d | constraint start no earlier than 2016-11-21 → start no earlier than 2015-11-16; baseline start none → 2015-11-16; baseline finish none → 2015-11-16 |
| 36 | Weekly Review Meeting 26 | 2016-11-28 → 2015-11-23 (-371d) | 2016-11-28 → 2015-11-23 (-371d) |  |  | 109.75d → 104.75d | constraint start no earlier than 2016-11-28 → start no earlier than 2015-11-23; baseline start none → 2015-11-23; baseline finish none → 2015-11-23 |
| 37 | Weekly Review Meeting 27 | 2016-12-05 → 2015-11-30 (-371d) | 2016-12-05 → 2015-11-30 (-371d) |  |  | 104.75d → 101.75d | constraint start no earlier than 2016-12-05 → start no earlier than 2015-11-30; baseline start none → 2015-11-30; baseline finish none → 2015-11-30 |
| 38 | Weekly Review Meeting 28 | 2016-12-12 → 2015-12-07 (-371d) | 2016-12-12 → 2015-12-07 (-371d) |  |  | 99.75d → 96.75d | constraint start no earlier than 2016-12-12 → start no earlier than 2015-12-07; baseline start none → 2015-12-07; baseline finish none → 2015-12-07 |
| 39 | Weekly Review Meeting 29 | 2016-12-19 → 2015-12-14 (-371d) | 2016-12-19 → 2015-12-14 (-371d) |  |  | 94.75d → 91.75d | constraint start no earlier than 2016-12-19 → start no earlier than 2015-12-14; baseline start none → 2015-12-14; baseline finish none → 2015-12-14 |
| 40 | Weekly Review Meeting 30 | 2016-12-26 → 2015-12-21 (-371d) | 2016-12-26 → 2015-12-21 (-371d) |  |  | 89.75d → 86.75d | constraint start no earlier than 2016-12-26 → start no earlier than 2015-12-21; baseline start none → 2015-12-21; baseline finish none → 2015-12-21 |
| 41 | Weekly Review Meeting 31 | 2017-01-02 → 2015-12-28 (-371d) | 2017-01-02 → 2015-12-28 (-371d) |  |  | 84.75d → 82.75d | constraint start no earlier than 2017-01-02 → start no earlier than 2015-12-28; baseline start none → 2015-12-28; baseline finish none → 2015-12-28 |
| 42 | Weekly Review Meeting 32 | 2017-01-09 → 2016-01-04 (-371d) | 2017-01-09 → 2016-01-04 (-371d) |  |  | 79.75d → 78.75d | constraint start no earlier than 2017-01-09 → start no earlier than 2016-01-04; baseline start none → 2016-01-04; baseline finish none → 2016-01-04 |
| 43 | Weekly Review Meeting 33 | 2017-01-16 → 2016-01-11 (-371d) | 2017-01-16 → 2016-01-11 (-371d) |  |  | 74.75d → 73.75d | constraint start no earlier than 2017-01-16 → start no earlier than 2016-01-11; baseline start none → 2016-01-11; baseline finish none → 2016-01-11 |
| 44 | Weekly Review Meeting 34 | 2017-01-23 → 2016-01-19 (-370d) | 2017-01-23 → 2016-01-19 (-370d) |  |  | 69.75d → 68.75d | constraint start no earlier than 2017-01-23 → start no earlier than 2016-01-18; baseline start none → 2016-01-19; baseline finish none → 2016-01-19 |
| 45 | Weekly Review Meeting 35 | 2017-01-30 → 2016-01-25 (-371d) | 2017-01-30 → 2016-01-25 (-371d) |  |  |  | constraint start no earlier than 2017-01-30 → start no earlier than 2016-01-25; baseline start none → 2016-01-25; baseline finish none → 2016-01-25 |
| 46 | Weekly Review Meeting 36 | 2017-02-06 → 2016-02-01 (-371d) | 2017-02-06 → 2016-02-01 (-371d) |  |  |  | constraint start no earlier than 2017-02-06 → start no earlier than 2016-02-01; baseline start none → 2016-02-01; baseline finish none → 2016-02-01 |
| 47 | Weekly Review Meeting 37 | 2017-02-13 → 2016-02-08 (-371d) | 2017-02-13 → 2016-02-08 (-371d) |  |  |  | constraint start no earlier than 2017-02-13 → start no earlier than 2016-02-08; baseline start none → 2016-02-08; baseline finish none → 2016-02-08 |
| 48 | Weekly Review Meeting 38 | 2017-02-20 → 2016-02-16 (-370d) | 2017-02-20 → 2016-02-16 (-370d) |  |  |  | constraint start no earlier than 2017-02-20 → start no earlier than 2016-02-15; baseline start none → 2016-02-16; baseline finish none → 2016-02-16 |
| 49 | Weekly Review Meeting 39 | 2017-02-27 → 2016-02-22 (-371d) | 2017-02-27 → 2016-02-22 (-371d) |  |  | 44.75d → 45.75d | constraint start no earlier than 2017-02-27 → start no earlier than 2016-02-22; baseline start none → 2016-02-22; baseline finish none → 2016-02-22 |
| 50 | Weekly Review Meeting 40 | 2017-03-06 → 2016-02-29 (-371d) | 2017-03-06 → 2016-02-29 (-371d) |  |  | 39.75d → 40.75d | constraint start no earlier than 2017-03-06 → start no earlier than 2016-02-29; baseline start none → 2016-02-29; baseline finish none → 2016-02-29 |
| 51 | **Detailed Design Phase** | 2016-05-31 → 2015-05-26 A (-371d) | 2016-09-08 → 2015-09-04 (-370d) |  | 0% → 34% | 0d → 157d | baseline start none → 2015-05-25; baseline finish none → 2015-09-02 |
| 52 | Technology Considerations | 2016-05-31 → 2015-05-26 A (-371d) | 2016-06-02 → 2015-05-28 A (-371d) |  | 0% → 100% | 0d → none | baseline start none → 2015-05-25; baseline finish none → 2015-05-27 |
| 53 | Integration Considerations | 2016-06-03 → 2015-05-29 A (-371d) | 2016-06-10 → 2015-06-05 A (-371d) |  | 0% → 100% | 0d → none | baseline start none → 2015-05-28; baseline finish none → 2015-06-04 |
| 54 | Non Functional Requirements | 2016-06-13 → 2015-06-08 A (-371d) | 2016-06-20 → 2015-06-15 A (-371d) |  | 0% → 100% | 0d → none | baseline start none → 2015-06-05; baseline finish none → 2015-06-12 |
| 55 | Administrative Needs and Roles | 2016-06-21 → 2015-06-16 A (-371d) | 2016-06-24 → 2015-06-24 (-366d) | 4d → 7d | 0% → 86% | 0d → 208d | baseline start none → 2015-06-15; baseline finish none → 2015-06-18 |
| 56 | RACI Matrix for LMS - Org wide | 2016-06-27 → 2015-06-25 A (-368d) | 2016-07-04 → 2015-06-30 A (-370d) | 6d → 4d | 0% → 100% | 0d → none | baseline start none → 2015-06-19; baseline finish none → 2015-06-26 |
| 57 | Content Strategy | 2016-07-05 → 2015-07-01 (-370d) | 2016-07-18 → 2015-07-14 (-370d) |  |  |  | baseline start none → 2015-06-29; baseline finish none → 2015-07-10 |
| 58 | Marketing Requirements | 2016-07-19 → 2015-07-15 (-370d) | 2016-07-25 → 2015-07-21 (-370d) |  |  |  | baseline start none → 2015-07-13; baseline finish none → 2015-07-17 |
| 59 | Deployment Plan (rollout to all colleges) | 2016-07-26 → 2015-07-22 (-370d) | 2016-08-01 → 2015-07-28 (-370d) |  |  |  | baseline start none → 2015-07-20; baseline finish none → 2015-07-24 |
| 60 | Doc: Functional Specification Document (FSD) | 2016-08-02 → 2015-07-29 (-370d) | 2016-08-08 → 2015-08-04 (-370d) |  |  |  | baseline start none → 2015-07-27; baseline finish none → 2015-07-31 |
| 61 | Review: FSD | 2016-08-09 → 2015-08-05 (-370d) | 2016-08-10 → 2015-08-06 (-370d) |  |  |  | baseline start none → 2015-08-03; baseline finish none → 2015-08-04 |
| 62 | Signoff: FSD | 2016-08-11 → 2015-08-07 (-370d) | 2016-08-12 → 2015-08-10 (-368d) |  |  |  | baseline start none → 2015-08-05; baseline finish none → 2015-08-06 |
| 63 | Doc: Technical Specifications Document (TSD) | 2016-08-15 → 2015-08-11 (-370d) | 2016-08-19 → 2015-08-17 (-368d) |  |  |  | baseline start none → 2015-08-07; baseline finish none → 2015-08-13 |
| 64 | Review: TSD | 2016-08-22 → 2015-08-18 (-370d) | 2016-08-23 → 2015-08-19 (-370d) |  |  |  | baseline start none → 2015-08-14; baseline finish none → 2015-08-17 |
| 65 | Signoff: TSD | 2016-08-24 → 2015-08-20 (-370d) | 2016-08-25 → 2015-08-21 (-370d) |  |  |  | baseline start none → 2015-08-18; baseline finish none → 2015-08-19 |
| 66 | Content Strategy Document (CSD) | 2016-08-26 → 2015-08-24 (-368d) | 2016-09-08 → 2015-09-04 (-370d) |  |  |  | baseline start none → 2015-08-20; baseline finish none → 2015-09-02 |
| 67 | Milestone: Detailed Design Complete | 2016-09-08 → 2015-09-04 (-370d) | 2016-09-08 → 2015-09-04 (-370d) |  |  |  | baseline start none → 2015-09-02; baseline finish none → 2015-09-02 |
| 68 | **Implementation Phase** | 2016-09-09 → 2015-09-07 (-368d) | 2017-01-12 → 2016-01-08 (-370d) | 90d → 83d |  |  | baseline start none → 2015-09-03; baseline finish none → 2016-01-06 |
| 69 | Testing Server Setup | 2016-09-09 → 2015-09-07 (-368d) | 2016-09-12 → 2015-09-08 (-370d) |  |  | 95d → 88d | baseline start none → 2015-09-03; baseline finish none → 2015-09-04 |
| 70 | Development Server Setup | 2016-09-13 → 2015-09-09 (-370d) | 2016-09-14 → 2015-09-10 (-370d) |  |  | 95d → 89d | baseline start none → 2015-09-07; baseline finish none → 2015-09-08 |

| ID | Task | Start | Finish | Duration | Total float | Other |
| --- | --- | --- | --- | --- | --- | --- |
| 71 | Install: Moodle Test installation | 2016-09-15 → 2015-09-11 (-370d) | 2016-09-15 → 2015-09-11 (-370d) |  | 95d → 89d | baseline start none → 2015-09-09; baseline finish none → 2015-09-09 |
| 72 | Database design | 2016-09-16 → 2015-09-14 (-368d) | 2016-09-22 → 2015-09-18 (-370d) |  | 95d → 89d | baseline start none → 2015-09-10; baseline finish none → 2015-09-16 |
| 73 | Doc: Upgrade Strategy Document (USD) | 2016-09-23 → 2015-09-21 (-368d) | 2016-09-29 → 2015-09-25 (-370d) |  | 95d → 89d | baseline start none → 2015-09-17; baseline finish none → 2015-09-23 |
| 74 | **Moodle: LMS Structure** | 2016-09-30 → 2015-09-28 (-368d) | 2016-10-27 → 2015-10-23 (-370d) | 20d → 19d | 95d → 89d | baseline start none → 2015-09-24; baseline finish none → 2015-10-21 |
| 75 | Home Page | 2016-09-30 → 2015-09-28 (-368d) | 2016-10-04 → 2015-09-30 (-370d) |  | 95d → 89d | baseline start none → 2015-09-24; baseline finish none → 2015-09-28 |
| 76 | Main Landing Page | 2016-10-05 → 2015-10-01 (-370d) | 2016-10-14 → 2015-10-12 (-368d) |  | 95d → 89d | baseline start none → 2015-09-29; baseline finish none → 2015-10-08 |
| 77 | Institution Landing Pages | 2016-10-17 → 2015-10-13 (-370d) | 2016-10-21 → 2015-10-19 (-368d) |  | 95d → 89d | baseline start none → 2015-10-09; baseline finish none → 2015-10-15 |
| 78 | Course Landing Pages | 2016-10-24 → 2015-10-20 (-370d) | 2016-10-27 → 2015-10-23 (-370d) |  | 95d → 89d | baseline start none → 2015-10-16; baseline finish none → 2015-10-21 |
| 79 | **Moodle: Course Design and Planning** | 2016-10-28 → 2015-10-26 (-368d) | 2016-11-14 → 2015-11-10 (-370d) |  | 95d → 89d | baseline start none → 2015-10-22; baseline finish none → 2015-11-06 |
| 80 | Courses Upload | 2016-10-28 → 2015-10-26 (-368d) | 2016-11-03 → 2015-10-30 (-370d) |  | 95d → 89d | baseline start none → 2015-10-22; baseline finish none → 2015-10-28 |
| 81 | Courses Structuring | 2016-11-04 → 2015-11-02 (-368d) | 2016-11-09 → 2015-11-05 (-370d) |  | 95d → 89d | baseline start none → 2015-10-29; baseline finish none → 2015-11-03 |
| 82 | Courses Support Material Upload | 2016-11-10 → 2015-11-06 (-370d) | 2016-11-14 → 2015-11-10 (-370d) |  | 95d → 89d | baseline start none → 2015-11-04; baseline finish none → 2015-11-06 |
| 83 | **Moodle: Course Creation** | 2016-11-15 → 2015-11-11 (-370d) | 2016-11-30 → 2015-11-26 (-370d) | 12d → 10d | 95d → 89d | baseline start none → 2015-11-09; baseline finish none → 2015-11-24 |
| 84 | Course Space Creation | 2016-11-15 → 2015-11-11 (-370d) | 2016-11-21 → 2015-11-17 (-370d) |  | 95d → 89d | baseline start none → 2015-11-09; baseline finish none → 2015-11-13 |
| 85 | Course Pages | 2016-11-22 → 2015-11-18 (-370d) | 2016-11-25 → 2015-11-23 (-368d) |  | 95d → 90d | baseline start none → 2015-11-16; baseline finish none → 2015-11-19 |
| 86 | Assessment Requirements | 2016-11-28 → 2015-11-24 (-370d) | 2016-11-30 → 2015-11-26 (-370d) |  | 95d → 90d | baseline start none → 2015-11-20; baseline finish none → 2015-11-24 |
| 87 | **Moodle: Performance and Control Considerations** | 2016-12-01 → 2015-11-27 (-370d) | 2016-12-16 → 2015-12-14 (-368d) | 12d → 11d | 95d → 91d | baseline start none → 2015-11-25; baseline finish none → 2015-12-10 |
| 88 | Automated and Manual Communications setup | 2016-12-01 → 2015-11-27 (-370d) | 2016-12-07 → 2015-12-03 (-370d) |  | 95d → 91d | baseline start none → 2015-11-25; baseline finish none → 2015-12-01 |
| 89 | Support Pages Configuration | 2016-12-08 → 2015-12-04 (-370d) | 2016-12-13 → 2015-12-09 (-370d) |  | 95d → 91d | baseline start none → 2015-12-02; baseline finish none → 2015-12-07 |
| 90 | Course Release Strategy | 2016-12-14 → 2015-12-10 (-370d) | 2016-12-16 → 2015-12-14 (-368d) |  | 95d → 91d | baseline start none → 2015-12-08; baseline finish none → 2015-12-10 |
| 91 | **LMS User Experience** | 2016-09-09 → 2015-09-07 (-368d) | 2016-10-26 → 2015-10-22 (-370d) | 34d → 32d | 56d → 51d | baseline start none → 2015-09-03; baseline finish none → 2015-10-20 |
| 92 | Doc: UX Design document (UXD) | 2016-09-09 → 2015-09-07 (-368d) | 2016-09-15 → 2015-09-11 (-370d) |  | 56d → 52d | baseline start none → 2015-09-03; baseline finish none → 2015-09-09 |
| 93 | Review: UXD | 2016-09-16 → 2015-09-14 (-368d) | 2016-09-19 → 2015-09-15 (-370d) |  | 56d → 52d | baseline start none → 2015-09-10; baseline finish none → 2015-09-11 |
| 94 | Signoff: UXD | 2016-09-20 → 2015-09-16 (-370d) | 2016-09-21 → 2015-09-17 (-370d) |  | 56d → 52d | baseline start none → 2015-09-14; baseline finish none → 2015-09-15 |
| 95 | Custom Theme Development | 2016-09-22 → 2015-09-18 (-370d) | 2016-10-05 → 2015-10-01 (-370d) |  | 56d → 52d | baseline start none → 2015-09-16; baseline finish none → 2015-09-29 |
| 96 | Department-wide custom themes | 2016-10-06 → 2015-10-02 (-370d) | 2016-10-12 → 2015-10-08 (-370d) |  | 56d → 51d | baseline start none → 2015-09-30; baseline finish none → 2015-10-06 |
| 97 | Logo and Branding requirements | 2016-10-13 → 2015-10-09 (-370d) | 2016-10-19 → 2015-10-15 (-370d) |  | 56d → 51d | baseline start none → 2015-10-07; baseline finish none → 2015-10-13 |
| 98 | Marketing UX reqts | 2016-10-20 → 2015-10-16 (-370d) | 2016-10-26 → 2015-10-22 (-370d) |  | 56d → 51d | baseline start none → 2015-10-14; baseline finish none → 2015-10-20 |
| 99 | Milestone: UX complete | 2016-10-26 → 2015-10-22 (-370d) | 2016-10-26 → 2015-10-22 (-370d) |  | 56d → 51d | baseline start none → 2015-10-20; baseline finish none → 2015-10-20 |
| 100 | **LMS Content Migration** | 2016-09-09 → 2015-09-07 (-368d) | 2017-01-12 → 2016-01-08 (-370d) | 90d → 83d |  | baseline start none → 2015-09-03; baseline finish none → 2016-01-06 |
| 101 | Content Vendor Selection | 2016-09-09 → 2015-09-07 (-368d) | 2016-09-15 → 2015-09-11 (-370d) |  |  | baseline start none → 2015-09-03; baseline finish none → 2015-09-09 |
| 102 | Content Vendor Engage | 2016-09-16 → 2015-09-14 (-368d) | 2016-09-22 → 2015-09-18 (-370d) |  |  | baseline start none → 2015-09-10; baseline finish none → 2015-09-16 |
| 103 | Migrate SCORM Content | 2016-09-23 → 2015-09-21 (-368d) | 2016-10-06 → 2015-10-02 (-370d) |  |  | baseline start none → 2015-09-17; baseline finish none → 2015-09-30 |
| 104 | Vendonr: New Content Creation | 2016-10-07 → 2015-10-05 (-368d) | 2016-12-29 → 2015-12-25 (-370d) |  |  | baseline start none → 2015-10-01; baseline finish none → 2015-12-23 |
| 105 | Vendor: New content Upload | 2016-12-30 → 2015-12-28 (-368d) | 2017-01-12 → 2016-01-08 (-370d) |  |  | baseline start none → 2015-12-24; baseline finish none → 2016-01-06 |
| 106 | Milestone: Migration done | 2017-01-12 → 2016-01-08 (-370d) | 2017-01-12 → 2016-01-08 (-370d) |  |  | baseline start none → 2016-01-06; baseline finish none → 2016-01-06 |
| 107 | **Mobile App Development** | 2016-09-30 → 2015-09-29 (-367d) | 2016-12-22 → 2015-12-21 (-367d) | 60d → 56d | 15d → 12d | baseline start none → 2015-09-25; baseline finish none → 2015-12-17 |
| 108 | Mobile Dev Vendor Selection | 2016-09-30 → 2015-09-29 (-367d) | 2016-10-06 → 2015-10-05 (-367d) |  | 15d → 13d | baseline start none → 2015-09-25; baseline finish none → 2015-10-01 |
| 109 | Requirements and signoff | 2016-10-07 → 2015-10-06 (-367d) | 2016-10-20 → 2015-10-19 (-367d) |  | 15d → 13d | baseline start none → 2015-10-02; baseline finish none → 2015-10-15 |
| 110 | Notifications | 2016-10-21 → 2015-10-20 (-367d) | 2016-10-26 → 2015-10-23 (-369d) |  | 15d → 13d | baseline start none → 2015-10-16; baseline finish none → 2015-10-21 |
| 111 | Calendar | 2016-10-27 → 2015-10-26 (-367d) | 2016-10-28 → 2015-10-27 (-367d) |  | 15d → 13d | baseline start none → 2015-10-22; baseline finish none → 2015-10-23 |
| 112 | Quiz Engine | 2016-10-31 → 2015-10-28 (-369d) | 2016-11-18 → 2015-11-17 (-367d) |  | 15d → 12d | baseline start none → 2015-10-26; baseline finish none → 2015-11-13 |
| 113 | Annual Time Table | 2016-11-21 → 2015-11-18 (-369d) | 2016-11-22 → 2015-11-19 (-369d) |  | 15d → 12d | baseline start none → 2015-11-16; baseline finish none → 2015-11-17 |
| 114 | Messaging | 2016-11-23 → 2015-11-20 (-369d) | 2016-11-29 → 2015-11-26 (-369d) |  | 15d → 12d | baseline start none → 2015-11-18; baseline finish none → 2015-11-24 |
| 115 | Social Integration | 2016-11-30 → 2015-11-27 (-369d) | 2016-12-01 → 2015-11-30 (-367d) |  | 15d → 13d | baseline start none → 2015-11-25; baseline finish none → 2015-11-26 |
| 116 | Usability Testing | 2016-12-02 → 2015-12-01 (-367d) | 2016-12-08 → 2015-12-07 (-367d) |  | 15d → 13d | baseline start none → 2015-11-27; baseline finish none → 2015-12-03 |
| 117 | Functional Testing | 2016-12-09 → 2015-12-08 (-367d) | 2016-12-15 → 2015-12-14 (-367d) |  | 15d → 12d | baseline start none → 2015-12-04; baseline finish none → 2015-12-10 |
| 118 | Integration testing | 2016-12-16 → 2015-12-15 (-367d) | 2016-12-22 → 2015-12-21 (-367d) |  | 15d → 12d | baseline start none → 2015-12-11; baseline finish none → 2015-12-17 |
| 119 | Milestone: Mobile dev complete | 2016-12-22 → 2015-12-21 (-367d) | 2016-12-22 → 2015-12-21 (-367d) |  | 15d → 12d | baseline start none → 2015-12-17; baseline finish none → 2015-12-17 |
| 120 | **Testing Plan and Setup** | 2016-10-21 → 2015-10-21 (-366d) | 2016-12-08 → 2015-12-08 (-366d) | 35d → 32d | 25d → 21d | baseline start none → 2015-10-19; baseline finish none → 2015-12-04 |
| 121 | Doc: Test Specification Document (TSD) | 2016-10-21 → 2015-10-21 (-366d) | 2016-11-03 → 2015-11-03 (-366d) |  | 25d → 20d | baseline start none → 2015-10-19; baseline finish none → 2015-10-30 |
| 122 | Test team setup | 2016-11-04 → 2015-11-04 (-366d) | 2016-11-10 → 2015-11-10 (-366d) |  | 25d → 20d | baseline start none → 2015-11-02; baseline finish none → 2015-11-06 |
| 123 | Review: TSD | 2016-11-11 → 2015-11-11 (-366d) | 2016-11-15 → 2015-11-13 (-368d) |  | 25d → 20d | baseline start none → 2015-11-09; baseline finish none → 2015-11-11 |
| 124 | Signoff: TSD | 2016-11-16 → 2015-11-16 (-366d) | 2016-11-17 → 2015-11-17 (-366d) |  | 25d → 21d | baseline start none → 2015-11-12; baseline finish none → 2015-11-13 |
| 125 | Content Test Strategy | 2016-11-18 → 2015-11-18 (-366d) | 2016-12-01 → 2015-12-01 (-366d) |  | 25d → 21d | baseline start none → 2015-11-16; baseline finish none → 2015-11-27 |
| 126 | Usability Test Strategy | 2016-12-02 → 2015-12-02 (-366d) | 2016-12-08 → 2015-12-08 (-366d) |  | 25d → 21d | baseline start none → 2015-11-30; baseline finish none → 2015-12-04 |
| 127 | Milestone: Implementation Complete | 2017-01-12 → 2016-01-08 (-370d) | 2017-01-12 → 2016-01-08 (-370d) |  |  | baseline start none → 2016-01-06; baseline finish none → 2016-01-06 |
| 128 | **Integration Phase** | 2017-01-13 → 2016-01-11 (-368d) | 2017-03-29 → 2016-03-24 (-370d) | 54d → 52d |  | baseline start none → 2016-01-07; baseline finish none → 2016-03-22 |
| 129 | Single Sign On (SSO) Setup | 2017-01-13 → 2016-01-11 (-368d) | 2017-01-17 → 2016-01-13 (-370d) |  |  | baseline start none → 2016-01-07; baseline finish none → 2016-01-11 |
| 130 | Student Information System (SIS) Setup | 2017-01-18 → 2016-01-14 (-370d) | 2017-01-24 → 2016-01-20 (-370d) |  | 1d → 2d | baseline start none → 2016-01-12; baseline finish none → 2016-01-18 |
| 131 | Datewarehousing Integration (Learning Analytics) | 2017-01-25 → 2016-01-21 (-370d) | 2017-02-07 → 2016-02-03 (-370d) |  | 1d → 2d | baseline start none → 2016-01-19; baseline finish none → 2016-02-01 |
| 132 | SAP Integration | 2017-02-08 → 2016-02-04 (-370d) | 2017-02-28 → 2016-02-24 (-370d) |  | 1d → 2d | baseline start none → 2016-02-02; baseline finish none → 2016-02-22 |
| 133 | Accounting Software Setup | 2017-03-01 → 2016-02-25 (-370d) | 2017-03-07 → 2016-03-02 (-370d) |  | 1d → 2d | baseline start none → 2016-02-23; baseline finish none → 2016-02-29 |
| 134 | **STAGING SERVER SETUP** | 2017-03-08 → 2016-03-03 (-370d) | 2017-03-29 → 2016-03-24 (-370d) |  | 1d → 2d | baseline start none → 2016-03-01; baseline finish none → 2016-03-22 |
| 135 | Server setup, Redundancy setup | 2017-03-08 → 2016-03-03 (-370d) | 2017-03-10 → 2016-03-07 (-368d) |  | 1d → 2d | baseline start none → 2016-03-01; baseline finish none → 2016-03-03 |
| 136 | Database Configuration | 2017-03-13 → 2016-03-08 (-370d) | 2017-03-15 → 2016-03-10 (-370d) |  | 1d → 2d | baseline start none → 2016-03-04; baseline finish none → 2016-03-08 |
| 137 | LMS Installation | 2017-03-16 → 2016-03-11 (-370d) | 2017-03-17 → 2016-03-14 (-368d) |  | 1d → 2d | baseline start none → 2016-03-09; baseline finish none → 2016-03-10 |
| 138 | Course Data Migration | 2017-03-20 → 2016-03-15 (-370d) | 2017-03-22 → 2016-03-17 (-370d) |  | 1d → 2d | baseline start none → 2016-03-11; baseline finish none → 2016-03-15 |
| 139 | Student Data Import | 2017-03-23 → 2016-03-18 (-370d) | 2017-03-27 → 2016-03-22 (-370d) |  | 1d → 2d | baseline start none → 2016-03-16; baseline finish none → 2016-03-18 |
| 140 | RBAC Setup and testing | 2017-03-28 → 2016-03-23 (-370d) | 2017-03-29 → 2016-03-24 (-370d) |  | 1d → 2d | baseline start none → 2016-03-21; baseline finish none → 2016-03-22 |

| ID | Task | Start | Finish | Duration | Total float | Other |
| --- | --- | --- | --- | --- | --- | --- |
| 141 | Milestone: Integration Phase Complete | 2017-03-29 → 2016-03-24 (-370d) | 2017-03-29 → 2016-03-24 (-370d) |  | 1d → 2d | baseline start none → 2016-03-22; baseline finish none → 2016-03-22 |
| 142 | **VERIFICATION and STAGING** | 2016-10-28 → 2015-10-26 (-368d) | 2017-04-20 → 2016-04-15 (-370d) | 125d → 117d | 6d → 7d | baseline start none → 2015-10-22; baseline finish none → 2016-04-13 |
| 143 | Unit Testing of all modules | 2016-10-28 → 2015-10-26 (-368d) | 2016-12-22 → 2015-12-18 (-370d) |  |  | baseline start none → 2015-10-22; baseline finish none → 2015-12-16 |
| 144 | Functional Testing | 2016-12-23 → 2015-12-21 (-368d) | 2017-01-12 → 2016-01-08 (-370d) |  |  | baseline start none → 2015-12-17; baseline finish none → 2016-01-06 |
| 145 | Installation and Deploy Testing | 2017-01-13 → 2016-01-11 (-368d) | 2017-01-26 → 2016-01-22 (-370d) |  |  | baseline start none → 2016-01-07; baseline finish none → 2016-01-20 |
| 146 | Performance Testing | 2017-01-27 → 2016-01-25 (-368d) | 2017-02-09 → 2016-02-05 (-370d) |  |  | baseline start none → 2016-01-21; baseline finish none → 2016-02-03 |
| 147 | Usability Testing | 2017-02-10 → 2016-02-08 (-368d) | 2017-02-23 → 2016-02-19 (-370d) |  |  | baseline start none → 2016-02-04; baseline finish none → 2016-02-17 |
| 148 | Alpha Testing | 2017-02-24 → 2016-02-22 (-368d) | 2017-03-09 → 2016-03-04 (-370d) |  | 6d → 7d | baseline start none → 2016-02-18; baseline finish none → 2016-03-02 |
| 149 | UAT Scripting | 2017-03-10 → 2016-03-07 (-368d) | 2017-03-23 → 2016-03-18 (-370d) |  | 6d → 7d | baseline start none → 2016-03-03; baseline finish none → 2016-03-16 |
| 150 | UAT cases review and approval | 2017-03-24 → 2016-03-21 (-368d) | 2017-04-06 → 2016-04-01 (-370d) |  | 6d → 7d | baseline start none → 2016-03-17; baseline finish none → 2016-03-30 |
| 151 | User Acceptance Testing | 2017-04-07 → 2016-04-04 (-368d) | 2017-04-20 → 2016-04-15 (-370d) |  | 6d → 7d | baseline start none → 2016-03-31; baseline finish none → 2016-04-13 |
| 152 | Milestone: Testing Complete | 2017-04-20 → 2016-04-15 (-370d) | 2017-04-20 → 2016-04-15 (-370d) |  | 6d → 7d | baseline start none → 2016-04-13; baseline finish none → 2016-04-13 |
| 153 | **PRODUCTION DEPLOYMENT** | 2017-03-30 → 2016-03-25 (-370d) | 2017-04-27 → 2016-04-22 (-370d) | 21d → 20d | 1d → 2d | baseline start none → 2016-03-23; baseline finish none → 2016-04-20 |
| 154 | Hardware, Software, Database Setup, Configuration | 2017-03-30 → 2016-03-25 (-370d) | 2017-04-05 → 2016-03-31 (-370d) |  | 1d → 2d | baseline start none → 2016-03-23; baseline finish none → 2016-03-29 |
| 155 | Course Data Migration | 2017-04-06 → 2016-04-01 (-370d) | 2017-04-13 → 2016-04-08 (-370d) |  | 1d → 2d | baseline start none → 2016-03-30; baseline finish none → 2016-04-06 |
| 156 | Student Data Migration | 2017-04-14 → 2016-04-11 (-368d) | 2017-04-19 → 2016-04-14 (-370d) |  |  | baseline start none → 2016-04-07; baseline finish none → 2016-04-12 |
| 157 | Course Creation - all Colleges | 2017-04-20 → 2016-04-15 (-370d) | 2017-04-26 → 2016-04-21 (-370d) |  |  | baseline start none → 2016-04-13; baseline finish none → 2016-04-19 |
| 158 | Roles and Accounts | 2017-04-27 → 2016-04-22 (-370d) | 2017-04-27 → 2016-04-22 (-370d) |  | 1d → 2d | baseline start none → 2016-04-20; baseline finish none → 2016-04-20 |
| 159 | Milestone: Prod Deploy Complete | 2017-04-27 → 2016-04-22 (-370d) | 2017-04-27 → 2016-04-22 (-370d) |  | 1d → 2d | baseline start none → 2016-04-20; baseline finish none → 2016-04-20 |
| 160 | **Maintenance Handover** | 2017-02-10 → 2016-02-09 (-367d) | 2017-04-28 → 2016-04-26 (-367d) | 56d → 54d |  | baseline start none → 2016-02-05; baseline finish none → 2016-04-22 |
| 161 | Training Calendar | 2017-02-10 → 2016-02-09 (-367d) | 2017-02-14 → 2016-02-11 (-369d) |  |  | baseline start none → 2016-02-05; baseline finish none → 2016-02-09 |
| 162 | Maintenance Vendor Selection | 2017-02-15 → 2016-02-12 (-369d) | 2017-03-14 → 2016-03-10 (-369d) |  |  | baseline start none → 2016-02-10; baseline finish none → 2016-03-08 |
| 163 | Maintenance Vendor Engagement | 2017-03-15 → 2016-03-11 (-369d) | 2017-03-21 → 2016-03-17 (-369d) |  |  | baseline start none → 2016-03-09; baseline finish none → 2016-03-15 |
| 164 | User Manual | 2017-03-22 → 2016-03-18 (-369d) | 2017-04-04 → 2016-03-31 (-369d) |  |  | baseline start none → 2016-03-16; baseline finish none → 2016-03-29 |
| 165 | Administration Manual | 2017-04-05 → 2016-04-01 (-369d) | 2017-04-18 → 2016-04-14 (-369d) |  |  | baseline start none → 2016-03-30; baseline finish none → 2016-04-12 |
| 166 | Techno Functional Handover | 2017-04-19 → 2016-04-15 (-369d) | 2017-04-21 → 2016-04-19 (-367d) |  |  | baseline start none → 2016-04-13; baseline finish none → 2016-04-15 |
| 167 | Training Org Wide | 2017-04-24 → 2016-04-20 (-369d) | 2017-04-28 → 2016-04-26 (-367d) |  |  | baseline start none → 2016-04-18; baseline finish none → 2016-04-22 |
| 168 | **BUGZILLA** | 2017-04-24 → 2016-04-20 (-369d) | 2017-04-28 → 2016-04-26 (-367d) |  |  | baseline start none → 2016-04-18; baseline finish none → 2016-04-22 |
| 169 | Issue Tracking BUGZILLA installation | 2017-04-24 → 2016-04-20 (-369d) | 2017-04-25 → 2016-04-21 (-369d) |  |  | baseline start none → 2016-04-18; baseline finish none → 2016-04-19 |
| 170 | Bugzilla accounts, training and access handover | 2017-04-26 → 2016-04-22 (-369d) | 2017-04-28 → 2016-04-26 (-367d) |  |  | baseline start none → 2016-04-20; baseline finish none → 2016-04-22 |
| 171 | Milestone: Project Complete | 2017-04-28 → 2016-04-26 (-367d) | 2017-04-28 → 2016-04-26 (-367d) |  |  | baseline start none → 2016-04-22; baseline finish none → 2016-04-22 |

## Version 4 (saved 2025-04-02, file 12.0 Project Exercise 10 - Learning Management System Implementation_ver3.0.mpp)

Last finish 2016-04-26 → 2016-04-22 (-4d). Complete tasks 16 → 0.

Changed:

| ID | Task | Start | Finish | Duration | Complete | Total float |
| --- | --- | --- | --- | --- | --- | --- |
| 1 | **Planning Phase** | 2015-04-06 A → 2015-04-06 | 2015-05-25 → 2015-05-22 (-3d) |  | 99% → 0% | 230d → 0d |
| 2 | Strategic Objectives | 2015-04-06 A → 2015-04-06 | 2015-04-14 A → 2015-04-14 |  | 100% → 0% | none → 0d |
| 3 | Budgetary Objectives | 2015-04-15 A → 2015-04-15 | 2015-04-21 A → 2015-04-21 |  | 100% → 0% | none → 0d |
| 4 | Compliance and Regulatory requirements | 2015-04-22 A → 2015-04-22 | 2015-04-29 A → 2015-04-29 |  | 100% → 0% | none → 0d |
| 5 | Partners/Suppliers/Corporate Objectives | 2015-04-30 A → 2015-04-30 | 2015-05-01 A → 2015-05-01 |  | 100% → 0% | none → 0d |
| 6 | Doc: Strategic Objectives document | 2015-05-04 A → 2015-05-04 | 2015-05-12 A → 2015-05-12 |  | 100% → 0% | none → 0d |
| 7 | Review Objectives Document | 2015-05-13 A → 2015-05-13 | 2015-05-19 A → 2015-05-19 |  | 100% → 0% | none → 0d |
| 8 | Signoff Objectives | 2015-05-20 A → 2015-05-20 | 2015-05-25 A → 2015-05-22 (-3d) | 4d → 3d | 100% → 0% | none → 0d |
| 9 | Milestone: Planning Complete | 2015-05-25 → 2015-05-22 (-3d) | 2015-05-25 → 2015-05-22 (-3d) |  |  | 230d → 0d |
| 10 | **Weekly Review Meeting** | 2015-06-01 A → 2015-06-01 |  |  | 13% → 0% | 40.75d → 38.75d |
| 11 | Weekly Review Meeting 1 | 2015-06-01 A → 2015-06-01 | 2015-06-01 A → 2015-06-01 |  | 100% → 0% | none → 223.75d |
| 12 | Weekly Review Meeting 2 | 2015-06-08 A → 2015-06-08 | 2015-06-08 A → 2015-06-08 |  | 100% → 0% | none → 218.75d |
| 13 | Weekly Review Meeting 3 | 2015-06-15 A → 2015-06-15 | 2015-06-15 A → 2015-06-15 |  | 100% → 0% | none → 213.75d |
| 14 | Weekly Review Meeting 4 | 2015-06-22 A → 2015-06-22 | 2015-06-22 A → 2015-06-22 |  | 100% → 0% | none → 208.75d |
| 15 | Weekly Review Meeting 5 | 2015-06-29 A → 2015-06-29 | 2015-06-29 A → 2015-06-29 |  | 100% → 0% | none → 203.75d |
| 51 | **Detailed Design Phase** | 2015-05-26 A → 2015-05-25 (-1d) | 2015-09-04 → 2015-09-02 (-2d) | 73d → 71d | 34% → 0% | 157d → 0d |
| 52 | Technology Considerations | 2015-05-26 A → 2015-05-25 (-1d) | 2015-05-28 A → 2015-05-27 (-1d) |  | 100% → 0% | none → 0d |
| 53 | Integration Considerations | 2015-05-29 A → 2015-05-28 (-1d) | 2015-06-05 A → 2015-06-04 (-1d) |  | 100% → 0% | none → 0d |
| 54 | Non Functional Requirements | 2015-06-08 A → 2015-06-05 (-3d) | 2015-06-15 A → 2015-06-12 (-3d) |  | 100% → 0% | none → 0d |
| 55 | Administrative Needs and Roles | 2015-06-16 A → 2015-06-15 (-1d) | 2015-06-24 → 2015-06-18 (-6d) | 7d → 4d | 86% → 0% | 208d → 0d |
| 56 | RACI Matrix for LMS - Org wide | 2015-06-25 A → 2015-06-19 (-6d) | 2015-06-30 A → 2015-06-26 (-4d) | 4d → 6d | 100% → 0% | none → 0d |
| 57 | Content Strategy | 2015-07-01 → 2015-06-29 (-2d) | 2015-07-14 → 2015-07-10 (-4d) |  |  |  |
| 58 | Marketing Requirements | 2015-07-15 → 2015-07-13 (-2d) | 2015-07-21 → 2015-07-17 (-4d) |  |  |  |
| 59 | Deployment Plan (rollout to all colleges) | 2015-07-22 → 2015-07-20 (-2d) | 2015-07-28 → 2015-07-24 (-4d) |  |  |  |
| 60 | Doc: Functional Specification Document (FSD) | 2015-07-29 → 2015-07-27 (-2d) | 2015-08-04 → 2015-07-31 (-4d) |  |  |  |
| 61 | Review: FSD | 2015-08-05 → 2015-08-03 (-2d) | 2015-08-06 → 2015-08-04 (-2d) |  |  |  |
| 62 | Signoff: FSD | 2015-08-07 → 2015-08-05 (-2d) | 2015-08-10 → 2015-08-06 (-4d) |  |  |  |
| 63 | Doc: Technical Specifications Document (TSD) | 2015-08-11 → 2015-08-07 (-4d) | 2015-08-17 → 2015-08-13 (-4d) |  |  |  |
| 64 | Review: TSD | 2015-08-18 → 2015-08-14 (-4d) | 2015-08-19 → 2015-08-17 (-2d) |  |  |  |
| 65 | Signoff: TSD | 2015-08-20 → 2015-08-18 (-2d) | 2015-08-21 → 2015-08-19 (-2d) |  |  |  |
| 66 | Content Strategy Document (CSD) | 2015-08-24 → 2015-08-20 (-4d) | 2015-09-04 → 2015-09-02 (-2d) |  |  |  |
| 67 | Milestone: Detailed Design Complete | 2015-09-04 → 2015-09-02 (-2d) | 2015-09-04 → 2015-09-02 (-2d) |  |  |  |
| 68 | **Implementation Phase** | 2015-09-07 → 2015-09-03 (-4d) | 2016-01-08 → 2016-01-06 (-2d) |  |  |  |
| 69 | Testing Server Setup | 2015-09-07 → 2015-09-03 (-4d) | 2015-09-08 → 2015-09-04 (-4d) |  |  |  |
| 70 | Development Server Setup | 2015-09-09 → 2015-09-07 (-2d) | 2015-09-10 → 2015-09-08 (-2d) |  |  | 89d → 88d |
| 71 | Install: Moodle Test installation | 2015-09-11 → 2015-09-09 (-2d) | 2015-09-11 → 2015-09-09 (-2d) |  |  |  |
| 72 | Database design | 2015-09-14 → 2015-09-10 (-4d) | 2015-09-18 → 2015-09-16 (-2d) |  |  |  |
| 73 | Doc: Upgrade Strategy Document (USD) | 2015-09-21 → 2015-09-17 (-4d) | 2015-09-25 → 2015-09-23 (-2d) |  |  |  |
| 74 | **Moodle: LMS Structure** | 2015-09-28 → 2015-09-24 (-4d) | 2015-10-23 → 2015-10-21 (-2d) |  |  |  |
| 75 | Home Page | 2015-09-28 → 2015-09-24 (-4d) | 2015-09-30 → 2015-09-28 (-2d) |  |  |  |
| 76 | Main Landing Page | 2015-10-01 → 2015-09-29 (-2d) | 2015-10-12 → 2015-10-08 (-4d) |  |  | 89d → 88d |
| 77 | Institution Landing Pages | 2015-10-13 → 2015-10-09 (-4d) | 2015-10-19 → 2015-10-15 (-4d) |  |  | 89d → 88d |
| 78 | Course Landing Pages | 2015-10-20 → 2015-10-16 (-4d) | 2015-10-23 → 2015-10-21 (-2d) |  |  |  |
| 79 | **Moodle: Course Design and Planning** | 2015-10-26 → 2015-10-22 (-4d) | 2015-11-10 → 2015-11-06 (-4d) |  |  |  |
| 80 | Courses Upload | 2015-10-26 → 2015-10-22 (-4d) | 2015-10-30 → 2015-10-28 (-2d) |  |  |  |
| 81 | Courses Structuring | 2015-11-02 → 2015-10-29 (-4d) | 2015-11-05 → 2015-11-03 (-2d) |  |  |  |
| 82 | Courses Support Material Upload | 2015-11-06 → 2015-11-04 (-2d) | 2015-11-10 → 2015-11-06 (-4d) |  |  |  |
| 83 | **Moodle: Course Creation** | 2015-11-11 → 2015-11-09 (-2d) | 2015-11-26 → 2015-11-24 (-2d) | 10d → 11d |  |  |
| 84 | Course Space Creation | 2015-11-11 → 2015-11-09 (-2d) | 2015-11-17 → 2015-11-13 (-4d) |  |  |  |
| 85 | Course Pages | 2015-11-18 → 2015-11-16 (-2d) | 2015-11-23 → 2015-11-19 (-4d) |  |  |  |
| 86 | Assessment Requirements | 2015-11-24 → 2015-11-20 (-4d) | 2015-11-26 → 2015-11-24 (-2d) |  |  |  |
| 87 | **Moodle: Performance and Control Considerations** | 2015-11-27 → 2015-11-25 (-2d) | 2015-12-14 → 2015-12-10 (-4d) | 11d → 10d |  | 91d → 90d |
| 88 | Automated and Manual Communications setup | 2015-11-27 → 2015-11-25 (-2d) | 2015-12-03 → 2015-12-01 (-2d) |  |  | 91d → 90d |
| 89 | Support Pages Configuration | 2015-12-04 → 2015-12-02 (-2d) | 2015-12-09 → 2015-12-07 (-2d) |  |  |  |
| 90 | Course Release Strategy | 2015-12-10 → 2015-12-08 (-2d) | 2015-12-14 → 2015-12-10 (-4d) |  |  |  |
| 91 | **LMS User Experience** | 2015-09-07 → 2015-09-03 (-4d) | 2015-10-22 → 2015-10-20 (-2d) |  |  |  |
| 92 | Doc: UX Design document (UXD) | 2015-09-07 → 2015-09-03 (-4d) | 2015-09-11 → 2015-09-09 (-2d) |  |  | 52d → 53d |
| 93 | Review: UXD | 2015-09-14 → 2015-09-10 (-4d) | 2015-09-15 → 2015-09-11 (-4d) |  |  |  |
| 94 | Signoff: UXD | 2015-09-16 → 2015-09-14 (-2d) | 2015-09-17 → 2015-09-15 (-2d) |  |  |  |
| 95 | Custom Theme Development | 2015-09-18 → 2015-09-16 (-2d) | 2015-10-01 → 2015-09-29 (-2d) |  |  |  |
| 96 | Department-wide custom themes | 2015-10-02 → 2015-09-30 (-2d) | 2015-10-08 → 2015-10-06 (-2d) |  |  | 51d → 52d |
| 97 | Logo and Branding requirements | 2015-10-09 → 2015-10-07 (-2d) | 2015-10-15 → 2015-10-13 (-2d) |  |  | 51d → 52d |
| 98 | Marketing UX reqts | 2015-10-16 → 2015-10-14 (-2d) | 2015-10-22 → 2015-10-20 (-2d) |  |  |  |
| 99 | Milestone: UX complete | 2015-10-22 → 2015-10-20 (-2d) | 2015-10-22 → 2015-10-20 (-2d) |  |  |  |
| 100 | **LMS Content Migration** | 2015-09-07 → 2015-09-03 (-4d) | 2016-01-08 → 2016-01-06 (-2d) |  |  |  |
| 101 | Content Vendor Selection | 2015-09-07 → 2015-09-03 (-4d) | 2015-09-11 → 2015-09-09 (-2d) |  |  |  |
| 102 | Content Vendor Engage | 2015-09-14 → 2015-09-10 (-4d) | 2015-09-18 → 2015-09-16 (-2d) |  |  |  |
| 103 | Migrate SCORM Content | 2015-09-21 → 2015-09-17 (-4d) | 2015-10-02 → 2015-09-30 (-2d) |  |  |  |
| 104 | Vendonr: New Content Creation | 2015-10-05 → 2015-10-01 (-4d) | 2015-12-25 → 2015-12-23 (-2d) |  |  |  |
| 105 | Vendor: New content Upload | 2015-12-28 → 2015-12-24 (-4d) | 2016-01-08 → 2016-01-06 (-2d) |  |  |  |

| ID | Task | Start | Finish | Duration | Total float | Other |
| --- | --- | --- | --- | --- | --- | --- |
| 106 | Milestone: Migration done | 2016-01-08 → 2016-01-06 (-2d) | 2016-01-08 → 2016-01-06 (-2d) |  |  |  |
| 107 | **Mobile App Development** | 2015-09-29 → 2015-09-25 (-4d) | 2015-12-21 → 2015-12-17 (-4d) |  |  |  |
| 108 | Mobile Dev Vendor Selection | 2015-09-29 → 2015-09-25 (-4d) | 2015-10-05 → 2015-10-01 (-4d) |  |  |  |
| 109 | Requirements and signoff | 2015-10-06 → 2015-10-02 (-4d) | 2015-10-19 → 2015-10-15 (-4d) |  |  |  |
| 110 | Notifications | 2015-10-20 → 2015-10-16 (-4d) | 2015-10-23 → 2015-10-21 (-2d) |  | 13d → 14d |  |
| 111 | Calendar | 2015-10-26 → 2015-10-22 (-4d) | 2015-10-27 → 2015-10-23 (-4d) |  |  |  |
| 112 | Quiz Engine | 2015-10-28 → 2015-10-26 (-2d) | 2015-11-17 → 2015-11-13 (-4d) |  |  |  |
| 113 | Annual Time Table | 2015-11-18 → 2015-11-16 (-2d) | 2015-11-19 → 2015-11-17 (-2d) |  |  |  |
| 114 | Messaging | 2015-11-20 → 2015-11-18 (-2d) | 2015-11-26 → 2015-11-24 (-2d) |  |  |  |
| 115 | Social Integration | 2015-11-27 → 2015-11-25 (-2d) | 2015-11-30 → 2015-11-26 (-4d) |  | 13d → 12d |  |
| 116 | Usability Testing | 2015-12-01 → 2015-11-27 (-4d) | 2015-12-07 → 2015-12-03 (-4d) |  |  |  |
| 117 | Functional Testing | 2015-12-08 → 2015-12-04 (-4d) | 2015-12-14 → 2015-12-10 (-4d) |  | 12d → 13d |  |
| 118 | Integration testing | 2015-12-15 → 2015-12-11 (-4d) | 2015-12-21 → 2015-12-17 (-4d) |  |  |  |
| 119 | Milestone: Mobile dev complete | 2015-12-21 → 2015-12-17 (-4d) | 2015-12-21 → 2015-12-17 (-4d) |  |  |  |
| 120 | **Testing Plan and Setup** | 2015-10-21 → 2015-10-19 (-2d) | 2015-12-08 → 2015-12-04 (-4d) |  |  |  |
| 121 | Doc: Test Specification Document (TSD) | 2015-10-21 → 2015-10-19 (-2d) | 2015-11-03 → 2015-10-30 (-4d) |  |  |  |
| 122 | Test team setup | 2015-11-04 → 2015-11-02 (-2d) | 2015-11-10 → 2015-11-06 (-4d) |  |  |  |
| 123 | Review: TSD | 2015-11-11 → 2015-11-09 (-2d) | 2015-11-13 → 2015-11-11 (-2d) |  |  |  |
| 124 | Signoff: TSD | 2015-11-16 → 2015-11-12 (-4d) | 2015-11-17 → 2015-11-13 (-4d) |  |  |  |
| 125 | Content Test Strategy | 2015-11-18 → 2015-11-16 (-2d) | 2015-12-01 → 2015-11-27 (-4d) |  |  |  |
| 126 | Usability Test Strategy | 2015-12-02 → 2015-11-30 (-2d) | 2015-12-08 → 2015-12-04 (-4d) |  |  |  |
| 127 | Milestone: Implementation Complete | 2016-01-08 → 2016-01-06 (-2d) | 2016-01-08 → 2016-01-06 (-2d) |  |  |  |
| 128 | **Integration Phase** | 2016-01-11 → 2016-01-07 (-4d) | 2016-03-24 → 2016-03-22 (-2d) |  |  |  |
| 129 | Single Sign On (SSO) Setup | 2016-01-11 → 2016-01-07 (-4d) | 2016-01-13 → 2016-01-11 (-2d) |  |  |  |
| 130 | Student Information System (SIS) Setup | 2016-01-14 → 2016-01-12 (-2d) | 2016-01-20 → 2016-01-18 (-2d) |  |  |  |
| 131 | Datewarehousing Integration (Learning Analytics) | 2016-01-21 → 2016-01-19 (-2d) | 2016-02-03 → 2016-02-01 (-2d) |  |  |  |
| 132 | SAP Integration | 2016-02-04 → 2016-02-02 (-2d) | 2016-02-24 → 2016-02-22 (-2d) |  |  |  |
| 133 | Accounting Software Setup | 2016-02-25 → 2016-02-23 (-2d) | 2016-03-02 → 2016-02-29 (-2d) |  |  |  |
| 134 | **STAGING SERVER SETUP** | 2016-03-03 → 2016-03-01 (-2d) | 2016-03-24 → 2016-03-22 (-2d) |  |  |  |
| 135 | Server setup, Redundancy setup | 2016-03-03 → 2016-03-01 (-2d) | 2016-03-07 → 2016-03-03 (-4d) |  |  |  |
| 136 | Database Configuration | 2016-03-08 → 2016-03-04 (-4d) | 2016-03-10 → 2016-03-08 (-2d) |  |  |  |
| 137 | LMS Installation | 2016-03-11 → 2016-03-09 (-2d) | 2016-03-14 → 2016-03-10 (-4d) |  |  |  |
| 138 | Course Data Migration | 2016-03-15 → 2016-03-11 (-4d) | 2016-03-17 → 2016-03-15 (-2d) |  |  |  |
| 139 | Student Data Import | 2016-03-18 → 2016-03-16 (-2d) | 2016-03-22 → 2016-03-18 (-4d) |  |  |  |
| 140 | RBAC Setup and testing | 2016-03-23 → 2016-03-21 (-2d) | 2016-03-24 → 2016-03-22 (-2d) |  |  |  |
| 141 | Milestone: Integration Phase Complete | 2016-03-24 → 2016-03-22 (-2d) | 2016-03-24 → 2016-03-22 (-2d) |  |  |  |
| 142 | **VERIFICATION and STAGING** | 2015-10-26 → 2015-10-22 (-4d) | 2016-04-15 → 2016-04-13 (-2d) | 117d → 118d | 7d → 6d | baseline start 2015-10-22 → 2015-10-19; baseline finish 2016-04-13 → 2016-04-11 |
| 143 | Unit Testing of all modules | 2015-10-26 → 2015-10-22 (-4d) | 2015-12-18 → 2015-12-16 (-2d) |  |  | baseline start 2015-10-22 → 2015-10-19; baseline finish 2015-12-16 → 2015-12-14 |
| 144 | Functional Testing | 2015-12-21 → 2015-12-17 (-4d) | 2016-01-08 → 2016-01-06 (-2d) |  |  | baseline start 2015-12-17 → 2015-12-14; baseline finish 2016-01-06 → 2016-01-04 |
| 145 | Installation and Deploy Testing | 2016-01-11 → 2016-01-07 (-4d) | 2016-01-22 → 2016-01-20 (-2d) |  | 6d → 7d | baseline start 2016-01-07 → 2016-01-04; baseline finish 2016-01-20 → 2016-01-18 |
| 146 | Performance Testing | 2016-01-25 → 2016-01-21 (-4d) | 2016-02-05 → 2016-02-03 (-2d) |  | 6d → 7d | baseline start 2016-01-21 → 2016-01-18; baseline finish 2016-02-03 → 2016-02-01 |
| 147 | Usability Testing | 2016-02-08 → 2016-02-04 (-4d) | 2016-02-19 → 2016-02-17 (-2d) |  | 6d → 7d | baseline start 2016-02-04 → 2016-02-01; baseline finish 2016-02-17 → 2016-02-15 |
| 148 | Alpha Testing | 2016-02-22 → 2016-02-18 (-4d) | 2016-03-04 → 2016-03-02 (-2d) |  |  | baseline start 2016-02-18 → 2016-02-15; baseline finish 2016-03-02 → 2016-02-29 |
| 149 | UAT Scripting | 2016-03-07 → 2016-03-03 (-4d) | 2016-03-18 → 2016-03-16 (-2d) |  |  | baseline start 2016-03-03 → 2016-02-29; baseline finish 2016-03-16 → 2016-03-14 |
| 150 | UAT cases review and approval | 2016-03-21 → 2016-03-17 (-4d) | 2016-04-01 → 2016-03-30 (-2d) |  |  | baseline start 2016-03-17 → 2016-03-14; baseline finish 2016-03-30 → 2016-03-28 |
| 151 | User Acceptance Testing | 2016-04-04 → 2016-03-31 (-4d) | 2016-04-15 → 2016-04-13 (-2d) |  | 7d → 6d | baseline start 2016-03-31 → 2016-03-28; baseline finish 2016-04-13 → 2016-04-11 |
| 152 | Milestone: Testing Complete | 2016-04-15 → 2016-04-13 (-2d) | 2016-04-15 → 2016-04-13 (-2d) |  | 7d → 6d | baseline start 2016-04-13 → 2016-04-11; baseline finish 2016-04-13 → 2016-04-11 |
| 153 | **PRODUCTION DEPLOYMENT** | 2016-03-25 → 2016-03-23 (-2d) | 2016-04-22 → 2016-04-20 (-2d) |  |  |  |
| 154 | Hardware, Software, Database Setup, Configuration | 2016-03-25 → 2016-03-23 (-2d) | 2016-03-31 → 2016-03-29 (-2d) |  |  |  |
| 155 | Course Data Migration | 2016-04-01 → 2016-03-30 (-2d) | 2016-04-08 → 2016-04-06 (-2d) |  |  |  |
| 156 | Student Data Migration | 2016-04-11 → 2016-04-07 (-4d) | 2016-04-14 → 2016-04-12 (-2d) |  | 1d → 2d |  |
| 157 | Course Creation - all Colleges | 2016-04-15 → 2016-04-13 (-2d) | 2016-04-21 → 2016-04-19 (-2d) |  | 1d → 2d |  |
| 158 | Roles and Accounts | 2016-04-22 → 2016-04-20 (-2d) | 2016-04-22 → 2016-04-20 (-2d) |  |  |  |
| 159 | Milestone: Prod Deploy Complete | 2016-04-22 → 2016-04-20 (-2d) | 2016-04-22 → 2016-04-20 (-2d) |  |  |  |
| 160 | **Maintenance Handover** | 2016-02-09 → 2016-02-05 (-4d) | 2016-04-26 → 2016-04-22 (-4d) |  |  |  |
| 161 | Training Calendar | 2016-02-09 → 2016-02-05 (-4d) | 2016-02-11 → 2016-02-09 (-2d) |  |  |  |
| 162 | Maintenance Vendor Selection | 2016-02-12 → 2016-02-10 (-2d) | 2016-03-10 → 2016-03-08 (-2d) |  |  |  |
| 163 | Maintenance Vendor Engagement | 2016-03-11 → 2016-03-09 (-2d) | 2016-03-17 → 2016-03-15 (-2d) |  |  |  |
| 164 | User Manual | 2016-03-18 → 2016-03-16 (-2d) | 2016-03-31 → 2016-03-29 (-2d) |  |  |  |
| 165 | Administration Manual | 2016-04-01 → 2016-03-30 (-2d) | 2016-04-14 → 2016-04-12 (-2d) |  |  |  |
| 166 | Techno Functional Handover | 2016-04-15 → 2016-04-13 (-2d) | 2016-04-19 → 2016-04-15 (-4d) |  |  |  |
| 167 | Training Org Wide | 2016-04-20 → 2016-04-18 (-2d) | 2016-04-26 → 2016-04-22 (-4d) |  |  |  |
| 168 | **BUGZILLA** | 2016-04-20 → 2016-04-18 (-2d) | 2016-04-26 → 2016-04-22 (-4d) |  |  |  |
| 169 | Issue Tracking BUGZILLA installation | 2016-04-20 → 2016-04-18 (-2d) | 2016-04-21 → 2016-04-19 (-2d) |  |  |  |
| 170 | Bugzilla accounts, training and access handover | 2016-04-22 → 2016-04-20 (-2d) | 2016-04-26 → 2016-04-22 (-4d) |  |  |  |
| 171 | Milestone: Project Complete | 2016-04-26 → 2016-04-22 (-4d) | 2016-04-26 → 2016-04-22 (-4d) |  |  |  |

## Version 5 (saved 2025-04-02, file 12.0 Project Exercise 10 - Learning Management System Implementation_ver4.0.mpp)

Last finish stays 2016-04-22.

Changed:

| ID | Task | Other |
| --- | --- | --- |
| 142 | **VERIFICATION and STAGING** | baseline start 2015-10-19 → 2015-10-22; baseline finish 2016-04-11 → 2016-04-13 |
| 143 | Unit Testing of all modules | baseline start 2015-10-19 → 2015-10-22; baseline finish 2015-12-14 → 2015-12-16 |
| 144 | Functional Testing | baseline start 2015-12-14 → 2015-12-17; baseline finish 2016-01-04 → 2016-01-06 |
| 145 | Installation and Deploy Testing | baseline start 2016-01-04 → 2016-01-07; baseline finish 2016-01-18 → 2016-01-20 |
| 146 | Performance Testing | baseline start 2016-01-18 → 2016-01-21; baseline finish 2016-02-01 → 2016-02-03 |
| 147 | Usability Testing | baseline start 2016-02-01 → 2016-02-04; baseline finish 2016-02-15 → 2016-02-17 |
| 148 | Alpha Testing | baseline start 2016-02-15 → 2016-02-18; baseline finish 2016-02-29 → 2016-03-02 |
| 149 | UAT Scripting | baseline start 2016-02-29 → 2016-03-03; baseline finish 2016-03-14 → 2016-03-16 |
| 150 | UAT cases review and approval | baseline start 2016-03-14 → 2016-03-17; baseline finish 2016-03-28 → 2016-03-30 |
| 151 | User Acceptance Testing | baseline start 2016-03-28 → 2016-03-31; baseline finish 2016-04-11 → 2016-04-13 |
| 152 | Milestone: Testing Complete | baseline start 2016-04-11 → 2016-04-13; baseline finish 2016-04-11 → 2016-04-13 |

## Version 6 (data date 2016-02-29, saved 2025-04-02, file 12.0 Project Exercise 10 - Learning Management System Implementation_ver9.0.mpp)

Last finish 2016-04-22 → 2016-05-05 (+13d). Complete tasks 0 → 121.

Changed:

| ID | Task | Start | Finish | Duration | Complete | Total float |
| --- | --- | --- | --- | --- | --- | --- |
| 1 | **Planning Phase** | 2015-04-06 A | 2015-05-22 → 2015-05-25 A (+3d) |  | 0% → 100% | 0d → none |
| 2 | Strategic Objectives | 2015-04-06 A | 2015-04-14 A |  | 0% → 100% | 0d → none |
| 3 | Budgetary Objectives | 2015-04-15 A | 2015-04-21 A |  | 0% → 100% | 0d → none |
| 4 | Compliance and Regulatory requirements | 2015-04-22 A | 2015-04-29 A |  | 0% → 100% | 0d → none |
| 5 | Partners/Suppliers/Corporate Objectives | 2015-04-30 A | 2015-05-01 A |  | 0% → 100% | 0d → none |
| 6 | Doc: Strategic Objectives document | 2015-05-04 A | 2015-05-12 A |  | 0% → 100% | 0d → none |
| 7 | Review Objectives Document | 2015-05-13 A | 2015-05-19 A |  | 0% → 100% | 0d → none |
| 8 | Signoff Objectives | 2015-05-20 A | 2015-05-22 → 2015-05-25 A (+3d) | 3d → 4d | 0% → 100% | 0d → none |
| 9 | Milestone: Planning Complete | 2015-05-22 → 2015-05-25 A (+3d) | 2015-05-22 → 2015-05-25 A (+3d) |  | 0% → 100% | 0d → none |
| 10 | **Weekly Review Meeting** | 2015-06-01 A | 2016-02-29 A |  | 0% → 100% | 38.75d → none |
| 11 | Weekly Review Meeting 1 | 2015-06-01 A | 2015-06-01 A |  | 0% → 100% | 223.75d → none |
| 12 | Weekly Review Meeting 2 | 2015-06-08 A | 2015-06-08 A |  | 0% → 100% | 218.75d → none |
| 13 | Weekly Review Meeting 3 | 2015-06-15 A | 2015-06-15 A |  | 0% → 100% | 213.75d → none |
| 14 | Weekly Review Meeting 4 | 2015-06-22 A | 2015-06-22 A |  | 0% → 100% | 208.75d → none |
| 15 | Weekly Review Meeting 5 | 2015-06-29 A | 2015-06-29 A |  | 0% → 100% | 203.75d → none |
| 16 | Weekly Review Meeting 6 | 2015-07-06 A | 2015-07-06 A |  | 0% → 100% | 199.75d → none |
| 17 | Weekly Review Meeting 7 | 2015-07-13 A | 2015-07-13 A |  | 0% → 100% | 194.75d → none |
| 18 | Weekly Review Meeting 8 | 2015-07-20 A | 2015-07-20 A |  | 0% → 100% | 189.75d → none |
| 19 | Weekly Review Meeting 9 | 2015-07-27 A | 2015-07-27 A |  | 0% → 100% | 184.75d → none |
| 20 | Weekly Review Meeting 10 | 2015-08-03 A | 2015-08-03 A |  | 0% → 100% | 179.75d → none |
| 21 | Weekly Review Meeting 11 | 2015-08-10 A | 2015-08-10 A |  | 0% → 100% | 174.75d → none |
| 22 | Weekly Review Meeting 12 | 2015-08-17 A | 2015-08-17 A |  | 0% → 100% | 169.75d → none |
| 23 | Weekly Review Meeting 13 | 2015-08-24 A | 2015-08-24 A |  | 0% → 100% | 164.75d → none |
| 24 | Weekly Review Meeting 14 | 2015-08-31 A | 2015-08-31 A |  | 0% → 100% | 159.75d → none |
| 25 | Weekly Review Meeting 15 | 2015-09-08 A | 2015-09-08 A |  | 0% → 100% | 154.75d → none |
| 26 | Weekly Review Meeting 16 | 2015-09-14 A | 2015-09-14 A |  | 0% → 100% | 150.75d → none |
| 27 | Weekly Review Meeting 17 | 2015-09-21 A | 2015-09-21 A |  | 0% → 100% | 145.75d → none |
| 28 | Weekly Review Meeting 18 | 2015-09-28 A | 2015-09-28 A |  | 0% → 100% | 140.75d → none |
| 29 | Weekly Review Meeting 19 | 2015-10-05 A | 2015-10-05 A |  | 0% → 100% | 135.75d → none |
| 30 | Weekly Review Meeting 20 | 2015-10-13 A | 2015-10-13 A |  | 0% → 100% | 130.75d → none |
| 31 | Weekly Review Meeting 21 | 2015-10-19 A | 2015-10-19 A |  | 0% → 100% | 126.75d → none |
| 32 | Weekly Review Meeting 22 | 2015-10-26 A | 2015-10-26 A |  | 0% → 100% | 121.75d → none |
| 33 | Weekly Review Meeting 23 | 2015-11-02 A | 2015-11-02 A |  | 0% → 100% | 116.75d → none |
| 34 | Weekly Review Meeting 24 | 2015-11-09 A | 2015-11-09 A |  | 0% → 100% | 111.75d → none |
| 35 | Weekly Review Meeting 25 | 2015-11-16 A | 2015-11-16 A |  | 0% → 100% | 107.75d → none |
| 36 | Weekly Review Meeting 26 | 2015-11-23 A | 2015-11-23 A |  | 0% → 100% | 102.75d → none |
| 37 | Weekly Review Meeting 27 | 2015-11-30 A | 2015-11-30 A |  | 0% → 100% | 99.75d → none |
| 38 | Weekly Review Meeting 28 | 2015-12-07 A | 2015-12-07 A |  | 0% → 100% | 94.75d → none |
| 39 | Weekly Review Meeting 29 | 2015-12-14 A | 2015-12-14 A |  | 0% → 100% | 89.75d → none |
| 40 | Weekly Review Meeting 30 | 2015-12-21 A | 2015-12-21 A |  | 0% → 100% | 84.75d → none |
| 41 | Weekly Review Meeting 31 | 2015-12-28 A | 2015-12-28 A |  | 0% → 100% | 80.75d → none |
| 42 | Weekly Review Meeting 32 | 2016-01-04 A | 2016-01-04 A |  | 0% → 100% | 76.75d → none |
| 43 | Weekly Review Meeting 33 | 2016-01-11 A | 2016-01-11 A |  | 0% → 100% | 71.75d → none |
| 44 | Weekly Review Meeting 34 | 2016-01-19 A | 2016-01-19 A |  | 0% → 100% | 66.75d → none |
| 45 | Weekly Review Meeting 35 | 2016-01-25 A | 2016-01-25 A |  | 0% → 100% | 62.75d → none |
| 46 | Weekly Review Meeting 36 | 2016-02-01 A | 2016-02-01 A |  | 0% → 100% | 57.75d → none |
| 47 | Weekly Review Meeting 37 | 2016-02-08 A | 2016-02-08 A |  | 0% → 100% | 52.75d → none |
| 48 | Weekly Review Meeting 38 | 2016-02-16 A | 2016-02-16 A |  | 0% → 100% | 47.75d → none |
| 49 | Weekly Review Meeting 39 | 2016-02-22 A | 2016-02-22 A |  | 0% → 100% | 43.75d → none |
| 50 | Weekly Review Meeting 40 | 2016-02-29 A | 2016-02-29 A |  | 0% → 100% | 38.75d → none |
| 51 | **Detailed Design Phase** | 2015-05-25 → 2015-05-26 A (+1d) | 2015-09-02 → 2015-09-08 (+6d) | 71d → 74d | 0% → 99% | 0d → 163d |
| 52 | Technology Considerations | 2015-05-25 → 2015-05-26 A (+1d) | 2015-05-27 → 2015-05-28 A (+1d) |  | 0% → 100% | 0d → none |
| 53 | Integration Considerations | 2015-05-28 → 2015-05-29 A (+1d) | 2015-06-04 → 2015-06-05 A (+1d) |  | 0% → 100% | 0d → none |
| 54 | Non Functional Requirements | 2015-06-05 → 2015-06-08 A (+3d) | 2015-06-12 → 2015-06-15 A (+3d) |  | 0% → 100% | 0d → none |
| 55 | Administrative Needs and Roles | 2015-06-15 → 2015-06-16 A (+1d) | 2015-06-18 → 2015-06-24 (+6d) | 4d → 7d | 0% → 86% | 0d → 215d |
| 56 | RACI Matrix for LMS - Org wide | 2015-06-19 → 2015-06-25 A (+6d) | 2015-06-26 → 2015-06-30 A (+4d) | 6d → 4d | 0% → 100% | 0d → none |
| 57 | Content Strategy | 2015-06-29 → 2015-07-01 A (+2d) | 2015-07-10 → 2015-07-16 A (+6d) | 2w → 2.4w | 0% → 100% | 0d → none |
| 58 | Marketing Requirements | 2015-07-13 → 2015-07-17 A (+4d) | 2015-07-17 → 2015-07-23 A (+6d) |  | 0% → 100% | 0d → none |
| 59 | Deployment Plan (rollout to all colleges) | 2015-07-20 → 2015-07-24 A (+4d) | 2015-07-24 → 2015-07-30 A (+6d) |  | 0% → 100% | 0d → none |
| 60 | Doc: Functional Specification Document (FSD) | 2015-07-27 → 2015-07-31 A (+4d) | 2015-07-31 → 2015-08-06 A (+6d) |  | 0% → 100% | 0d → none |
| 61 | Review: FSD | 2015-08-03 → 2015-08-07 A (+4d) | 2015-08-04 → 2015-08-10 A (+6d) |  | 0% → 100% | 0d → none |
| 62 | Signoff: FSD | 2015-08-05 → 2015-08-11 A (+6d) | 2015-08-06 → 2015-08-12 A (+6d) |  | 0% → 100% | 0d → none |
| 63 | Doc: Technical Specifications Document (TSD) | 2015-08-07 → 2015-08-13 A (+6d) | 2015-08-13 → 2015-08-19 A (+6d) |  | 0% → 100% | 0d → none |
| 64 | Review: TSD | 2015-08-14 → 2015-08-20 A (+6d) | 2015-08-17 → 2015-08-21 A (+4d) |  | 0% → 100% | 0d → none |
| 65 | Signoff: TSD | 2015-08-18 → 2015-08-24 A (+6d) | 2015-08-19 → 2015-08-25 A (+6d) |  | 0% → 100% | 0d → none |
| 66 | Content Strategy Document (CSD) | 2015-08-20 → 2015-08-26 A (+6d) | 2015-09-02 → 2015-09-08 A (+6d) |  | 0% → 100% | 0d → none |
| 67 | Milestone: Detailed Design Complete | 2015-09-02 → 2015-09-08 A (+6d) | 2015-09-02 → 2015-09-08 A (+6d) |  | 0% → 100% | 0d → none |
| 68 | **Implementation Phase** | 2015-09-03 → 2015-09-09 A (+6d) | 2016-01-06 → 2016-01-19 (+13d) | 83d → 88d | 0% → 99% | 0d → 75d |
| 69 | Testing Server Setup | 2015-09-03 → 2015-09-09 A (+6d) | 2015-09-04 → 2015-09-10 A (+6d) |  | 0% → 100% | 88d → none |
| 70 | Development Server Setup | 2015-09-07 → 2015-09-11 A (+4d) | 2015-09-08 → 2015-09-14 A (+6d) |  | 0% → 100% | 88d → none |

| ID | Task | Start | Finish | Duration | Complete | Total float | Other |
| --- | --- | --- | --- | --- | --- | --- | --- |
| 71 | Install: Moodle Test installation | 2015-09-09 → 2015-09-15 A (+6d) | 2015-09-09 → 2015-09-15 A (+6d) |  | 0% → 100% | 89d → none |  |
| 72 | Database design | 2015-09-10 → 2015-09-16 A (+6d) | 2015-09-16 → 2015-09-22 A (+6d) |  | 0% → 100% | 89d → none |  |
| 73 | Doc: Upgrade Strategy Document (USD) | 2015-09-17 → 2015-09-23 A (+6d) | 2015-09-23 → 2015-09-29 A (+6d) |  | 0% → 100% | 89d → none |  |
| 74 | **Moodle: LMS Structure** | 2015-09-24 → 2015-09-30 A (+6d) | 2015-10-21 → 2015-10-29 A (+8d) | 19d → 21d | 0% → 100% | 89d → none |  |
| 75 | Home Page | 2015-09-24 → 2015-09-30 A (+6d) | 2015-09-28 → 2015-10-02 A (+4d) |  | 0% → 100% | 89d → none |  |
| 76 | Main Landing Page | 2015-09-29 → 2015-10-05 A (+6d) | 2015-10-08 → 2015-10-16 A (+8d) | 8d → 10d | 0% → 100% | 88d → none |  |
| 77 | Institution Landing Pages | 2015-10-09 → 2015-10-19 A (+10d) | 2015-10-15 → 2015-10-23 A (+8d) |  | 0% → 100% | 88d → none |  |
| 78 | Course Landing Pages | 2015-10-16 → 2015-10-26 A (+10d) | 2015-10-21 → 2015-10-29 A (+8d) |  | 0% → 100% | 89d → none |  |
| 79 | **Moodle: Course Design and Planning** | 2015-10-22 → 2015-10-30 A (+8d) | 2015-11-06 → 2015-11-16 A (+10d) | 12d → 11d | 0% → 100% | 89d → none |  |
| 80 | Courses Upload | 2015-10-22 → 2015-10-30 A (+8d) | 2015-10-28 → 2015-11-05 A (+8d) |  | 0% → 100% | 89d → none |  |
| 81 | Courses Structuring | 2015-10-29 → 2015-11-06 A (+8d) | 2015-11-03 → 2015-11-11 A (+8d) |  | 0% → 100% | 89d → none |  |
| 82 | Courses Support Material Upload | 2015-11-04 → 2015-11-12 A (+8d) | 2015-11-06 → 2015-11-16 A (+10d) |  | 0% → 100% | 89d → none |  |
| 83 | **Moodle: Course Creation** | 2015-11-09 → 2015-11-17 A (+8d) | 2015-11-24 → 2015-12-02 A (+8d) | 11d → 10d | 0% → 100% | 89d → none |  |
| 84 | Course Space Creation | 2015-11-09 → 2015-11-17 A (+8d) | 2015-11-13 → 2015-11-23 A (+10d) |  | 0% → 100% | 89d → none |  |
| 85 | Course Pages | 2015-11-16 → 2015-11-24 A (+8d) | 2015-11-19 → 2015-11-27 A (+8d) |  | 0% → 100% | 90d → none |  |
| 86 | Assessment Requirements | 2015-11-20 → 2015-11-30 A (+10d) | 2015-11-24 → 2015-12-02 A (+8d) |  | 0% → 100% | 90d → none |  |
| 87 | **Moodle: Performance and Control Considerations** | 2015-11-25 → 2015-12-03 A (+8d) | 2015-12-10 → 2015-12-22 (+12d) | 10d → 13.25d | 0% → 91% | 90d → 92.75d |  |
| 88 | Automated and Manual Communications setup | 2015-11-25 → 2015-12-03 A (+8d) | 2015-12-01 → 2015-12-11 (+10d) | 5d → 6.25d | 0% → 80% | 90d → 99.75d |  |
| 89 | Support Pages Configuration | 2015-12-02 → 2015-12-11 A (+9d) | 2015-12-07 → 2015-12-17 A (+10d) |  | 0% → 100% | 91d → none |  |
| 90 | Course Release Strategy | 2015-12-08 → 2015-12-17 A (+9d) | 2015-12-10 → 2015-12-22 A (+12d) |  | 0% → 100% | 91d → none |  |
| 91 | **LMS User Experience** | 2015-09-03 → 2015-09-09 A (+6d) | 2015-10-20 → 2015-10-26 A (+6d) | 32d → 33d | 0% → 100% | 51d → none |  |
| 92 | Doc: UX Design document (UXD) | 2015-09-03 → 2015-09-09 A (+6d) | 2015-09-09 → 2015-09-15 A (+6d) |  | 0% → 100% | 53d → none |  |
| 93 | Review: UXD | 2015-09-10 → 2015-09-16 A (+6d) | 2015-09-11 → 2015-09-17 A (+6d) |  | 0% → 100% | 52d → none |  |
| 94 | Signoff: UXD | 2015-09-14 → 2015-09-18 A (+4d) | 2015-09-15 → 2015-09-21 A (+6d) |  | 0% → 100% | 52d → none |  |
| 95 | Custom Theme Development | 2015-09-16 → 2015-09-22 A (+6d) | 2015-09-29 → 2015-10-05 A (+6d) |  | 0% → 100% | 52d → none |  |
| 96 | Department-wide custom themes | 2015-09-30 → 2015-10-06 A (+6d) | 2015-10-06 → 2015-10-12 A (+6d) |  | 0% → 100% | 52d → none |  |
| 97 | Logo and Branding requirements | 2015-10-07 → 2015-10-13 A (+6d) | 2015-10-13 → 2015-10-19 A (+6d) |  | 0% → 100% | 52d → none |  |
| 98 | Marketing UX reqts | 2015-10-14 → 2015-10-20 A (+6d) | 2015-10-20 → 2015-10-26 A (+6d) |  | 0% → 100% | 51d → none |  |
| 99 | Milestone: UX complete | 2015-10-20 → 2015-10-26 A (+6d) | 2015-10-20 → 2015-10-26 A (+6d) |  | 0% → 100% | 51d → none |  |
| 100 | **LMS Content Migration** | 2015-09-03 → 2015-09-09 A (+6d) | 2016-01-06 → 2016-01-19 (+13d) | 83d → 88d | 0% → 99% | 0d → 75d |  |
| 101 | Content Vendor Selection | 2015-09-03 → 2015-09-09 A (+6d) | 2015-09-09 → 2015-09-15 A (+6d) |  | 0% → 100% | 0d → none |  |
| 102 | Content Vendor Engage | 2015-09-10 → 2015-09-16 A (+6d) | 2015-09-16 → 2015-09-22 A (+6d) |  | 0% → 100% | 0d → none |  |
| 103 | Migrate SCORM Content | 2015-09-17 → 2015-09-23 A (+6d) | 2015-09-30 → 2015-10-06 A (+6d) |  | 0% → 100% | 0d → none |  |
| 104 | Vendor: New Content Creation | 2015-10-01 → 2015-10-07 A (+6d) | 2015-12-23 → 2015-12-29 A (+6d) |  | 0% → 100% | 0d → none | was named Vendonr: New Content Creation |
| 105 | Vendor: New content Upload | 2015-12-24 → 2015-12-30 A (+6d) | 2016-01-06 → 2016-01-19 A (+13d) | 10d → 15d | 0% → 100% | 0d → none |  |
| 106 | Milestone: Migration done | 2016-01-06 → 2016-01-19 (+13d) | 2016-01-06 → 2016-01-19 (+13d) |  |  | 0d → 75d |  |
| 107 | **Mobile App Development** | 2015-09-25 → 2015-09-30 A (+5d) | 2015-12-17 → 2015-12-22 A (+5d) |  | 0% → 100% | 12d → none |  |
| 108 | Mobile Dev Vendor Selection | 2015-09-25 → 2015-09-30 A (+5d) | 2015-10-01 → 2015-10-06 A (+5d) |  | 0% → 100% | 13d → none |  |
| 109 | Requirements and signoff | 2015-10-02 → 2015-10-07 A (+5d) | 2015-10-15 → 2015-10-20 A (+5d) |  | 0% → 100% | 13d → none |  |
| 110 | Notifications | 2015-10-16 → 2015-10-21 A (+5d) | 2015-10-21 → 2015-10-26 A (+5d) |  | 0% → 100% | 14d → none |  |
| 111 | Calendar | 2015-10-22 → 2015-10-27 A (+5d) | 2015-10-23 → 2015-10-28 A (+5d) |  | 0% → 100% | 13d → none |  |
| 112 | Quiz Engine | 2015-10-26 → 2015-10-29 A (+3d) | 2015-11-13 → 2015-11-18 A (+5d) |  | 0% → 100% | 12d → none |  |
| 113 | Annual Time Table | 2015-11-16 → 2015-11-19 A (+3d) | 2015-11-17 → 2015-11-20 A (+3d) |  | 0% → 100% | 12d → none |  |
| 114 | Messaging | 2015-11-18 → 2015-11-23 A (+5d) | 2015-11-24 → 2015-11-27 A (+3d) |  | 0% → 100% | 12d → none |  |
| 115 | Social Integration | 2015-11-25 → 2015-11-30 A (+5d) | 2015-11-26 → 2015-12-01 A (+5d) |  | 0% → 100% | 12d → none |  |
| 116 | Usability Testing | 2015-11-27 → 2015-12-02 A (+5d) | 2015-12-03 → 2015-12-08 A (+5d) |  | 0% → 100% | 13d → none |  |
| 117 | Functional Testing | 2015-12-04 → 2015-12-09 A (+5d) | 2015-12-10 → 2015-12-15 A (+5d) |  | 0% → 100% | 13d → none |  |
| 118 | Integration testing | 2015-12-11 → 2015-12-16 A (+5d) | 2015-12-17 → 2015-12-22 A (+5d) |  | 0% → 100% | 12d → none |  |
| 119 | Milestone: Mobile dev complete | 2015-12-17 → 2015-12-22 A (+5d) | 2015-12-17 → 2015-12-22 A (+5d) |  | 0% → 100% | 12d → none |  |
| 120 | **Testing Plan and Setup** | 2015-10-19 → 2015-10-22 A (+3d) | 2015-12-04 → 2015-12-16 A (+12d) | 32d → 37d | 0% → 100% | 21d → none |  |
| 121 | Doc: Test Specification Document (TSD) | 2015-10-19 → 2015-10-22 A (+3d) | 2015-10-30 → 2015-11-11 A (+12d) | 2w → 3w | 0% → 100% | 20d → none |  |
| 122 | Test team setup | 2015-11-02 → 2015-11-12 A (+10d) | 2015-11-06 → 2015-11-18 A (+12d) |  | 0% → 100% | 20d → none |  |
| 123 | Review: TSD | 2015-11-09 → 2015-11-19 A (+10d) | 2015-11-11 → 2015-11-23 A (+12d) |  | 0% → 100% | 20d → none |  |
| 124 | Signoff: TSD | 2015-11-12 → 2015-11-24 A (+12d) | 2015-11-13 → 2015-11-25 A (+12d) |  | 0% → 100% | 21d → none |  |
| 125 | Content Test Strategy | 2015-11-16 → 2015-11-26 A (+10d) | 2015-11-27 → 2015-12-09 A (+12d) |  | 0% → 100% | 21d → none |  |
| 126 | Usability Test Strategy | 2015-11-30 → 2015-12-10 A (+10d) | 2015-12-04 → 2015-12-16 A (+12d) |  | 0% → 100% | 21d → none |  |
| 127 | Milestone: Implementation Complete | 2016-01-06 → 2016-01-19 A (+13d) | 2016-01-06 → 2016-01-19 A (+13d) |  | 0% → 100% | 0d → none |  |
| 128 | **Integration Phase** | 2016-01-07 → 2016-01-20 A (+13d) | 2016-03-22 → 2016-04-04 (+13d) | 52d → 53d | 0% → 54% | 0d → 2d |  |
| 129 | Single Sign On (SSO) Setup | 2016-01-07 → 2016-01-20 A (+13d) | 2016-01-11 → 2016-01-22 A (+11d) |  | 0% → 100% | 0d → none |  |
| 130 | Student Information System (SIS) Setup | 2016-01-12 → 2016-01-25 A (+13d) | 2016-01-18 → 2016-01-29 A (+11d) |  | 0% → 100% | 2d → none |  |
| 131 | Datewarehousing Integration (Learning Analytics) | 2016-01-19 → 2016-02-01 A (+13d) | 2016-02-01 → 2016-02-12 A (+11d) |  | 0% → 100% | 2d → none |  |
| 132 | SAP Integration | 2016-02-02 → 2016-02-15 A (+13d) | 2016-02-22 → 2016-03-04 (+11d) |  | 0% → 73% |  |  |
| 133 | Accounting Software Setup | 2016-02-23 → 2016-03-07 (+13d) | 2016-02-29 → 2016-03-11 (+11d) |  |  |  |  |
| 134 | **STAGING SERVER SETUP** | 2016-03-01 → 2016-03-14 (+13d) | 2016-03-22 → 2016-04-04 (+13d) |  |  |  |  |
| 135 | Server setup, Redundancy setup | 2016-03-01 → 2016-03-14 (+13d) | 2016-03-03 → 2016-03-16 (+13d) |  |  |  |  |
| 136 | Database Configuration | 2016-03-04 → 2016-03-17 (+13d) | 2016-03-08 → 2016-03-21 (+13d) |  |  |  |  |
| 137 | LMS Installation | 2016-03-09 → 2016-03-22 (+13d) | 2016-03-10 → 2016-03-23 (+13d) |  |  |  |  |
| 138 | Course Data Migration | 2016-03-11 → 2016-03-24 (+13d) | 2016-03-15 → 2016-03-28 (+13d) |  |  |  |  |
| 139 | Student Data Import | 2016-03-16 → 2016-03-29 (+13d) | 2016-03-18 → 2016-03-31 (+13d) |  |  |  |  |
| 140 | RBAC Setup and testing | 2016-03-21 → 2016-04-01 (+11d) | 2016-03-22 → 2016-04-04 (+13d) |  |  |  |  |

| ID | Task | Start | Finish | Duration | Complete | Total float |
| --- | --- | --- | --- | --- | --- | --- |
| 141 | Milestone: Integration Phase Complete | 2016-03-22 → 2016-04-04 (+13d) | 2016-03-22 → 2016-04-04 (+13d) |  |  |  |
| 142 | **VERIFICATION and STAGING** | 2015-10-22 → 2015-11-02 A (+11d) | 2016-04-13 → 2016-04-22 (+9d) | 118d → 117d | 0% → 69% | 6d → 9d |
| 143 | Unit Testing of all modules | 2015-10-22 → 2015-11-02 A (+11d) | 2015-12-16 → 2015-12-25 A (+9d) |  | 0% → 100% | 6d → none |
| 144 | Functional Testing | 2015-12-17 → 2015-12-28 A (+11d) | 2016-01-06 → 2016-01-15 A (+9d) |  | 0% → 100% | 6d → none |
| 145 | Installation and Deploy Testing | 2016-01-07 → 2016-01-18 A (+11d) | 2016-01-20 → 2016-01-29 A (+9d) |  | 0% → 100% | 7d → none |
| 146 | Performance Testing | 2016-01-21 → 2016-02-01 A (+11d) | 2016-02-03 → 2016-02-12 A (+9d) |  | 0% → 100% | 7d → none |
| 147 | Usability Testing | 2016-02-04 → 2016-02-15 A (+11d) | 2016-02-17 → 2016-02-26 A (+9d) |  | 0% → 100% | 7d → none |
| 148 | Alpha Testing | 2016-02-18 → 2016-02-29 A (+11d) | 2016-03-02 → 2016-03-11 (+9d) |  | 0% → 10% | 7d → 9d |
| 149 | UAT Scripting | 2016-03-03 → 2016-03-14 (+11d) | 2016-03-16 → 2016-03-25 (+9d) |  |  | 7d → 9d |
| 150 | UAT cases review and approval | 2016-03-17 → 2016-03-28 (+11d) | 2016-03-30 → 2016-04-08 (+9d) |  |  | 7d → 8d |
| 151 | User Acceptance Testing | 2016-03-31 → 2016-04-11 (+11d) | 2016-04-13 → 2016-04-22 (+9d) |  |  | 6d → 8d |
| 152 | Milestone: Testing Complete | 2016-04-13 → 2016-04-22 (+9d) | 2016-04-13 → 2016-04-22 (+9d) |  |  | 6d → 9d |
| 153 | **PRODUCTION DEPLOYMENT** | 2016-03-23 → 2016-04-05 (+13d) | 2016-04-20 → 2016-05-03 (+13d) |  |  |  |
| 154 | Hardware, Software, Database Setup, Configuration | 2016-03-23 → 2016-04-05 (+13d) | 2016-03-29 → 2016-04-11 (+13d) |  |  |  |
| 155 | Course Data Migration | 2016-03-30 → 2016-04-12 (+13d) | 2016-04-06 → 2016-04-19 (+13d) |  |  |  |
| 156 | Student Data Migration | 2016-04-07 → 2016-04-20 (+13d) | 2016-04-12 → 2016-04-25 (+13d) |  |  |  |
| 157 | Course Creation - all Colleges | 2016-04-13 → 2016-04-26 (+13d) | 2016-04-19 → 2016-05-02 (+13d) |  |  |  |
| 158 | Roles and Accounts | 2016-04-20 → 2016-05-03 (+13d) | 2016-04-20 → 2016-05-03 (+13d) |  |  |  |
| 159 | Milestone: Prod Deploy Complete | 2016-04-20 → 2016-05-03 (+13d) | 2016-04-20 → 2016-05-03 (+13d) |  |  |  |
| 160 | **Maintenance Handover** | 2016-02-05 → 2016-02-18 A (+13d) | 2016-04-22 → 2016-05-05 (+13d) | 54d → 55d | 0% → 13% |  |
| 161 | Training Calendar | 2016-02-05 → 2016-02-18 A (+13d) | 2016-02-09 → 2016-02-22 A (+13d) |  | 0% → 100% | 0d → none |
| 162 | Maintenance Vendor Selection | 2016-02-10 → 2016-02-23 A (+13d) | 2016-03-08 → 2016-03-21 (+13d) |  | 0% → 25% |  |
| 163 | Maintenance Vendor Engagement | 2016-03-09 → 2016-03-22 (+13d) | 2016-03-15 → 2016-03-28 (+13d) |  |  |  |
| 164 | User Manual | 2016-03-16 → 2016-03-29 (+13d) | 2016-03-29 → 2016-04-11 (+13d) |  |  |  |
| 165 | Administration Manual | 2016-03-30 → 2016-04-12 (+13d) | 2016-04-12 → 2016-04-25 (+13d) |  |  |  |
| 166 | Techno Functional Handover | 2016-04-13 → 2016-04-26 (+13d) | 2016-04-15 → 2016-04-28 (+13d) |  |  |  |
| 167 | Training Org Wide | 2016-04-18 → 2016-04-29 (+11d) | 2016-04-22 → 2016-05-05 (+13d) |  |  |  |
| 168 | **BUGZILLA** | 2016-04-18 → 2016-04-29 (+11d) | 2016-04-22 → 2016-05-05 (+13d) |  |  |  |
| 169 | Issue Tracking BUGZILLA installation | 2016-04-18 → 2016-04-29 (+11d) | 2016-04-19 → 2016-05-02 (+13d) |  |  |  |
| 170 | Bugzilla accounts, training and access handover | 2016-04-20 → 2016-05-03 (+13d) | 2016-04-22 → 2016-05-05 (+13d) |  |  |  |
| 171 | Milestone: Project Complete | 2016-04-22 → 2016-05-05 (+13d) | 2016-04-22 → 2016-05-05 (+13d) |  |  |  |

## Version 7 (data date 2015-08-31, saved 2025-04-02, file 12.0 Project Exercise 10 - Learning Management System Implementation_ver6.0.mpp)

Last finish 2016-05-05 → 2016-04-28 (-7d). Complete tasks 121 → 26.

Changed:

| ID | Task | Start | Finish | Duration | Complete | Total float |
| --- | --- | --- | --- | --- | --- | --- |
| 10 | **Weekly Review Meeting** |  | 2016-02-29 A → 2016-02-29 |  | 100% → 13% | none → 42.75d |
| 16 | Weekly Review Meeting 6 | 2015-07-06 A → 2015-07-06 | 2015-07-06 A → 2015-07-06 |  | 100% → 0% | none → 203.75d |
| 17 | Weekly Review Meeting 7 | 2015-07-13 A → 2015-07-13 | 2015-07-13 A → 2015-07-13 |  | 100% → 0% | none → 198.75d |
| 18 | Weekly Review Meeting 8 | 2015-07-20 A → 2015-07-20 | 2015-07-20 A → 2015-07-20 |  | 100% → 0% | none → 193.75d |
| 19 | Weekly Review Meeting 9 | 2015-07-27 A → 2015-07-27 | 2015-07-27 A → 2015-07-27 |  | 100% → 0% | none → 188.75d |
| 20 | Weekly Review Meeting 10 | 2015-08-03 A → 2015-08-03 | 2015-08-03 A → 2015-08-03 |  | 100% → 0% | none → 183.75d |
| 21 | Weekly Review Meeting 11 | 2015-08-10 A → 2015-08-10 | 2015-08-10 A → 2015-08-10 |  | 100% → 0% | none → 178.75d |
| 22 | Weekly Review Meeting 12 | 2015-08-17 A → 2015-08-17 | 2015-08-17 A → 2015-08-17 |  | 100% → 0% | none → 173.75d |
| 23 | Weekly Review Meeting 13 | 2015-08-24 A → 2015-08-24 | 2015-08-24 A → 2015-08-24 |  | 100% → 0% | none → 168.75d |
| 24 | Weekly Review Meeting 14 | 2015-08-31 A → 2015-08-31 | 2015-08-31 A → 2015-08-31 |  | 100% → 0% | none → 163.75d |
| 25 | Weekly Review Meeting 15 | 2015-09-08 A → 2015-09-08 | 2015-09-08 A → 2015-09-08 |  | 100% → 0% | none → 158.75d |
| 26 | Weekly Review Meeting 16 | 2015-09-14 A → 2015-09-14 | 2015-09-14 A → 2015-09-14 |  | 100% → 0% | none → 154.75d |
| 27 | Weekly Review Meeting 17 | 2015-09-21 A → 2015-09-21 | 2015-09-21 A → 2015-09-21 |  | 100% → 0% | none → 149.75d |
| 28 | Weekly Review Meeting 18 | 2015-09-28 A → 2015-09-28 | 2015-09-28 A → 2015-09-28 |  | 100% → 0% | none → 144.75d |
| 29 | Weekly Review Meeting 19 | 2015-10-05 A → 2015-10-05 | 2015-10-05 A → 2015-10-05 |  | 100% → 0% | none → 139.75d |
| 30 | Weekly Review Meeting 20 | 2015-10-13 A → 2015-10-13 | 2015-10-13 A → 2015-10-13 |  | 100% → 0% | none → 134.75d |
| 31 | Weekly Review Meeting 21 | 2015-10-19 A → 2015-10-19 | 2015-10-19 A → 2015-10-19 |  | 100% → 0% | none → 130.75d |
| 32 | Weekly Review Meeting 22 | 2015-10-26 A → 2015-10-26 | 2015-10-26 A → 2015-10-26 |  | 100% → 0% | none → 125.75d |
| 33 | Weekly Review Meeting 23 | 2015-11-02 A → 2015-11-02 | 2015-11-02 A → 2015-11-02 |  | 100% → 0% | none → 120.75d |
| 34 | Weekly Review Meeting 24 | 2015-11-09 A → 2015-11-09 | 2015-11-09 A → 2015-11-09 |  | 100% → 0% | none → 115.75d |
| 35 | Weekly Review Meeting 25 | 2015-11-16 A → 2015-11-16 | 2015-11-16 A → 2015-11-16 |  | 100% → 0% | none → 111.75d |
| 36 | Weekly Review Meeting 26 | 2015-11-23 A → 2015-11-23 | 2015-11-23 A → 2015-11-23 |  | 100% → 0% | none → 106.75d |
| 37 | Weekly Review Meeting 27 | 2015-11-30 A → 2015-11-30 | 2015-11-30 A → 2015-11-30 |  | 100% → 0% | none → 103.75d |
| 38 | Weekly Review Meeting 28 | 2015-12-07 A → 2015-12-07 | 2015-12-07 A → 2015-12-07 |  | 100% → 0% | none → 98.75d |
| 39 | Weekly Review Meeting 29 | 2015-12-14 A → 2015-12-14 | 2015-12-14 A → 2015-12-14 |  | 100% → 0% | none → 93.75d |
| 40 | Weekly Review Meeting 30 | 2015-12-21 A → 2015-12-21 | 2015-12-21 A → 2015-12-21 |  | 100% → 0% | none → 88.75d |
| 41 | Weekly Review Meeting 31 | 2015-12-28 A → 2015-12-28 | 2015-12-28 A → 2015-12-28 |  | 100% → 0% | none → 84.75d |
| 42 | Weekly Review Meeting 32 | 2016-01-04 A → 2016-01-04 | 2016-01-04 A → 2016-01-04 |  | 100% → 0% | none → 80.75d |
| 43 | Weekly Review Meeting 33 | 2016-01-11 A → 2016-01-11 | 2016-01-11 A → 2016-01-11 |  | 100% → 0% | none → 75.75d |
| 44 | Weekly Review Meeting 34 | 2016-01-19 A → 2016-01-19 | 2016-01-19 A → 2016-01-19 |  | 100% → 0% | none → 70.75d |
| 45 | Weekly Review Meeting 35 | 2016-01-25 A → 2016-01-25 | 2016-01-25 A → 2016-01-25 |  | 100% → 0% | none → 66.75d |
| 46 | Weekly Review Meeting 36 | 2016-02-01 A → 2016-02-01 | 2016-02-01 A → 2016-02-01 |  | 100% → 0% | none → 61.75d |
| 47 | Weekly Review Meeting 37 | 2016-02-08 A → 2016-02-08 | 2016-02-08 A → 2016-02-08 |  | 100% → 0% | none → 56.75d |
| 48 | Weekly Review Meeting 38 | 2016-02-16 A → 2016-02-16 | 2016-02-16 A → 2016-02-16 |  | 100% → 0% | none → 51.75d |
| 49 | Weekly Review Meeting 39 | 2016-02-22 A → 2016-02-22 | 2016-02-22 A → 2016-02-22 |  | 100% → 0% | none → 47.75d |
| 50 | Weekly Review Meeting 40 | 2016-02-29 A → 2016-02-29 | 2016-02-29 A → 2016-02-29 |  | 100% → 0% | none → 42.75d |
| 51 | **Detailed Design Phase** |  |  |  | 99% → 91% | 163d → 158d |
| 66 | Content Strategy Document (CSD) |  | 2015-09-08 A → 2015-09-08 |  | 100% → 40% | none → 0d |
| 67 | Milestone: Detailed Design Complete | 2015-09-08 A → 2015-09-08 | 2015-09-08 A → 2015-09-08 |  | 100% → 0% | none → 0d |
| 68 | **Implementation Phase** | 2015-09-09 A → 2015-09-09 | 2016-01-19 → 2016-01-12 (-7d) | 88d → 84d | 99% → 0% | 75d → 0d |
| 69 | Testing Server Setup | 2015-09-09 A → 2015-09-09 | 2015-09-10 A → 2015-09-10 |  | 100% → 0% | none → 89d |
| 70 | Development Server Setup | 2015-09-11 A → 2015-09-11 | 2015-09-14 A → 2015-09-14 |  | 100% → 0% | none → 89d |
| 71 | Install: Moodle Test installation | 2015-09-15 A → 2015-09-15 | 2015-09-15 A → 2015-09-15 |  | 100% → 0% | none → 89d |
| 72 | Database design | 2015-09-16 A → 2015-09-16 | 2015-09-22 A → 2015-09-22 |  | 100% → 0% | none → 89d |
| 73 | Doc: Upgrade Strategy Document (USD) | 2015-09-23 A → 2015-09-23 | 2015-09-29 A → 2015-09-29 |  | 100% → 0% | none → 89d |
| 74 | **Moodle: LMS Structure** | 2015-09-30 A → 2015-09-30 | 2015-10-29 A → 2015-10-27 (-2d) | 21d → 19d | 100% → 0% | none → 89d |
| 75 | Home Page | 2015-09-30 A → 2015-09-30 | 2015-10-02 A → 2015-10-02 |  | 100% → 0% | none → 88d |
| 76 | Main Landing Page | 2015-10-05 A → 2015-10-05 | 2015-10-16 A → 2015-10-14 (-2d) | 10d → 8d | 100% → 0% | none → 88d |
| 77 | Institution Landing Pages | 2015-10-19 A → 2015-10-15 (-4d) | 2015-10-23 A → 2015-10-21 (-2d) |  | 100% → 0% | none → 89d |
| 78 | Course Landing Pages | 2015-10-26 A → 2015-10-22 (-4d) | 2015-10-29 A → 2015-10-27 (-2d) |  | 100% → 0% | none → 89d |
| 79 | **Moodle: Course Design and Planning** | 2015-10-30 A → 2015-10-28 (-2d) | 2015-11-16 A → 2015-11-12 (-4d) |  | 100% → 0% | none → 89d |
| 80 | Courses Upload | 2015-10-30 A → 2015-10-28 (-2d) | 2015-11-05 A → 2015-11-03 (-2d) |  | 100% → 0% | none → 89d |
| 81 | Courses Structuring | 2015-11-06 A → 2015-11-04 (-2d) | 2015-11-11 A → 2015-11-09 (-2d) |  | 100% → 0% | none → 89d |
| 82 | Courses Support Material Upload | 2015-11-12 A → 2015-11-10 (-2d) | 2015-11-16 A → 2015-11-12 (-4d) |  | 100% → 0% | none → 89d |
| 83 | **Moodle: Course Creation** | 2015-11-17 A → 2015-11-13 (-4d) | 2015-12-02 A → 2015-11-30 (-2d) |  | 100% → 0% | none → 90d |
| 84 | Course Space Creation | 2015-11-17 A → 2015-11-13 (-4d) | 2015-11-23 A → 2015-11-19 (-4d) |  | 100% → 0% | none → 90d |
| 85 | Course Pages | 2015-11-24 A → 2015-11-20 (-4d) | 2015-11-27 A → 2015-11-25 (-2d) |  | 100% → 0% | none → 90d |
| 86 | Assessment Requirements | 2015-11-30 A → 2015-11-26 (-4d) | 2015-12-02 A → 2015-11-30 (-2d) |  | 100% → 0% | none → 90d |
| 87 | **Moodle: Performance and Control Considerations** | 2015-12-03 A → 2015-12-01 (-2d) | 2015-12-22 → 2015-12-16 (-6d) | 13.25d → 12d | 91% → 0% | 92.75d → 91d |
| 88 | Automated and Manual Communications setup | 2015-12-03 A → 2015-12-01 (-2d) | 2015-12-11 → 2015-12-07 (-4d) | 6.25d → 5d | 80% → 0% | 99.75d → 91d |
| 89 | Support Pages Configuration | 2015-12-11 A → 2015-12-08 (-3d) | 2015-12-17 A → 2015-12-11 (-6d) |  | 100% → 0% | none → 91d |
| 90 | Course Release Strategy | 2015-12-17 A → 2015-12-14 (-3d) | 2015-12-22 A → 2015-12-16 (-6d) |  | 100% → 0% | none → 91d |
| 91 | **LMS User Experience** | 2015-09-09 A → 2015-09-09 | 2015-10-26 A → 2015-10-26 |  | 100% → 0% | none → 51d |
| 92 | Doc: UX Design document (UXD) | 2015-09-09 A → 2015-09-09 | 2015-09-15 A → 2015-09-15 |  | 100% → 0% | none → 52d |
| 93 | Review: UXD | 2015-09-16 A → 2015-09-16 | 2015-09-17 A → 2015-09-17 |  | 100% → 0% | none → 52d |
| 94 | Signoff: UXD | 2015-09-18 A → 2015-09-18 | 2015-09-21 A → 2015-09-21 |  | 100% → 0% | none → 52d |
| 95 | Custom Theme Development | 2015-09-22 A → 2015-09-22 | 2015-10-05 A → 2015-10-05 |  | 100% → 0% | none → 52d |
| 96 | Department-wide custom themes | 2015-10-06 A → 2015-10-06 | 2015-10-12 A → 2015-10-12 |  | 100% → 0% | none → 52d |
| 97 | Logo and Branding requirements | 2015-10-13 A → 2015-10-13 | 2015-10-19 A → 2015-10-19 |  | 100% → 0% | none → 51d |
| 98 | Marketing UX reqts | 2015-10-20 A → 2015-10-20 | 2015-10-26 A → 2015-10-26 |  | 100% → 0% | none → 51d |

| ID | Task | Start | Finish | Duration | Complete | Total float | Other |
| --- | --- | --- | --- | --- | --- | --- | --- |
| 99 | Milestone: UX complete | 2015-10-26 A → 2015-10-26 | 2015-10-26 A → 2015-10-26 |  | 100% → 0% | none → 51d |  |
| 100 | **LMS Content Migration** | 2015-09-09 A → 2015-09-09 | 2016-01-19 → 2016-01-12 (-7d) | 88d → 84d | 99% → 0% | 75d → 0d |  |
| 101 | Content Vendor Selection | 2015-09-09 A → 2015-09-09 | 2015-09-15 A → 2015-09-15 |  | 100% → 0% | none → 0d |  |
| 102 | Content Vendor Engage | 2015-09-16 A → 2015-09-16 | 2015-09-22 A → 2015-09-22 |  | 100% → 0% | none → 0d |  |
| 103 | Migrate SCORM Content | 2015-09-23 A → 2015-09-23 | 2015-10-06 A → 2015-10-06 |  | 100% → 0% | none → 0d |  |
| 104 | Vendonr: New Content Creation | 2015-10-07 A → 2015-10-07 | 2015-12-29 A → 2015-12-29 |  | 100% → 0% | none → 0d | was named Vendor: New Content Creation |
| 105 | Vendor: New content Upload | 2015-12-30 A → 2015-12-30 | 2016-01-19 A → 2016-01-12 (-7d) | 15d → 10d | 100% → 0% | none → 0d |  |
| 106 | Milestone: Migration done | 2016-01-19 → 2016-01-12 (-7d) | 2016-01-19 → 2016-01-12 (-7d) |  |  | 75d → 0d |  |
| 107 | **Mobile App Development** | 2015-09-30 A → 2015-09-30 | 2015-12-22 A → 2015-12-22 |  | 100% → 0% | none → 13d |  |
| 108 | Mobile Dev Vendor Selection | 2015-09-30 A → 2015-09-30 | 2015-10-06 A → 2015-10-06 |  | 100% → 0% | none → 14d |  |
| 109 | Requirements and signoff | 2015-10-07 A → 2015-10-07 | 2015-10-20 A → 2015-10-20 |  | 100% → 0% | none → 14d |  |
| 110 | Notifications | 2015-10-21 A → 2015-10-21 | 2015-10-26 A → 2015-10-26 |  | 100% → 0% | none → 14d |  |
| 111 | Calendar | 2015-10-27 A → 2015-10-27 | 2015-10-28 A → 2015-10-28 |  | 100% → 0% | none → 14d |  |
| 112 | Quiz Engine | 2015-10-29 A → 2015-10-29 | 2015-11-18 A → 2015-11-18 |  | 100% → 0% | none → 13d |  |
| 113 | Annual Time Table | 2015-11-19 A → 2015-11-19 | 2015-11-20 A → 2015-11-20 |  | 100% → 0% | none → 13d |  |
| 114 | Messaging | 2015-11-23 A → 2015-11-23 | 2015-11-27 A → 2015-11-27 |  | 100% → 0% | none → 13d |  |
| 115 | Social Integration | 2015-11-30 A → 2015-11-30 | 2015-12-01 A → 2015-12-01 |  | 100% → 0% | none → 15d |  |
| 116 | Usability Testing | 2015-12-02 A → 2015-12-02 | 2015-12-08 A → 2015-12-08 |  | 100% → 0% | none → 14d |  |
| 117 | Functional Testing | 2015-12-09 A → 2015-12-09 | 2015-12-15 A → 2015-12-15 |  | 100% → 0% | none → 13d |  |
| 118 | Integration testing | 2015-12-16 A → 2015-12-16 | 2015-12-22 A → 2015-12-22 |  | 100% → 0% | none → 13d |  |
| 119 | Milestone: Mobile dev complete | 2015-12-22 A → 2015-12-22 | 2015-12-22 A → 2015-12-22 |  | 100% → 0% | none → 13d |  |
| 120 | **Testing Plan and Setup** | 2015-10-22 A → 2015-10-22 | 2015-12-16 A → 2015-12-09 (-7d) | 37d → 32d | 100% → 0% | none → 22d |  |
| 121 | Doc: Test Specification Document (TSD) | 2015-10-22 A → 2015-10-22 | 2015-11-11 A → 2015-11-04 (-7d) | 3w → 2w | 100% → 0% | none → 21d |  |
| 122 | Test team setup | 2015-11-12 A → 2015-11-05 (-7d) | 2015-11-18 A → 2015-11-11 (-7d) |  | 100% → 0% | none → 21d |  |
| 123 | Review: TSD | 2015-11-19 A → 2015-11-12 (-7d) | 2015-11-23 A → 2015-11-16 (-7d) |  | 100% → 0% | none → 22d |  |
| 124 | Signoff: TSD | 2015-11-24 A → 2015-11-17 (-7d) | 2015-11-25 A → 2015-11-18 (-7d) |  | 100% → 0% | none → 22d |  |
| 125 | Content Test Strategy | 2015-11-26 A → 2015-11-19 (-7d) | 2015-12-09 A → 2015-12-02 (-7d) |  | 100% → 0% | none → 22d |  |
| 126 | Usability Test Strategy | 2015-12-10 A → 2015-12-03 (-7d) | 2015-12-16 A → 2015-12-09 (-7d) |  | 100% → 0% | none → 22d |  |
| 127 | Milestone: Implementation Complete | 2016-01-19 A → 2016-01-12 (-7d) | 2016-01-19 A → 2016-01-12 (-7d) |  | 100% → 0% | none → 0d |  |
| 128 | **Integration Phase** | 2016-01-20 A → 2016-01-13 (-7d) | 2016-04-04 → 2016-03-28 (-7d) | 53d → 52d | 54% → 0% | 2d → 0d |  |
| 129 | Single Sign On (SSO) Setup | 2016-01-20 A → 2016-01-13 (-7d) | 2016-01-22 A → 2016-01-15 (-7d) |  | 100% → 0% | none → 0d |  |
| 130 | Student Information System (SIS) Setup | 2016-01-25 A → 2016-01-18 (-7d) | 2016-01-29 A → 2016-01-22 (-7d) |  | 100% → 0% | none → 1d |  |
| 131 | Datewarehousing Integration (Learning Analytics) | 2016-02-01 A → 2016-01-25 (-7d) | 2016-02-12 A → 2016-02-05 (-7d) |  | 100% → 0% | none → 2d |  |
| 132 | SAP Integration | 2016-02-15 A → 2016-02-08 (-7d) | 2016-03-04 → 2016-02-26 (-7d) |  | 73% → 0% |  |  |
| 133 | Accounting Software Setup | 2016-03-07 → 2016-02-29 (-7d) | 2016-03-11 → 2016-03-04 (-7d) |  |  |  |  |
| 134 | **STAGING SERVER SETUP** | 2016-03-14 → 2016-03-07 (-7d) | 2016-04-04 → 2016-03-28 (-7d) |  |  |  |  |
| 135 | Server setup, Redundancy setup | 2016-03-14 → 2016-03-07 (-7d) | 2016-03-16 → 2016-03-09 (-7d) |  |  |  |  |
| 136 | Database Configuration | 2016-03-17 → 2016-03-10 (-7d) | 2016-03-21 → 2016-03-14 (-7d) |  |  |  |  |
| 137 | LMS Installation | 2016-03-22 → 2016-03-15 (-7d) | 2016-03-23 → 2016-03-16 (-7d) |  |  |  |  |
| 138 | Course Data Migration | 2016-03-24 → 2016-03-17 (-7d) | 2016-03-28 → 2016-03-21 (-7d) |  |  |  |  |
| 139 | Student Data Import | 2016-03-29 → 2016-03-22 (-7d) | 2016-03-31 → 2016-03-24 (-7d) |  |  |  |  |
| 140 | RBAC Setup and testing | 2016-04-01 → 2016-03-25 (-7d) | 2016-04-04 → 2016-03-28 (-7d) |  |  |  |  |
| 141 | Milestone: Integration Phase Complete | 2016-04-04 → 2016-03-28 (-7d) | 2016-04-04 → 2016-03-28 (-7d) |  |  |  |  |
| 142 | **VERIFICATION and STAGING** | 2015-11-02 A → 2015-10-28 (-5d) | 2016-04-22 → 2016-04-19 (-3d) |  | 69% → 0% | 9d → 7d |  |
| 143 | Unit Testing of all modules | 2015-11-02 A → 2015-10-28 (-5d) | 2015-12-25 A → 2015-12-22 (-3d) |  | 100% → 0% | none → 6d |  |
| 144 | Functional Testing | 2015-12-28 A → 2015-12-23 (-5d) | 2016-01-15 A → 2016-01-12 (-3d) |  | 100% → 0% | none → 6d |  |
| 145 | Installation and Deploy Testing | 2016-01-18 A → 2016-01-13 (-5d) | 2016-01-29 A → 2016-01-26 (-3d) |  | 100% → 0% | none → 6d |  |
| 146 | Performance Testing | 2016-02-01 A → 2016-01-27 (-5d) | 2016-02-12 A → 2016-02-09 (-3d) |  | 100% → 0% | none → 6d |  |
| 147 | Usability Testing | 2016-02-15 A → 2016-02-10 (-5d) | 2016-02-26 A → 2016-02-23 (-3d) |  | 100% → 0% | none → 6d |  |
| 148 | Alpha Testing | 2016-02-29 A → 2016-02-24 (-5d) | 2016-03-11 → 2016-03-08 (-3d) |  | 10% → 0% | 9d → 7d |  |
| 149 | UAT Scripting | 2016-03-14 → 2016-03-09 (-5d) | 2016-03-25 → 2016-03-22 (-3d) |  |  | 9d → 7d |  |
| 150 | UAT cases review and approval | 2016-03-28 → 2016-03-23 (-5d) | 2016-04-08 → 2016-04-05 (-3d) |  |  | 8d → 7d |  |
| 151 | User Acceptance Testing | 2016-04-11 → 2016-04-06 (-5d) | 2016-04-22 → 2016-04-19 (-3d) |  |  | 8d → 7d |  |
| 152 | Milestone: Testing Complete | 2016-04-22 → 2016-04-19 (-3d) | 2016-04-22 → 2016-04-19 (-3d) |  |  | 9d → 7d |  |
| 153 | **PRODUCTION DEPLOYMENT** | 2016-04-05 → 2016-03-29 (-7d) | 2016-05-03 → 2016-04-26 (-7d) |  |  |  |  |
| 154 | Hardware, Software, Database Setup, Configuration | 2016-04-05 → 2016-03-29 (-7d) | 2016-04-11 → 2016-04-04 (-7d) |  |  |  |  |
| 155 | Course Data Migration | 2016-04-12 → 2016-04-05 (-7d) | 2016-04-19 → 2016-04-12 (-7d) |  |  |  |  |
| 156 | Student Data Migration | 2016-04-20 → 2016-04-13 (-7d) | 2016-04-25 → 2016-04-18 (-7d) |  |  |  |  |
| 157 | Course Creation - all Colleges | 2016-04-26 → 2016-04-19 (-7d) | 2016-05-02 → 2016-04-25 (-7d) |  |  |  |  |
| 158 | Roles and Accounts | 2016-05-03 → 2016-04-26 (-7d) | 2016-05-03 → 2016-04-26 (-7d) |  |  |  |  |
| 159 | Milestone: Prod Deploy Complete | 2016-05-03 → 2016-04-26 (-7d) | 2016-05-03 → 2016-04-26 (-7d) |  |  |  |  |
| 160 | **Maintenance Handover** | 2016-02-18 A → 2016-02-11 (-7d) | 2016-05-05 → 2016-04-28 (-7d) | 55d → 54d | 13% → 0% |  |  |
| 161 | Training Calendar | 2016-02-18 A → 2016-02-11 (-7d) | 2016-02-22 A → 2016-02-15 (-7d) |  | 100% → 0% | none → 0d |  |
| 162 | Maintenance Vendor Selection | 2016-02-23 A → 2016-02-16 (-7d) | 2016-03-21 → 2016-03-14 (-7d) |  | 25% → 0% |  |  |
| 163 | Maintenance Vendor Engagement | 2016-03-22 → 2016-03-15 (-7d) | 2016-03-28 → 2016-03-21 (-7d) |  |  |  |  |
| 164 | User Manual | 2016-03-29 → 2016-03-22 (-7d) | 2016-04-11 → 2016-04-04 (-7d) |  |  |  |  |
| 165 | Administration Manual | 2016-04-12 → 2016-04-05 (-7d) | 2016-04-25 → 2016-04-18 (-7d) |  |  |  |  |
| 166 | Techno Functional Handover | 2016-04-26 → 2016-04-19 (-7d) | 2016-04-28 → 2016-04-21 (-7d) |  |  |  |  |
| 167 | Training Org Wide | 2016-04-29 → 2016-04-22 (-7d) | 2016-05-05 → 2016-04-28 (-7d) |  |  |  |  |
| 168 | **BUGZILLA** | 2016-04-29 → 2016-04-22 (-7d) | 2016-05-05 → 2016-04-28 (-7d) |  |  |  |  |

| ID | Task | Start | Finish |
| --- | --- | --- | --- |
| 169 | Issue Tracking BUGZILLA installation | 2016-04-29 → 2016-04-22 (-7d) | 2016-05-02 → 2016-04-25 (-7d) |
| 170 | Bugzilla accounts, training and access handover | 2016-05-03 → 2016-04-26 (-7d) | 2016-05-05 → 2016-04-28 (-7d) |
| 171 | Milestone: Project Complete | 2016-05-05 → 2016-04-28 (-7d) | 2016-05-05 → 2016-04-28 (-7d) |

## Version 8 (data date 2016-04-14, saved 2025-04-02, file 12.0 Project Exercise 10 - Learning Management System Implementation_ver10.0.mpp)

Last finish 2016-04-28 → 2016-05-18 (+20d). Complete tasks 26 → 136.

Changed:

| ID | Task | Start | Finish | Duration | Complete | Total float |
| --- | --- | --- | --- | --- | --- | --- |
| 10 | **Weekly Review Meeting** |  | 2016-02-29 A |  | 13% → 100% | 42.75d → none |
| 16 | Weekly Review Meeting 6 | 2015-07-06 A | 2015-07-06 A |  | 0% → 100% | 203.75d → none |
| 17 | Weekly Review Meeting 7 | 2015-07-13 A | 2015-07-13 A |  | 0% → 100% | 198.75d → none |
| 18 | Weekly Review Meeting 8 | 2015-07-20 A | 2015-07-20 A |  | 0% → 100% | 193.75d → none |
| 19 | Weekly Review Meeting 9 | 2015-07-27 A | 2015-07-27 A |  | 0% → 100% | 188.75d → none |
| 20 | Weekly Review Meeting 10 | 2015-08-03 A | 2015-08-03 A |  | 0% → 100% | 183.75d → none |
| 21 | Weekly Review Meeting 11 | 2015-08-10 A | 2015-08-10 A |  | 0% → 100% | 178.75d → none |
| 22 | Weekly Review Meeting 12 | 2015-08-17 A | 2015-08-17 A |  | 0% → 100% | 173.75d → none |
| 23 | Weekly Review Meeting 13 | 2015-08-24 A | 2015-08-24 A |  | 0% → 100% | 168.75d → none |
| 24 | Weekly Review Meeting 14 | 2015-08-31 A | 2015-08-31 A |  | 0% → 100% | 163.75d → none |
| 25 | Weekly Review Meeting 15 | 2015-09-08 A | 2015-09-08 A |  | 0% → 100% | 158.75d → none |
| 26 | Weekly Review Meeting 16 | 2015-09-14 A | 2015-09-14 A |  | 0% → 100% | 154.75d → none |
| 27 | Weekly Review Meeting 17 | 2015-09-21 A | 2015-09-21 A |  | 0% → 100% | 149.75d → none |
| 28 | Weekly Review Meeting 18 | 2015-09-28 A | 2015-09-28 A |  | 0% → 100% | 144.75d → none |
| 29 | Weekly Review Meeting 19 | 2015-10-05 A | 2015-10-05 A |  | 0% → 100% | 139.75d → none |
| 30 | Weekly Review Meeting 20 | 2015-10-13 A | 2015-10-13 A |  | 0% → 100% | 134.75d → none |
| 31 | Weekly Review Meeting 21 | 2015-10-19 A | 2015-10-19 A |  | 0% → 100% | 130.75d → none |
| 32 | Weekly Review Meeting 22 | 2015-10-26 A | 2015-10-26 A |  | 0% → 100% | 125.75d → none |
| 33 | Weekly Review Meeting 23 | 2015-11-02 A | 2015-11-02 A |  | 0% → 100% | 120.75d → none |
| 34 | Weekly Review Meeting 24 | 2015-11-09 A | 2015-11-09 A |  | 0% → 100% | 115.75d → none |
| 35 | Weekly Review Meeting 25 | 2015-11-16 A | 2015-11-16 A |  | 0% → 100% | 111.75d → none |
| 36 | Weekly Review Meeting 26 | 2015-11-23 A | 2015-11-23 A |  | 0% → 100% | 106.75d → none |
| 37 | Weekly Review Meeting 27 | 2015-11-30 A | 2015-11-30 A |  | 0% → 100% | 103.75d → none |
| 38 | Weekly Review Meeting 28 | 2015-12-07 A | 2015-12-07 A |  | 0% → 100% | 98.75d → none |
| 39 | Weekly Review Meeting 29 | 2015-12-14 A | 2015-12-14 A |  | 0% → 100% | 93.75d → none |
| 40 | Weekly Review Meeting 30 | 2015-12-21 A | 2015-12-21 A |  | 0% → 100% | 88.75d → none |
| 41 | Weekly Review Meeting 31 | 2015-12-28 A | 2015-12-28 A |  | 0% → 100% | 84.75d → none |
| 42 | Weekly Review Meeting 32 | 2016-01-04 A | 2016-01-04 A |  | 0% → 100% | 80.75d → none |
| 43 | Weekly Review Meeting 33 | 2016-01-11 A | 2016-01-11 A |  | 0% → 100% | 75.75d → none |
| 44 | Weekly Review Meeting 34 | 2016-01-19 A | 2016-01-19 A |  | 0% → 100% | 70.75d → none |
| 45 | Weekly Review Meeting 35 | 2016-01-25 A | 2016-01-25 A |  | 0% → 100% | 66.75d → none |
| 46 | Weekly Review Meeting 36 | 2016-02-01 A | 2016-02-01 A |  | 0% → 100% | 61.75d → none |
| 47 | Weekly Review Meeting 37 | 2016-02-08 A | 2016-02-08 A |  | 0% → 100% | 56.75d → none |
| 48 | Weekly Review Meeting 38 | 2016-02-16 A | 2016-02-16 A |  | 0% → 100% | 51.75d → none |
| 49 | Weekly Review Meeting 39 | 2016-02-22 A | 2016-02-22 A |  | 0% → 100% | 47.75d → none |
| 50 | Weekly Review Meeting 40 | 2016-02-29 A | 2016-02-29 A |  | 0% → 100% | 42.75d → none |
| 51 | **Detailed Design Phase** |  |  |  | 91% → 99% | 158d → 172d |
| 66 | Content Strategy Document (CSD) |  | 2015-09-08 A |  | 40% → 100% | 0d → none |
| 67 | Milestone: Detailed Design Complete | 2015-09-08 A | 2015-09-08 A |  | 0% → 100% | 0d → none |
| 68 | **Implementation Phase** | 2015-09-09 A | 2016-01-12 → 2016-01-19 (+7d) | 84d → 88d | 0% → 99% | 0d → 84d |
| 69 | Testing Server Setup | 2015-09-09 A | 2015-09-10 A |  | 0% → 100% | 89d → none |
| 70 | Development Server Setup | 2015-09-11 A | 2015-09-14 A |  | 0% → 100% | 89d → none |
| 71 | Install: Moodle Test installation | 2015-09-15 A | 2015-09-15 A |  | 0% → 100% | 89d → none |
| 72 | Database design | 2015-09-16 A | 2015-09-22 A |  | 0% → 100% | 89d → none |
| 73 | Doc: Upgrade Strategy Document (USD) | 2015-09-23 A | 2015-09-29 A |  | 0% → 100% | 89d → none |
| 74 | **Moodle: LMS Structure** | 2015-09-30 A | 2015-10-27 → 2015-10-29 A (+2d) | 19d → 21d | 0% → 100% | 89d → none |
| 75 | Home Page | 2015-09-30 A | 2015-10-02 A |  | 0% → 100% | 88d → none |
| 76 | Main Landing Page | 2015-10-05 A | 2015-10-14 → 2015-10-16 A (+2d) | 8d → 10d | 0% → 100% | 88d → none |
| 77 | Institution Landing Pages | 2015-10-15 → 2015-10-19 A (+4d) | 2015-10-21 → 2015-10-23 A (+2d) |  | 0% → 100% | 89d → none |
| 78 | Course Landing Pages | 2015-10-22 → 2015-10-26 A (+4d) | 2015-10-27 → 2015-10-29 A (+2d) |  | 0% → 100% | 89d → none |
| 79 | **Moodle: Course Design and Planning** | 2015-10-28 → 2015-10-30 A (+2d) | 2015-11-12 → 2015-11-16 A (+4d) |  | 0% → 100% | 89d → none |
| 80 | Courses Upload | 2015-10-28 → 2015-10-30 A (+2d) | 2015-11-03 → 2015-11-05 A (+2d) |  | 0% → 100% | 89d → none |
| 81 | Courses Structuring | 2015-11-04 → 2015-11-06 A (+2d) | 2015-11-09 → 2015-11-11 A (+2d) |  | 0% → 100% | 89d → none |
| 82 | Courses Support Material Upload | 2015-11-10 → 2015-11-12 A (+2d) | 2015-11-12 → 2015-11-16 A (+4d) |  | 0% → 100% | 89d → none |
| 83 | **Moodle: Course Creation** | 2015-11-13 → 2015-11-17 A (+4d) | 2015-11-30 → 2015-12-02 A (+2d) |  | 0% → 100% | 90d → none |
| 84 | Course Space Creation | 2015-11-13 → 2015-11-17 A (+4d) | 2015-11-19 → 2015-11-23 A (+4d) |  | 0% → 100% | 90d → none |
| 85 | Course Pages | 2015-11-20 → 2015-11-24 A (+4d) | 2015-11-25 → 2015-11-27 A (+2d) |  | 0% → 100% | 90d → none |
| 86 | Assessment Requirements | 2015-11-26 → 2015-11-30 A (+4d) | 2015-11-30 → 2015-12-02 A (+2d) |  | 0% → 100% | 90d → none |
| 87 | **Moodle: Performance and Control Considerations** | 2015-12-01 → 2015-12-03 A (+2d) | 2015-12-16 → 2015-12-22 A (+6d) | 12d → 13.25d | 0% → 100% | 91d → none |
| 88 | Automated and Manual Communications setup | 2015-12-01 → 2015-12-03 A (+2d) | 2015-12-07 → 2015-12-11 A (+4d) | 5d → 6.25d | 0% → 100% | 91d → none |
| 89 | Support Pages Configuration | 2015-12-08 → 2015-12-11 A (+3d) | 2015-12-11 → 2015-12-17 A (+6d) |  | 0% → 100% | 91d → none |
| 90 | Course Release Strategy | 2015-12-14 → 2015-12-17 A (+3d) | 2015-12-16 → 2015-12-22 A (+6d) |  | 0% → 100% | 91d → none |
| 91 | **LMS User Experience** | 2015-09-09 A | 2015-10-26 A |  | 0% → 100% | 51d → none |
| 92 | Doc: UX Design document (UXD) | 2015-09-09 A | 2015-09-15 A |  | 0% → 100% | 52d → none |
| 93 | Review: UXD | 2015-09-16 A | 2015-09-17 A |  | 0% → 100% | 52d → none |
| 94 | Signoff: UXD | 2015-09-18 A | 2015-09-21 A |  | 0% → 100% | 52d → none |
| 95 | Custom Theme Development | 2015-09-22 A | 2015-10-05 A |  | 0% → 100% | 52d → none |
| 96 | Department-wide custom themes | 2015-10-06 A | 2015-10-12 A |  | 0% → 100% | 52d → none |
| 97 | Logo and Branding requirements | 2015-10-13 A | 2015-10-19 A |  | 0% → 100% | 51d → none |
| 98 | Marketing UX reqts | 2015-10-20 A | 2015-10-26 A |  | 0% → 100% | 51d → none |

| ID | Task | Start | Finish | Duration | Complete | Total float | Other |
| --- | --- | --- | --- | --- | --- | --- | --- |
| 99 | Milestone: UX complete | 2015-10-26 A | 2015-10-26 A |  | 0% → 100% | 51d → none |  |
| 100 | **LMS Content Migration** | 2015-09-09 A | 2016-01-12 → 2016-01-19 (+7d) | 84d → 88d | 0% → 99% | 0d → 84d |  |
| 101 | Content Vendor Selection | 2015-09-09 A | 2015-09-15 A |  | 0% → 100% | 0d → none |  |
| 102 | Content Vendor Engage | 2015-09-16 A | 2015-09-22 A |  | 0% → 100% | 0d → none |  |
| 103 | Migrate SCORM Content | 2015-09-23 A | 2015-10-06 A |  | 0% → 100% | 0d → none |  |
| 104 | Vendor: New Content Creation | 2015-10-07 A | 2015-12-29 A |  | 0% → 100% | 0d → none | was named Vendonr: New Content Creation |
| 105 | Vendor: New content Upload | 2015-12-30 A | 2016-01-12 → 2016-01-19 A (+7d) | 10d → 15d | 0% → 100% | 0d → none |  |
| 106 | Milestone: Migration done | 2016-01-12 → 2016-01-19 (+7d) | 2016-01-12 → 2016-01-19 (+7d) |  |  | 0d → 84d |  |
| 107 | **Mobile App Development** | 2015-09-30 A | 2015-12-22 A |  | 0% → 100% | 13d → none |  |
| 108 | Mobile Dev Vendor Selection | 2015-09-30 A | 2015-10-06 A |  | 0% → 100% | 14d → none |  |
| 109 | Requirements and signoff | 2015-10-07 A | 2015-10-20 A |  | 0% → 100% | 14d → none |  |
| 110 | Notifications | 2015-10-21 A | 2015-10-26 A |  | 0% → 100% | 14d → none |  |
| 111 | Calendar | 2015-10-27 A | 2015-10-28 A |  | 0% → 100% | 14d → none |  |
| 112 | Quiz Engine | 2015-10-29 A | 2015-11-18 A |  | 0% → 100% | 13d → none |  |
| 113 | Annual Time Table | 2015-11-19 A | 2015-11-20 A |  | 0% → 100% | 13d → none |  |
| 114 | Messaging | 2015-11-23 A | 2015-11-27 A |  | 0% → 100% | 13d → none |  |
| 115 | Social Integration | 2015-11-30 A | 2015-12-01 A |  | 0% → 100% | 15d → none |  |
| 116 | Usability Testing | 2015-12-02 A | 2015-12-08 A |  | 0% → 100% | 14d → none |  |
| 117 | Functional Testing | 2015-12-09 A | 2015-12-15 A |  | 0% → 100% | 13d → none |  |
| 118 | Integration testing | 2015-12-16 A | 2015-12-22 A |  | 0% → 100% | 13d → none |  |
| 119 | Milestone: Mobile dev complete | 2015-12-22 A | 2015-12-22 A |  | 0% → 100% | 13d → none |  |
| 120 | **Testing Plan and Setup** | 2015-10-22 A | 2015-12-09 → 2015-12-16 A (+7d) | 32d → 37d | 0% → 100% | 22d → none |  |
| 121 | Doc: Test Specification Document (TSD) | 2015-10-22 A | 2015-11-04 → 2015-11-11 A (+7d) | 2w → 3w | 0% → 100% | 21d → none |  |
| 122 | Test team setup | 2015-11-05 → 2015-11-12 A (+7d) | 2015-11-11 → 2015-11-18 A (+7d) |  | 0% → 100% | 21d → none |  |
| 123 | Review: TSD | 2015-11-12 → 2015-11-19 A (+7d) | 2015-11-16 → 2015-11-23 A (+7d) |  | 0% → 100% | 22d → none |  |
| 124 | Signoff: TSD | 2015-11-17 → 2015-11-24 A (+7d) | 2015-11-18 → 2015-11-25 A (+7d) |  | 0% → 100% | 22d → none |  |
| 125 | Content Test Strategy | 2015-11-19 → 2015-11-26 A (+7d) | 2015-12-02 → 2015-12-09 A (+7d) |  | 0% → 100% | 22d → none |  |
| 126 | Usability Test Strategy | 2015-12-03 → 2015-12-10 A (+7d) | 2015-12-09 → 2015-12-16 A (+7d) |  | 0% → 100% | 22d → none |  |
| 127 | Milestone: Implementation Complete | 2016-01-12 → 2016-01-19 A (+7d) | 2016-01-12 → 2016-01-19 A (+7d) |  | 0% → 100% | 0d → none |  |
| 128 | **Integration Phase** | 2016-01-13 → 2016-01-20 A (+7d) | 2016-03-28 → 2016-04-04 A (+7d) | 52d → 53d | 0% → 100% | 0d → none |  |
| 129 | Single Sign On (SSO) Setup | 2016-01-13 → 2016-01-20 A (+7d) | 2016-01-15 → 2016-01-22 A (+7d) |  | 0% → 100% | 0d → none |  |
| 130 | Student Information System (SIS) Setup | 2016-01-18 → 2016-01-25 A (+7d) | 2016-01-22 → 2016-01-29 A (+7d) |  | 0% → 100% | 1d → none |  |
| 131 | Datewarehousing Integration (Learning Analytics) | 2016-01-25 → 2016-02-01 A (+7d) | 2016-02-05 → 2016-02-12 A (+7d) |  | 0% → 100% | 2d → none |  |
| 132 | SAP Integration | 2016-02-08 → 2016-02-15 A (+7d) | 2016-02-26 → 2016-03-04 A (+7d) |  | 0% → 100% | 2d → none |  |
| 133 | Accounting Software Setup | 2016-02-29 → 2016-03-07 A (+7d) | 2016-03-04 → 2016-03-11 A (+7d) |  | 0% → 100% | 2d → none |  |
| 134 | **STAGING SERVER SETUP** | 2016-03-07 → 2016-03-14 A (+7d) | 2016-03-28 → 2016-04-04 A (+7d) |  | 0% → 100% | 2d → none |  |
| 135 | Server setup, Redundancy setup | 2016-03-07 → 2016-03-14 A (+7d) | 2016-03-09 → 2016-03-16 A (+7d) |  | 0% → 100% | 2d → none |  |
| 136 | Database Configuration | 2016-03-10 → 2016-03-17 A (+7d) | 2016-03-14 → 2016-03-21 A (+7d) |  | 0% → 100% | 2d → none |  |
| 137 | LMS Installation | 2016-03-15 → 2016-03-22 A (+7d) | 2016-03-16 → 2016-03-23 A (+7d) |  | 0% → 100% | 2d → none |  |
| 138 | Course Data Migration | 2016-03-17 → 2016-03-24 A (+7d) | 2016-03-21 → 2016-03-28 A (+7d) |  | 0% → 100% | 2d → none |  |
| 139 | Student Data Import | 2016-03-22 → 2016-03-29 A (+7d) | 2016-03-24 → 2016-03-31 A (+7d) |  | 0% → 100% | 2d → none |  |
| 140 | RBAC Setup and testing | 2016-03-25 → 2016-04-01 A (+7d) | 2016-03-28 → 2016-04-04 A (+7d) |  | 0% → 100% | 2d → none |  |
| 141 | Milestone: Integration Phase Complete | 2016-03-28 → 2016-04-04 A (+7d) | 2016-03-28 → 2016-04-04 A (+7d) |  | 0% → 100% | 2d → none |  |
| 142 | **VERIFICATION and STAGING** | 2015-10-28 → 2015-11-02 A (+5d) | 2016-04-19 → 2016-04-28 (+9d) | 117d → 121d | 0% → 92% | 7d → 14d |  |
| 143 | Unit Testing of all modules | 2015-10-28 → 2015-11-02 A (+5d) | 2015-12-22 → 2015-12-25 A (+3d) |  | 0% → 100% | 6d → none |  |
| 144 | Functional Testing | 2015-12-23 → 2015-12-28 A (+5d) | 2016-01-12 → 2016-01-15 A (+3d) |  | 0% → 100% | 6d → none |  |
| 145 | Installation and Deploy Testing | 2016-01-13 → 2016-01-18 A (+5d) | 2016-01-26 → 2016-01-29 A (+3d) |  | 0% → 100% | 6d → none |  |
| 146 | Performance Testing | 2016-01-27 → 2016-02-01 A (+5d) | 2016-02-09 → 2016-02-12 A (+3d) |  | 0% → 100% | 6d → none |  |
| 147 | Usability Testing | 2016-02-10 → 2016-02-15 A (+5d) | 2016-02-23 → 2016-02-26 A (+3d) |  | 0% → 100% | 6d → none |  |
| 148 | Alpha Testing | 2016-02-24 → 2016-02-29 A (+5d) | 2016-03-08 → 2016-03-18 A (+10d) | 2w → 3w | 0% → 100% | 7d → none |  |
| 149 | UAT Scripting | 2016-03-09 → 2016-03-21 A (+12d) | 2016-03-22 → 2016-04-15 (+24d) |  | 0% → 90% | 7d → 23d |  |
| 150 | UAT cases review and approval | 2016-03-23 → 2016-04-01 A (+9d) | 2016-04-05 → 2016-04-14 A (+9d) |  | 0% → 100% | 7d → none |  |
| 151 | User Acceptance Testing | 2016-04-06 → 2016-04-15 (+9d) | 2016-04-19 → 2016-04-28 (+9d) |  |  | 7d → 13d |  |
| 152 | Milestone: Testing Complete | 2016-04-19 → 2016-04-28 (+9d) | 2016-04-19 → 2016-04-28 (+9d) |  |  | 7d → 14d |  |
| 153 | **PRODUCTION DEPLOYMENT** | 2016-03-29 → 2016-04-05 A (+7d) | 2016-04-26 → 2016-05-03 (+7d) |  | 0% → 38% | 2d → 11d |  |
| 154 | Hardware, Software, Database Setup, Configuration | 2016-03-29 → 2016-04-05 A (+7d) | 2016-04-04 → 2016-04-11 A (+7d) |  | 0% → 100% | 2d → none |  |
| 155 | Course Data Migration | 2016-04-05 → 2016-04-12 A (+7d) | 2016-04-12 → 2016-04-19 (+7d) |  | 0% → 50% | 2d → 11d |  |
| 156 | Student Data Migration | 2016-04-13 → 2016-04-20 (+7d) | 2016-04-18 → 2016-04-25 (+7d) |  |  | 2d → 11d |  |
| 157 | Course Creation - all Colleges | 2016-04-19 → 2016-04-26 (+7d) | 2016-04-25 → 2016-05-02 (+7d) |  |  | 2d → 11d |  |
| 158 | Roles and Accounts | 2016-04-26 → 2016-05-03 (+7d) | 2016-04-26 → 2016-05-03 (+7d) |  |  | 2d → 11d |  |
| 159 | Milestone: Prod Deploy Complete | 2016-04-26 → 2016-05-03 (+7d) | 2016-04-26 → 2016-05-03 (+7d) |  |  | 2d → 11d |  |
| 160 | **Maintenance Handover** | 2016-02-11 → 2016-02-18 A (+7d) | 2016-04-28 → 2016-05-18 (+20d) | 54d → 64d | 0% → 57% |  |  |
| 161 | Training Calendar | 2016-02-11 → 2016-02-18 A (+7d) | 2016-02-15 → 2016-02-22 A (+7d) |  | 0% → 100% | 0d → none |  |
| 162 | Maintenance Vendor Selection | 2016-02-16 → 2016-02-23 A (+7d) | 2016-03-14 → 2016-03-21 A (+7d) |  | 0% → 100% | 0d → none |  |
| 163 | Maintenance Vendor Engagement | 2016-03-15 → 2016-03-22 A (+7d) | 2016-03-21 → 2016-03-28 A (+7d) |  | 0% → 100% | 0d → none |  |
| 164 | User Manual | 2016-03-22 → 2016-03-29 A (+7d) | 2016-04-04 → 2016-04-28 (+24d) | 10d → 16.67d | 0% → 40% |  |  |
| 165 | Administration Manual | 2016-04-05 → 2016-04-11 A (+6d) | 2016-04-18 → 2016-05-06 (+18d) |  | 0% → 40% |  |  |
| 166 | Techno Functional Handover | 2016-04-19 → 2016-05-09 (+20d) | 2016-04-21 → 2016-05-11 (+20d) |  |  |  |  |
| 167 | Training Org Wide | 2016-04-22 → 2016-05-12 (+20d) | 2016-04-28 → 2016-05-18 (+20d) |  |  |  |  |
| 168 | **BUGZILLA** | 2016-04-22 → 2016-05-12 (+20d) | 2016-04-28 → 2016-05-18 (+20d) |  |  |  |  |

| ID | Task | Start | Finish |
| --- | --- | --- | --- |
| 169 | Issue Tracking BUGZILLA installation | 2016-04-22 → 2016-05-12 (+20d) | 2016-04-25 → 2016-05-13 (+18d) |
| 170 | Bugzilla accounts, training and access handover | 2016-04-26 → 2016-05-16 (+20d) | 2016-04-28 → 2016-05-18 (+20d) |
| 171 | Milestone: Project Complete | 2016-04-28 → 2016-05-18 (+20d) | 2016-04-28 → 2016-05-18 (+20d) |
